# Ekushey Bhaban Master Plan3

How a schedule from MS Project changed from version to version. A marks actual dates.

## Version 1 (data date 2010-08-26, saved 2011-02-01, file 01.Ekushey Bhaban Master Program (Rev-0.0) 01 Oct 2010.mpp)

| ID | WBS | Task | Duration | Start | Finish | Predecessors | Complete | Total float | Constraint |
| --- | --- | --- | --- | --- | --- | --- | --- | --- | --- |
| 1 | 1 | **EKUSHEY BHABAN** | 862d | 2010-03-26 A | 2012-09-11 |  | 6% | 0d |  |
| 2 | 1.1 | **PRELIMINARIES** | 846d | 2010-03-26 A | 2012-08-20 |  | 32% | 16d |  |
| 3 | 1.1.1 | **MOBILIZATION-1-TEMPORARY OFFICE-SHED** | 22d | 2010-03-26 A | 2010-04-16 A |  | 100% |  |  |
| 4 |  | Mud Tank | 9d | 2010-03-26 A | 2010-04-03 A |  | 100% |  |  |
| 5 |  | Land Development | 4d | 2010-04-04 A | 2010-04-07 A | 4 | 100% |  |  |
| 6 |  | Office Shed | 4d | 2010-04-08 A | 2010-04-11 A | 5 | 100% |  |  |
| 7 |  | Labour Shed | 4d | 2010-04-08 A | 2010-04-11 A | 6SS | 100% |  |  |
| 8 |  | Cement Store | 4d | 2010-04-08 A | 2010-04-11 A | 6SS | 100% |  |  |
| 9 |  | Staff Residence | 4d | 2010-04-08 A | 2010-04-11 A | 6SS | 100% |  |  |
| 10 |  | Toilet | 7d | 2010-04-08 A | 2010-04-14 A | 6SS | 100% |  |  |
| 11 |  | Main Gate-1 | 7d | 2010-04-04 A | 2010-04-10 A | 4 | 100% |  |  |
| 12 |  | Electrical Wiring | 2d | 2010-04-15 A | 2010-04-16 A | 10 | 100% |  |  |
| 13 | 1.1.2 | **MOBILIZATION-2 -INFRASTRUCTURE** | 15d | 2010-08-11 A | 2010-08-25 |  | 89% | 701d |  |
| 14 |  | East Side Bed Preparation | 2d | 2010-08-11 A | 2010-08-12 A | 54FS-5d | 100% |  |  |
| 15 |  | Labour Shed & Kitchen Making | 9d | 2010-08-12 A | 2010-08-20 | 14FS-1d | 90% | 706d |  |
| 16 |  | South Side Bed Preparation | 3d | 2010-08-12 A | 2010-08-14 A | 14FS-1d | 100% |  |  |
| 17 |  | Cement Shed, Residence, Office & Toilet Making | 8d | 2010-08-13 A | 2010-08-20 | 16SS+1d | 85% | 706d |  |
| 18 |  | North Side Bed Preparation | 4d | 2010-08-22 A | 2010-08-25 A | 17FS+1d | 100% |  |  |
| 19 |  | Soling, CC for Woking Bed | 3d | 2010-08-23 A | 2010-08-25 A | 18FF | 100% |  |  |
| 20 |  | West Side Bed Preparation | 3d | 2010-08-15 A | 2010-08-17 A | 16 | 100% |  |  |
| 21 |  | Security Room Making | 7d | 2010-08-16 A | 2010-08-22 | 20FS-2d | 90% | 704d |  |
| 22 |  | Water Tank Tower Making & Shifting of Water Line From West to Est | 9d | 2010-08-12 A | 2010-08-20 A | 14SS+1d | 100% |  |  |
| 23 |  | Rain Water Drainage System (South) | 8d | 2010-08-13 A | 2010-08-20 A | 16SS+1d | 100% |  |  |
| 24 |  | Rain Water Drainage System (East) | 9d | 2010-08-12 A | 2010-08-20 A | 14FS-1d, 23FF | 100% |  |  |
| 25 |  | Water Reservoir Making (North) | 4d | 2010-08-22 A | 2010-08-25 A | 18FF | 100% |  |  |
| 26 |  | Generator Base Making | 8d | 2010-08-13 A | 2010-08-20 A | 23SS | 100% |  |  |
| 27 |  | Electrical Pipe Wiring | 6d | 2010-08-20 | 2010-08-25 | 26FS-1d |  | 726d |  |
| 28 | 1.1.3 | **MOBILIZATION-3-GENERATOR & TOWER CRANE** | 33d | 2010-07-29 | 2010-08-30 |  |  | 699d |  |
| 29 | 1.1.3.1 | **Generator** | 33d | 2010-07-29 | 2010-08-30 |  |  | 699d |  |
| 30 |  | Supply | 30d | 2010-07-29 | 2010-08-27 | 31FF-3d |  | 724d |  |
| 31 |  | Installation | 3d | 2010-08-28 | 2010-08-30 | 26FS+7d |  | 721d |  |
| 32 | 1.1.4 | **PREPARTION FOR STRUCTURAL CONSTRUCTION** | 117d | 2010-08-21 | 2010-12-30 |  |  | 0d |  |
| 33 |  | Selection of Civil Contractor | 35d | 2010-08-21 | 2010-10-01 | 54 |  | 0d | finish no earlier than 2010-10-01 |
| 34 |  | Develop of Construction Method | 30d | 2010-09-02 | 2010-10-08 | 33FF+7d |  | 672d |  |
| 35 |  | Selection of Ready-mix Supplier | 7d | 2010-09-17 | 2010-09-23 | 34SS+8d |  | 687d |  |
| 36 |  | Structural Design Vetting From BUET | 45d | 2010-08-25 | 2010-10-15 |  |  | 11d | start no earlier than 2010-08-25 |
| 37 |  | Drill Work for Safety | 2d | 2010-11-30 | 2010-12-01 | 63FF |  | 626d |  |
| 38 |  | Selection & Agreement With Clinic for Medical Service | 7d | 2010-10-09 | 2010-10-15 | 36FF |  | 660d |  |
| 39 |  | Design Collection & Estimation of Structural Cost | 20d | 2010-11-04 | 2010-12-01 | 63FF |  | 626d |  |
| 40 |  | Selection of MEP Contractor | 10d | 2010-12-21 | 2010-12-30 | 74FF-15d |  | 597d |  |
| 41 | 1.1.5 | **MOBILIZATION-4-TOWER CRANE** | 32d | 2011-09-23 | 2011-10-24 |  |  | 307d |  |
| 42 |  | Selection | 15d | 2011-09-23 | 2011-10-08 | 43SF |  | 324d |  |
| 43 |  | Foundation | 3d | 2011-10-08 | 2011-10-11 | 44SF-7d |  | 321d |  |
| 44 |  | Installation | 7d | 2011-10-18 | 2011-10-24 | 523 |  | 307d |  |
| 45 | 1.1.6 | **MOBILIZATION-5-LIFTING HOIST** | 7d | 2012-05-17 | 2012-05-23 |  |  | 103d |  |
| 46 |  | Lifting Hoist Installation | 7d | 2012-05-17 | 2012-05-23 | 905 |  | 103d |  |
| 47 | 1.1.7 | **DEMOBILIZATION** | 78d | 2012-06-02 | 2012-08-20 |  |  | 0d |  |
| 48 |  | Dismantling Tower Crane | 2d | 2012-06-02 | 2012-06-03 | 896 |  | 9d |  |
| 49 |  | Dismatle Lifting Hoist | 2d | 2012-08-02 | 2012-08-03 | 907 |  | 0d |  |
| 50 |  | Dismantling Infrastructure | 15d | 2012-08-04 | 2012-08-20 | 49 |  | 0d |  |
| 51 | 1.2 | **SUB-STRUCTURE** | 375d | 2010-04-18 A | 2011-05-12 |  | 22% | 464d |  |
| 52 | 1.2.1 | **PART-1** | 120d | 2010-04-18 A | 2010-08-15 A |  | 100% |  |  |
| 53 |  | SHORE PILING (50 ft) | 100d | 2010-04-18 A | 2010-07-26 A | 3FS+1d | 100% |  |  |
| 54 | 1.2.1.2 | **PERIMETER BEAM** | 20d | 2010-07-27 A | 2010-08-15 A |  | 100% |  |  |
| 55 |  | Excavation for PileHead Breaking | 15d | 2010-07-27 A | 2010-08-10 A | 53 | 100% |  |  |
| 56 |  | Pile Head Breaking | 15d | 2010-07-29 A | 2010-08-12 A | 55SS+2d | 100% |  |  |
| 57 |  | Re bar Work & Concreting | 16d | 2010-07-31 A | 2010-08-15 A | 56SS+2d | 100% |  |  |
| 58 | 1.2.2 | **PART-2** | 215d | 2010-10-02 | 2011-05-12 |  |  | 0d |  |
| 59 | 1.2.2.1 | **EXCAVATION** | 83d | 2010-10-02 | 2010-12-31 |  |  | 0d |  |
| 60 |  | Mobilization-1 (Equipment) | 5d | 2010-10-02 | 2010-10-06 | 33 |  | 0d |  |
| 61 |  | Mobilization-2(Bracing) | 15d | 2010-10-02 | 2010-10-16 | 60SS |  | 68d |  |
| 62 |  | Excavation-Part-1 | 18d | 2010-10-04 | 2010-10-21 | 60SS+2d |  | 0d |  |
| 63 |  | Bracing | 34d | 2010-10-21 | 2010-12-01 | 62FS-1d |  | 0d |  |
| 64 |  | Excvation- Part-2 | 59d | 2010-10-26 | 2010-12-31 | 63SS+5d, 36FS-6d |  | 0d |  |
| 65 | 1.2.2.2 | **Mat Foundation** | 45d | 2010-12-25 | 2011-02-07 |  |  | 0d |  |
| 66 | 1.2.2.2.1 | **Part-1** | 23d | 2010-12-25 | 2011-01-16 |  |  | 0d |  |
| 67 |  | Bed Preparation | 7d | 2010-12-25 | 2010-12-31 | 59FS-7d |  | 0d |  |
| 68 |  | 2-Layer Polythene | 1d | 2011-01-01 | 2011-01-01 | 67 |  | 22d |  |
| 69 |  | Lean Concrete | 1d | 2011-01-02 | 2011-01-02 | 68 |  | 22d |  |
| 70 |  | Peripherial Brick Work | 1d | 2011-01-03 | 2011-01-03 | 69 |  | 22d |  |

| ID | WBS | Task | Duration | Start | Finish | Predecessors | Total float |
| --- | --- | --- | --- | --- | --- | --- | --- |
| 71 |  | Plaster | 1d | 2011-01-04 | 2011-01-04 | 70 | 22d |
| 72 |  | Water Proofing | 2d | 2011-01-08 | 2011-01-09 | 71FS+3d | 22d |
| 73 |  | Re-Bar Fabrication | 4d | 2011-01-10 | 2011-01-13 | 72 | 22d |
| 74 |  | MEP Works | 1d | 2011-01-14 | 2011-01-14 | 73 | 22d |
| 75 |  | Inspection | 1d | 2011-01-15 | 2011-01-15 | 74, 73 | 22d |
| 76 |  | Concreteing | 1d | 2011-01-16 | 2011-01-16 | 75 | 22d |
| 77 | 1.2.2.2.2 | **Part-2** | 24d | 2011-01-01 | 2011-01-24 |  | 0d |
| 78 |  | Bed Preparation | 8d | 2011-01-01 | 2011-01-08 | 67 | 0d |
| 79 |  | 2-Layer Polythene | 1d | 2011-01-09 | 2011-01-09 | 78 | 14d |
| 80 |  | Lean Concrete | 1d | 2011-01-10 | 2011-01-10 | 79 | 14d |
| 81 |  | Peripherial Brick Work | 1d | 2011-01-11 | 2011-01-11 | 80 | 14d |
| 82 |  | Plaster | 1d | 2011-01-12 | 2011-01-12 | 81 | 14d |
| 83 |  | Water Proofing | 2d | 2011-01-16 | 2011-01-17 | 82FS+3d | 14d |
| 84 |  | Re-Bar Fabrication | 4d | 2011-01-18 | 2011-01-21 | 83 | 14d |
| 85 |  | MEP Works | 1d | 2011-01-22 | 2011-01-22 | 84 | 14d |
| 86 |  | Inspection | 1d | 2011-01-23 | 2011-01-23 | 84, 85 | 14d |
| 87 |  | Concreteing | 1d | 2011-01-24 | 2011-01-24 | 86 | 14d |
| 88 | 1.2.2.2.3 | **Part-3** | 23d | 2011-01-09 | 2011-01-31 |  | 0d |
| 89 |  | Bed Preparation | 7d | 2011-01-09 | 2011-01-15 | 78 | 0d |
| 90 |  | 2-Layer Polythene | 1d | 2011-01-16 | 2011-01-16 | 89 | 7d |
| 91 |  | Lean Concrete | 1d | 2011-01-17 | 2011-01-17 | 90 | 7d |
| 92 |  | Peripherial Brick Work | 1d | 2011-01-18 | 2011-01-18 | 91 | 7d |
| 93 |  | Plaster | 1d | 2011-01-19 | 2011-01-19 | 92 | 7d |
| 94 |  | Water Proofing | 2d | 2011-01-23 | 2011-01-24 | 93FS+3d | 7d |
| 95 |  | Re-Bar Fabrication | 4d | 2011-01-25 | 2011-01-28 | 94 | 7d |
| 96 |  | MEP Works | 1d | 2011-01-29 | 2011-01-29 | 95 | 7d |
| 97 |  | Inspection | 1d | 2011-01-30 | 2011-01-30 | 95, 96 | 7d |
| 98 |  | Concreteing | 1d | 2011-01-31 | 2011-01-31 | 97 | 7d |
| 99 | 1.2.2.2.4 | **Part-4** | 23d | 2011-01-16 | 2011-02-07 |  | 0d |
| 100 |  | Bed Preparation | 7d | 2011-01-16 | 2011-01-22 | 89 | 0d |
| 101 |  | 2-Layer Polythene | 1d | 2011-01-23 | 2011-01-23 | 100 | 0d |
| 102 |  | Lean Concrete | 1d | 2011-01-24 | 2011-01-24 | 101 | 0d |
| 103 |  | Peripherial Brick Work | 1d | 2011-01-25 | 2011-01-25 | 102 | 0d |
| 104 |  | Plaster | 1d | 2011-01-26 | 2011-01-26 | 103 | 0d |
| 105 |  | Water Proofing | 2d | 2011-01-30 | 2011-01-31 | 104FS+3d | 0d |
| 106 |  | Re-Bar Fabrication | 4d | 2011-02-01 | 2011-02-04 | 105 | 0d |
| 107 |  | MEP Works | 1d | 2011-02-05 | 2011-02-05 | 106 | 0d |
| 108 |  | Inspection | 1d | 2011-02-06 | 2011-02-06 | 106, 107 | 0d |
| 109 |  | Concreteing | 1d | 2011-02-07 | 2011-02-07 | 108 | 0d |
| 110 | 1.2.2.3 | **BASEMENT-3** | 45d | 2011-02-08 | 2011-03-24 |  | 0d |
| 111 | 1.2.2.3.1 | **PART-1** | 24d | 2011-02-08 | 2011-03-03 |  | 0d |
| 112 | 1.2.2.3.1.1 | **Retaining Wall** | 16d | 2011-02-08 | 2011-02-23 |  | 0d |
| 113 |  | Brick Wall | 2d | 2011-02-08 | 2011-02-09 | 65 | 0d |
| 114 |  | Plaster | 1d | 2011-02-10 | 2011-02-10 | 113 | 0d |
| 115 |  | Water Proofing | 1d | 2011-02-17 | 2011-02-17 | 114FF+7d | 0d |
| 116 |  | Re-bar Work | 3d | 2011-02-18 | 2011-02-20 | 115 | 0d |
| 117 |  | Form Work | 2d | 2011-02-20 | 2011-02-21 | 116FF+1d | 0d |
| 118 |  | Conreting | 1d | 2011-02-22 | 2011-02-22 | 117FF+1d | 0d |
| 119 |  | De-shuttering | 1d | 2011-02-23 | 2011-02-23 | 118FF+1d | 0d |
| 120 | 1.2.2.3.1.2 | **Water Reservoir** | 10d | 2011-02-08 | 2011-02-17 |  | 548d |
| 121 | 1.2.2.3.1.2.1 | **Vertical Wall** | 6d | 2011-02-08 | 2011-02-13 |  | 548d |
| 122 |  | Re-bar Work | 3d | 2011-02-08 | 2011-02-10 | 65 | 548d |
| 123 |  | Form Work | 3d | 2011-02-09 | 2011-02-11 | 122FF+1d | 548d |
| 124 |  | Concrete | 2d | 2011-02-11 | 2011-02-12 | 123FF+1d | 548d |
| 125 |  | De Shuttering | 2d | 2011-02-12 | 2011-02-13 | 124FF+1d | 552d |
| 126 | 1.2.2.3.1.2.2 | **Top Slab** | 5d | 2011-02-13 | 2011-02-17 |  | 548d |
| 127 |  | Form Work | 3d | 2011-02-13 | 2011-02-15 | 124 | 548d |
| 128 |  | Re-bar Work | 3d | 2011-02-14 | 2011-02-16 | 127FF+1d | 548d |
| 129 |  | Concrete | 1d | 2011-02-17 | 2011-02-17 | 128FF+1d | 548d |
| 130 | 1.2.2.3.1.3 | **Column** | 8d | 2011-02-08 | 2011-02-15 |  | 8d |
| 131 |  | Re-Bar Work | 2d | 2011-02-08 | 2011-02-09 | 65 | 8d |
| 132 |  | Form Work | 2d | 2011-02-10 | 2011-02-11 | 131 | 8d |
| 133 |  | Concrete | 2d | 2011-02-12 | 2011-02-13 | 132 | 8d |
| 134 |  | De-shuttering | 2d | 2011-02-14 | 2011-02-15 | 133 | 8d |
| 135 | 1.2.2.3.1.4 | **Shear Wall** | 12d | 2011-02-08 | 2011-02-19 |  | 4d |
| 136 |  | Re-Bar Work | 3d | 2011-02-08 | 2011-02-10 | 65 | 4d |
| 137 |  | Form Work | 3d | 2011-02-11 | 2011-02-13 | 136 | 4d |
| 138 |  | Concrete | 3d | 2011-02-14 | 2011-02-16 | 137 | 4d |
| 139 |  | De-shuttering | 3d | 2011-02-17 | 2011-02-19 | 138 | 4d |
| 140 | 1.2.2.3.1.5 | **Stair - 1** | 4d | 2011-02-08 | 2011-02-11 |  | 399d |

| ID | WBS | Task | Duration | Start | Finish | Predecessors | Total float |
| --- | --- | --- | --- | --- | --- | --- | --- |
| 141 | 1.2.2.3.1.5.1 | **1st Flight** | 4d | 2011-02-08 | 2011-02-11 |  | 399d |
| 142 |  | Brick Work | 1d | 2011-02-08 | 2011-02-08 | 65 | 399d |
| 143 |  | Form Work | 1d | 2011-02-09 | 2011-02-09 | 142 | 399d |
| 144 |  | Re-bar Work | 1d | 2011-02-10 | 2011-02-10 | 143 | 399d |
| 145 |  | Concrete | 1d | 2011-02-11 | 2011-02-11 | 144 | 399d |
| 146 | 1.2.2.3.1.6 | **Ramp** | 2d | 2011-02-26 | 2011-02-27 |  | 538d |
| 147 |  | Form Work | 1d | 2011-02-26 | 2011-02-26 | 150FF | 538d |
| 148 |  | Re-Bar | 1d | 2011-02-27 | 2011-02-27 | 147 | 538d |
| 149 | 1.2.2.3.1.7 | **Roof Slab** | 8d | 2011-02-24 | 2011-03-03 |  | 0d |
| 150 |  | Form Work | 3d | 2011-02-24 | 2011-02-26 | 135, 130, 119 | 0d |
| 151 |  | Re-bar | 3d | 2011-02-26 | 2011-02-28 | 150FF+2d | 0d |
| 152 |  | MEP Work | 1d | 2011-03-01 | 2011-03-01 | 151 | 0d |
| 153 |  | Inspection | 1d | 2011-03-02 | 2011-03-02 | 152 | 0d |
| 154 |  | Concrete | 1d | 2011-03-03 | 2011-03-03 | 153 | 0d |
| 155 | 1.2.2.3.2 | **PART-2** | 21d | 2011-03-04 | 2011-03-24 | 154 | 368d |
| 156 | 1.2.2.3.2.1 | **Retaining Wall** | 14d | 2011-03-04 | 2011-03-17 |  | 368d |
| 157 |  | Brick Wall | 2d | 2011-03-04 | 2011-03-05 | 154FF+1d | 368d |
| 158 |  | Plaster | 2d | 2011-03-05 | 2011-03-06 | 157FF+1d | 368d |
| 159 |  | Water Proofing | 2d | 2011-03-12 | 2011-03-13 | 158FF+7d | 368d |
| 160 |  | Re-bar Work | 2d | 2011-03-13 | 2011-03-14 | 159FF+1d | 368d |
| 161 |  | Form Work | 2d | 2011-03-14 | 2011-03-15 | 160FF+1d | 368d |
| 162 |  | Conreting | 2d | 2011-03-15 | 2011-03-16 | 161FF+1d | 368d |
| 163 |  | De-shuttering | 2d | 2011-03-16 | 2011-03-17 | 162FF+1d | 368d |
| 164 | 1.2.2.3.2.2 | **Column** | 5d | 2011-03-04 | 2011-03-08 |  | 377d |
| 165 |  | Re-Bar Work | 2d | 2011-03-04 | 2011-03-05 | 154FF+1d | 377d |
| 166 |  | Form Work | 2d | 2011-03-05 | 2011-03-06 | 165FF+1d | 377d |
| 167 |  | Concrete | 2d | 2011-03-06 | 2011-03-07 | 166FF+1d | 377d |
| 168 |  | De-shuttering | 2d | 2011-03-07 | 2011-03-08 | 167FF+1d | 377d |
| 169 | 1.2.2.3.2.3 | **Shear Wall** | 6d | 2011-03-04 | 2011-03-09 |  | 376d |
| 170 |  | Re-Bar Work | 3d | 2011-03-04 | 2011-03-06 | 154FF+1d | 376d |
| 171 |  | Form Work | 3d | 2011-03-05 | 2011-03-07 | 170FF+1d | 376d |
| 172 |  | Concrete | 3d | 2011-03-06 | 2011-03-08 | 171FF+1d | 376d |
| 173 |  | De-shuttering | 3d | 2011-03-07 | 2011-03-09 | 172FF+1d | 376d |
| 174 | 1.2.2.3.2.4 | **Stair - 1** | 3d | 2011-03-04 | 2011-03-06 |  | 379d |
| 175 | 1.2.2.3.2.4.1 | **2nd Flight** | 3d | 2011-03-04 | 2011-03-06 |  | 379d |
| 176 |  | Brick Work | 1d | 2011-03-04 | 2011-03-04 | 145 | 379d |
| 177 |  | Form Work | 1d | 2011-03-05 | 2011-03-05 | 176FF+1d | 379d |
| 178 |  | Re-bar Work | 1d | 2011-03-06 | 2011-03-06 | 177FF+1d | 379d |
| 179 | 1.2.2.3.2.5 | **Ramp** | 3d | 2011-03-04 | 2011-03-06 |  | 531d |
| 180 |  | Form Work | 1d | 2011-03-04 | 2011-03-04 | 154FF+1d | 531d |
| 181 |  | Re-Bar | 1d | 2011-03-05 | 2011-03-05 | 180FF+1d | 531d |
| 182 |  | Concrete | 1d | 2011-03-06 | 2011-03-06 | 181FF+1d | 531d |
| 183 | 1.2.2.3.2.6 | **Roof Slab** | 7d | 2011-03-18 | 2011-03-24 |  | 368d |
| 184 |  | Form Work | 2d | 2011-03-18 | 2011-03-19 | 156, 164, 169, 174 | 368d |
| 185 |  | Re-bar | 2d | 2011-03-20 | 2011-03-21 | 184FF+2d | 368d |
| 186 |  | MEP Work | 1d | 2011-03-22 | 2011-03-22 | 185 | 368d |
| 187 |  | Inspection | 1d | 2011-03-23 | 2011-03-23 | 186 | 368d |
| 188 |  | Concrete | 1d | 2011-03-24 | 2011-03-24 | 187 | 368d |
| 189 | 1.2.2.4 | **BASEMENT-2** | 45d | 2011-03-04 | 2011-04-17 |  | 0d |
| 190 | 1.2.2.4.1 | **PART-1** | 25d | 2011-03-04 | 2011-03-28 |  | 0d |
| 191 | 1.2.2.4.1.1 | **Retaining Wall** | 18d | 2011-03-04 | 2011-03-21 |  | 0d |
| 192 |  | Brick Wall | 3d | 2011-03-04 | 2011-03-06 | 154 | 0d |
| 193 |  | Plaster | 2d | 2011-03-07 | 2011-03-08 | 192 | 0d |
| 194 |  | Water Proofing | 1d | 2011-03-15 | 2011-03-15 | 193FF+7d | 0d |
| 195 |  | Re-bar Work | 3d | 2011-03-16 | 2011-03-18 | 194 | 0d |
| 196 |  | Form Work | 2d | 2011-03-18 | 2011-03-19 | 195FF+1d | 0d |
| 197 |  | Conreting | 1d | 2011-03-20 | 2011-03-20 | 196FF+1d | 0d |
| 198 |  | De-shuttering | 1d | 2011-03-21 | 2011-03-21 | 197FF+1d | 0d |
| 199 | 1.2.2.4.1.2 | **Column** | 8d | 2011-03-04 | 2011-03-11 |  | 10d |
| 200 |  | Re-Bar Work | 2d | 2011-03-04 | 2011-03-05 | 154 | 10d |
| 201 |  | Form Work | 2d | 2011-03-06 | 2011-03-07 | 200 | 10d |
| 202 |  | Concrete | 2d | 2011-03-08 | 2011-03-09 | 201 | 10d |
| 203 |  | De-shuttering | 2d | 2011-03-10 | 2011-03-11 | 202 | 10d |
| 204 | 1.2.2.4.1.3 | **Shear Wall** | 12d | 2011-03-04 | 2011-03-15 |  | 6d |
| 205 |  | Re-Bar Work | 3d | 2011-03-04 | 2011-03-06 | 154 | 6d |
| 206 |  | Form Work | 3d | 2011-03-07 | 2011-03-09 | 205 | 6d |
| 207 |  | Concrete | 3d | 2011-03-10 | 2011-03-12 | 206 | 6d |
| 208 |  | De-shuttering | 3d | 2011-03-13 | 2011-03-15 | 207 | 6d |
| 209 | 1.2.2.4.1.4 | **Stair - 1** | 4d | 2011-03-25 | 2011-03-28 |  | 368d |
| 210 | 1.2.2.4.1.4.1 | **1st Flight** | 4d | 2011-03-25 | 2011-03-28 |  | 368d |

| ID | WBS | Task | Duration | Start | Finish | Predecessors | Total float |
| --- | --- | --- | --- | --- | --- | --- | --- |
| 211 |  | Brick Work | 1d | 2011-03-25 | 2011-03-25 | 188 | 368d |
| 212 |  | Form Work | 1d | 2011-03-26 | 2011-03-26 | 211 | 368d |
| 213 |  | Re-bar Work | 1d | 2011-03-27 | 2011-03-27 | 212 | 368d |
| 214 |  | Concrete | 1d | 2011-03-28 | 2011-03-28 | 213 | 368d |
| 215 | 1.2.2.4.1.5 | **Ramp** | 2d | 2011-03-23 | 2011-03-24 |  | 513d |
| 216 |  | Form Work | 1d | 2011-03-23 | 2011-03-23 | 219FF | 513d |
| 217 |  | Re-Bar | 1d | 2011-03-24 | 2011-03-24 | 216 | 513d |
| 218 | 1.2.2.4.1.6 | **Roof Slab** | 7d | 2011-03-22 | 2011-03-28 |  | 0d |
| 219 |  | Form Work | 2d | 2011-03-22 | 2011-03-23 | 198, 199, 204 | 0d |
| 220 |  | Re-bar | 2d | 2011-03-24 | 2011-03-25 | 219FF+2d | 0d |
| 221 |  | MEP Work | 1d | 2011-03-26 | 2011-03-26 | 220 | 0d |
| 222 |  | Inspection | 1d | 2011-03-27 | 2011-03-27 | 221 | 0d |
| 223 |  | Concrete | 1d | 2011-03-28 | 2011-03-28 | 222 | 0d |
| 224 | 1.2.2.4.2 | **PART-2** | 22d | 2011-03-27 | 2011-04-17 |  | 359d |
| 225 | 1.2.2.4.2.1 | **Retaining Wall** | 14d | 2011-03-28 | 2011-04-10 |  | 358d |
| 226 |  | Brick Wall | 2d | 2011-03-28 | 2011-03-29 | 223FF+1d | 358d |
| 227 |  | Plaster | 2d | 2011-03-29 | 2011-03-30 | 226FF+1d | 358d |
| 228 |  | Water Proofing | 2d | 2011-04-05 | 2011-04-06 | 227FF+7d | 358d |
| 229 |  | Re-bar Work | 2d | 2011-04-06 | 2011-04-07 | 228FF+1d | 358d |
| 230 |  | Form Work | 2d | 2011-04-07 | 2011-04-08 | 229FF+1d | 358d |
| 231 |  | Conreting | 2d | 2011-04-08 | 2011-04-09 | 230FF+1d | 358d |
| 232 |  | De-shuttering | 2d | 2011-04-09 | 2011-04-10 | 231FF+1d | 358d |
| 233 | 1.2.2.4.2.2 | **Column** | 5d | 2011-03-28 | 2011-04-01 |  | 367d |
| 234 |  | Re-Bar Work | 2d | 2011-03-28 | 2011-03-29 | 223FF+1d | 367d |
| 235 |  | Form Work | 2d | 2011-03-29 | 2011-03-30 | 234FF+1d | 367d |
| 236 |  | Concrete | 2d | 2011-03-30 | 2011-03-31 | 235FF+1d | 367d |
| 237 |  | De-shuttering | 2d | 2011-03-31 | 2011-04-01 | 236FF+1d | 367d |
| 238 | 1.2.2.4.2.3 | **Shear Wall** | 6d | 2011-03-27 | 2011-04-01 |  | 367d |
| 239 |  | Re-Bar Work | 3d | 2011-03-27 | 2011-03-29 | 223FF+1d | 367d |
| 240 |  | Form Work | 3d | 2011-03-28 | 2011-03-30 | 239FF+1d | 367d |
| 241 |  | Concrete | 3d | 2011-03-29 | 2011-03-31 | 240FF+1d | 367d |
| 242 |  | De-shuttering | 3d | 2011-03-30 | 2011-04-01 | 241FF+1d | 367d |
| 243 | 1.2.2.4.2.4 | **Stair - 1** | 3d | 2011-03-29 | 2011-03-31 |  | 368d |
| 244 | 1.2.2.4.2.4.1 | **2nd Flight** | 3d | 2011-03-29 | 2011-03-31 |  | 368d |
| 245 |  | Brick Work | 1d | 2011-03-29 | 2011-03-29 | 214 | 368d |
| 246 |  | Form Work | 1d | 2011-03-30 | 2011-03-30 | 245FF+1d | 368d |
| 247 |  | Re-bar Work | 1d | 2011-03-31 | 2011-03-31 | 246FF+1d | 368d |
| 248 | 1.2.2.4.2.5 | **Ramp** | 3d | 2011-03-29 | 2011-03-31 |  | 506d |
| 249 |  | Form Work | 1d | 2011-03-29 | 2011-03-29 | 223FF+1d | 506d |
| 250 |  | Re-Bar | 1d | 2011-03-30 | 2011-03-30 | 249FF+1d | 506d |
| 251 |  | Concrete | 1d | 2011-03-31 | 2011-03-31 | 250FF+1d | 506d |
| 252 | 1.2.2.4.2.6 | **Roof Slab** | 7d | 2011-04-11 | 2011-04-17 |  | 358d |
| 253 |  | Form Work | 2d | 2011-04-11 | 2011-04-12 | 225, 233, 238, 243 | 358d |
| 254 |  | Re-bar | 2d | 2011-04-13 | 2011-04-14 | 253FF+2d | 358d |
| 255 |  | MEP Work | 1d | 2011-04-15 | 2011-04-15 | 254 | 358d |
| 256 |  | Inspection | 1d | 2011-04-16 | 2011-04-16 | 255 | 358d |
| 257 |  | Concrete | 1d | 2011-04-17 | 2011-04-17 | 256 | 358d |
| 258 | 1.2.2.5 | **BASEMENT-1** | 45d | 2011-03-29 | 2011-05-12 |  | 0d |
| 259 | 1.2.2.5.1 | **PART-1** | 25d | 2011-03-29 | 2011-04-22 |  | 0d |
| 260 | 1.2.2.5.1.1 | **Retaining Wall** | 18d | 2011-03-29 | 2011-04-15 |  | 0d |
| 261 |  | Brick Wall | 3d | 2011-03-29 | 2011-03-31 | 223 | 0d |
| 262 |  | Plaster | 2d | 2011-04-01 | 2011-04-02 | 261 | 0d |
| 263 |  | Water Proofing | 1d | 2011-04-09 | 2011-04-09 | 262FF+7d | 0d |
| 264 |  | Re-bar Work | 3d | 2011-04-10 | 2011-04-12 | 263 | 0d |
| 265 |  | Form Work | 2d | 2011-04-12 | 2011-04-13 | 264FF+1d | 0d |
| 266 |  | Conreting | 1d | 2011-04-14 | 2011-04-14 | 265FF+1d | 0d |
| 267 |  | De-shuttering | 1d | 2011-04-15 | 2011-04-15 | 266FF+1d | 0d |
| 268 | 1.2.2.5.1.2 | **Column** | 8d | 2011-03-29 | 2011-04-05 |  | 10d |
| 269 |  | Re-Bar Work | 2d | 2011-03-29 | 2011-03-30 | 223 | 10d |
| 270 |  | Form Work | 2d | 2011-03-31 | 2011-04-01 | 269 | 10d |
| 271 |  | Concrete | 2d | 2011-04-02 | 2011-04-03 | 270 | 10d |
| 272 |  | De-shuttering | 2d | 2011-04-04 | 2011-04-05 | 271 | 10d |
| 273 | 1.2.2.5.1.3 | **Shear Wall** | 12d | 2011-03-29 | 2011-04-09 |  | 6d |
| 274 |  | Re-Bar Work | 3d | 2011-03-29 | 2011-03-31 | 223 | 6d |
| 275 |  | Form Work | 3d | 2011-04-01 | 2011-04-03 | 274 | 6d |
| 276 |  | Concrete | 3d | 2011-04-04 | 2011-04-06 | 275 | 6d |
| 277 |  | De-shuttering | 3d | 2011-04-07 | 2011-04-09 | 276 | 6d |
| 278 | 1.2.2.5.1.4 | **Stair - 1** | 4d | 2011-03-29 | 2011-04-01 |  | 31d |
| 279 | 1.2.2.5.1.4.1 | **1st Flight** | 4d | 2011-03-29 | 2011-04-01 |  | 31d |
| 280 |  | Brick Work | 1d | 2011-03-29 | 2011-03-29 | 223 | 31d |

| ID | WBS | Task | Duration | Start | Finish | Predecessors | Total float |
| --- | --- | --- | --- | --- | --- | --- | --- |
| 281 |  | Form Work | 1d | 2011-03-30 | 2011-03-30 | 280 | 31d |
| 282 |  | Re-bar Work | 1d | 2011-03-31 | 2011-03-31 | 281 | 31d |
| 283 |  | Concrete | 1d | 2011-04-01 | 2011-04-01 | 282 | 31d |
| 284 | 1.2.2.5.1.5 | **Ramp** | 2d | 2011-04-17 | 2011-04-18 |  | 488d |
| 285 |  | Form Work | 1d | 2011-04-17 | 2011-04-17 | 288FF | 488d |
| 286 |  | Re-Bar | 1d | 2011-04-18 | 2011-04-18 | 285 | 488d |
| 287 | 1.2.2.5.1.6 | **Roof Slab** | 7d | 2011-04-16 | 2011-04-22 |  | 0d |
| 288 |  | Form Work | 2d | 2011-04-16 | 2011-04-17 | 267, 268, 273 | 0d |
| 289 |  | Re-bar | 2d | 2011-04-18 | 2011-04-19 | 288FF+2d | 0d |
| 290 |  | MEP Work | 1d | 2011-04-20 | 2011-04-20 | 289 | 0d |
| 291 |  | Inspection | 1d | 2011-04-21 | 2011-04-21 | 290 | 0d |
| 292 |  | Concrete | 1d | 2011-04-22 | 2011-04-22 | 291 | 0d |
| 293 | 1.2.2.5.2 | **PART-2** | 41d | 2011-04-02 | 2011-05-12 |  | 20d |
| 294 | 1.2.2.5.2.1 | **Retaining Wall** | 14d | 2011-04-22 | 2011-05-05 |  | 0d |
| 295 |  | Brick Wall | 2d | 2011-04-22 | 2011-04-23 | 292FF+1d | 0d |
| 296 |  | Plaster | 2d | 2011-04-23 | 2011-04-24 | 295FF+1d | 0d |
| 297 |  | Water Proofing | 2d | 2011-04-30 | 2011-05-01 | 296FF+7d | 0d |
| 298 |  | Re-bar Work | 2d | 2011-05-01 | 2011-05-02 | 297FF+1d | 0d |
| 299 |  | Form Work | 2d | 2011-05-02 | 2011-05-03 | 298FF+1d | 0d |
| 300 |  | Conreting | 2d | 2011-05-03 | 2011-05-04 | 299FF+1d | 0d |
| 301 |  | De-shuttering | 2d | 2011-05-04 | 2011-05-05 | 300FF+1d | 0d |
| 302 | 1.2.2.5.2.2 | **Column** | 5d | 2011-04-22 | 2011-04-26 |  | 9d |
| 303 |  | Re-Bar Work | 2d | 2011-04-22 | 2011-04-23 | 292FF+1d | 9d |
| 304 |  | Form Work | 2d | 2011-04-23 | 2011-04-24 | 303FF+1d | 9d |
| 305 |  | Concrete | 2d | 2011-04-24 | 2011-04-25 | 304FF+1d | 9d |
| 306 |  | De-shuttering | 2d | 2011-04-25 | 2011-04-26 | 305FF+1d | 9d |
| 307 | 1.2.2.5.2.3 | **Shear Wall** | 6d | 2011-04-21 | 2011-04-26 |  | 9d |
| 308 |  | Re-Bar Work | 3d | 2011-04-21 | 2011-04-23 | 292FF+1d | 9d |
| 309 |  | Form Work | 3d | 2011-04-22 | 2011-04-24 | 308FF+1d | 9d |
| 310 |  | Concrete | 3d | 2011-04-23 | 2011-04-25 | 309FF+1d | 9d |
| 311 |  | De-shuttering | 3d | 2011-04-24 | 2011-04-26 | 310FF+1d | 9d |
| 312 | 1.2.2.5.2.4 | **Stair - 1** | 3d | 2011-04-02 | 2011-04-04 |  | 31d |
| 313 | 1.2.2.5.2.4.1 | **2nd Flight** | 3d | 2011-04-02 | 2011-04-04 |  | 31d |
| 314 |  | Brick Work | 1d | 2011-04-02 | 2011-04-02 | 283 | 31d |
| 315 |  | Form Work | 1d | 2011-04-03 | 2011-04-03 | 314FF+1d | 31d |
| 316 |  | Re-bar Work | 1d | 2011-04-04 | 2011-04-04 | 315FF+1d | 31d |
| 317 | 1.2.2.5.2.5 | **Ramp** | 3d | 2011-04-23 | 2011-04-25 |  | 481d |
| 318 |  | Form Work | 1d | 2011-04-23 | 2011-04-23 | 292FF+1d | 481d |
| 319 |  | Re-Bar | 1d | 2011-04-24 | 2011-04-24 | 318FF+1d | 481d |
| 320 |  | Concrete | 1d | 2011-04-25 | 2011-04-25 | 319FF+1d | 481d |
| 321 | 1.2.2.5.2.6 | **Roof Slab** | 7d | 2011-05-06 | 2011-05-12 |  | 0d |
| 322 |  | Form Work | 2d | 2011-05-06 | 2011-05-07 | 294, 302, 307, 312 | 0d |
| 323 |  | Re-bar | 2d | 2011-05-08 | 2011-05-09 | 322FF+2d | 0d |
| 324 |  | MEP Work | 1d | 2011-05-10 | 2011-05-10 | 323 | 0d |
| 325 |  | Inspection | 1d | 2011-05-11 | 2011-05-11 | 324 | 0d |
| 326 |  | Concrete | 1d | 2011-05-12 | 2011-05-12 | 325 | 0d |
| 327 | 1.3 | **SUPER STRUCTURE** | 370d | 2011-05-13 | 2012-06-01 |  | 0d |
| 328 | 1.3.1 | **GROUND FLOOR** | 25d | 2011-05-13 | 2011-06-06 |  | 0d |
| 329 | 1.3.1.1 | **Column** | 12d | 2011-05-13 | 2011-05-24 |  | 0d |
| 330 | 1.3.1.1.1 | **1ST Lift** | 6d | 2011-05-13 | 2011-05-18 |  | 0d |
| 331 |  | Re-Bar Work | 1d | 2011-05-13 | 2011-05-13 | 326 | 0d |
| 332 |  | Form Work | 1d | 2011-05-14 | 2011-05-14 | 331 | 0d |
| 333 |  | Concrete | 1d | 2011-05-15 | 2011-05-15 | 332 | 0d |
| 334 |  | De-shuttering | 1d | 2011-05-18 | 2011-05-18 | 333FS+2d | 0d |
| 335 | 1.3.1.1.2 | **2nd Lift** | 6d | 2011-05-19 | 2011-05-24 |  | 0d |
| 336 |  | Re-Bar Work | 1d | 2011-05-19 | 2011-05-19 | 334 | 0d |
| 337 |  | Form Work | 1d | 2011-05-20 | 2011-05-20 | 336 | 0d |
| 338 |  | Concrete | 1d | 2011-05-21 | 2011-05-21 | 337 | 0d |
| 339 |  | De-shuttering | 1d | 2011-05-24 | 2011-05-24 | 338FS+2d | 0d |
| 340 | 1.3.1.2 | **Shear Wall** | 12d | 2011-05-13 | 2011-05-24 |  | 0d |
| 341 | 1.3.1.2.1 | **1st Lift** | 6d | 2011-05-13 | 2011-05-18 |  | 0d |
| 342 |  | Re-Bar Work | 1d | 2011-05-13 | 2011-05-13 | 326 | 0d |
| 343 |  | Form Work | 1d | 2011-05-14 | 2011-05-14 | 342 | 0d |
| 344 |  | Concrete | 1d | 2011-05-15 | 2011-05-15 | 343 | 0d |
| 345 |  | De-shuttering | 1d | 2011-05-18 | 2011-05-18 | 344FS+2d | 0d |
| 346 | 1.3.1.2.2 | **2nd Lift** | 6d | 2011-05-19 | 2011-05-24 |  | 0d |
| 347 |  | Re-Bar Work | 1d | 2011-05-19 | 2011-05-19 | 345 | 0d |
| 348 |  | Form Work | 1d | 2011-05-20 | 2011-05-20 | 347 | 0d |
| 349 |  | Concrete | 1d | 2011-05-21 | 2011-05-21 | 348 | 0d |
| 350 |  | De-shuttering | 1d | 2011-05-24 | 2011-05-24 | 349FS+2d | 0d |

| ID | WBS | Task | Duration | Start | Finish | Predecessors | Total float |
| --- | --- | --- | --- | --- | --- | --- | --- |
| 351 | 1.3.1.3 | **Stair - 1 & 2** | 7d | 2011-05-13 | 2011-05-19 |  | 5d |
| 352 | 1.3.1.3.1 | **1st Flight** | 4d | 2011-05-13 | 2011-05-16 |  | 5d |
| 353 |  | Brick Work | 1d | 2011-05-13 | 2011-05-13 | 326 | 5d |
| 354 |  | Form Work | 1d | 2011-05-14 | 2011-05-14 | 353 | 5d |
| 355 |  | Re-bar Work | 1d | 2011-05-15 | 2011-05-15 | 354 | 5d |
| 356 |  | Concrete | 1d | 2011-05-16 | 2011-05-16 | 355 | 5d |
| 357 | 1.3.1.3.2 | **2nd Flight** | 3d | 2011-05-17 | 2011-05-19 |  | 5d |
| 358 |  | Form Work | 1d | 2011-05-17 | 2011-05-17 | 356 | 5d |
| 359 |  | Re-bar | 1d | 2011-05-18 | 2011-05-18 | 358 | 5d |
| 360 |  | Concrete | 1d | 2011-05-19 | 2011-05-19 | 359 | 5d |
| 361 | 1.3.1.4 | **Roof Slab** | 13d | 2011-05-25 | 2011-06-06 |  | 0d |
| 362 |  | Form Work | 5d | 2011-05-25 | 2011-05-29 | 339, 350, 360 | 0d |
| 363 |  | Re-bar | 4d | 2011-05-30 | 2011-06-02 | 362 | 0d |
| 364 |  | MEP Work | 1d | 2011-06-03 | 2011-06-03 | 363 | 0d |
| 365 |  | Inspection | 1d | 2011-06-04 | 2011-06-04 | 364 | 0d |
| 366 |  | Concrete | 2d | 2011-06-05 | 2011-06-06 | 365 | 0d |
| 367 | 1.3.2 | **1ST FLOOR** | 25d | 2011-06-07 | 2011-07-01 |  | 0d |
| 368 | 1.3.2.1 | **Column** | 12d | 2011-06-07 | 2011-06-18 |  | 0d |
| 369 | 1.3.2.1.1 | **1ST Lift** | 6d | 2011-06-07 | 2011-06-12 |  | 0d |
| 370 |  | Re-Bar Work | 1d | 2011-06-07 | 2011-06-07 | 366 | 0d |
| 371 |  | Form Work | 1d | 2011-06-08 | 2011-06-08 | 370 | 0d |
| 372 |  | Concrete | 1d | 2011-06-09 | 2011-06-09 | 371 | 0d |
| 373 |  | De-shuttering | 1d | 2011-06-12 | 2011-06-12 | 372FS+2d | 0d |
| 374 | 1.3.2.1.2 | **2nd Lift** | 6d | 2011-06-13 | 2011-06-18 |  | 0d |
| 375 |  | Re-Bar Work | 1d | 2011-06-13 | 2011-06-13 | 373 | 0d |
| 376 |  | Form Work | 1d | 2011-06-14 | 2011-06-14 | 375 | 0d |
| 377 |  | Concrete | 1d | 2011-06-15 | 2011-06-15 | 376 | 0d |
| 378 |  | De-shuttering | 1d | 2011-06-18 | 2011-06-18 | 377FS+2d | 0d |
| 379 | 1.3.2.2 | **Shear Wall** | 12d | 2011-06-07 | 2011-06-18 |  | 0d |
| 380 | 1.3.2.2.1 | **1st Lift** | 6d | 2011-06-07 | 2011-06-12 |  | 0d |
| 381 |  | Re-Bar Work | 1d | 2011-06-07 | 2011-06-07 | 366 | 0d |
| 382 |  | Form Work | 1d | 2011-06-08 | 2011-06-08 | 381 | 0d |
| 383 |  | Concrete | 1d | 2011-06-09 | 2011-06-09 | 382 | 0d |
| 384 |  | De-shuttering | 1d | 2011-06-12 | 2011-06-12 | 383FS+2d | 0d |
| 385 | 1.3.2.2.2 | **2nd Lift** | 6d | 2011-06-13 | 2011-06-18 |  | 0d |
| 386 |  | Re-Bar Work | 1d | 2011-06-13 | 2011-06-13 | 384 | 0d |
| 387 |  | Form Work | 1d | 2011-06-14 | 2011-06-14 | 386 | 0d |
| 388 |  | Concrete | 1d | 2011-06-15 | 2011-06-15 | 387 | 0d |
| 389 |  | De-shuttering | 1d | 2011-06-18 | 2011-06-18 | 388FS+2d | 0d |
| 390 | 1.3.2.3 | **Stair - 1 & 2** | 7d | 2011-06-07 | 2011-06-13 |  | 5d |
| 391 | 1.3.2.3.1 | **1st Flight** | 4d | 2011-06-07 | 2011-06-10 |  | 5d |
| 392 |  | Brick Work | 1d | 2011-06-07 | 2011-06-07 | 366 | 5d |
| 393 |  | Form Work | 1d | 2011-06-08 | 2011-06-08 | 392 | 5d |
| 394 |  | Re-bar Work | 1d | 2011-06-09 | 2011-06-09 | 393 | 5d |
| 395 |  | Concrete | 1d | 2011-06-10 | 2011-06-10 | 394 | 5d |
| 396 | 1.3.2.3.2 | **2nd Flight** | 3d | 2011-06-11 | 2011-06-13 |  | 5d |
| 397 |  | Form Work | 1d | 2011-06-11 | 2011-06-11 | 395 | 5d |
| 398 |  | Re-bar | 1d | 2011-06-12 | 2011-06-12 | 397 | 5d |
| 399 |  | Concrete | 1d | 2011-06-13 | 2011-06-13 | 398 | 5d |
| 400 | 1.3.2.4 | **Roof Slab** | 13d | 2011-06-19 | 2011-07-01 |  | 0d |
| 401 |  | Form Work | 5d | 2011-06-19 | 2011-06-23 | 378, 389, 399 | 0d |
| 402 |  | Re-bar | 4d | 2011-06-24 | 2011-06-27 | 401 | 0d |
| 403 |  | MEP Work | 1d | 2011-06-28 | 2011-06-28 | 402 | 0d |
| 404 |  | Inspection | 1d | 2011-06-29 | 2011-06-29 | 403 | 0d |
| 405 |  | Concrete | 2d | 2011-06-30 | 2011-07-01 | 404 | 0d |
| 406 | 1.3.3 | **2ND FLOOR** | 25d | 2011-07-02 | 2011-07-26 |  | 0d |
| 407 | 1.3.3.1 | **Column** | 12d | 2011-07-02 | 2011-07-13 |  | 0d |
| 408 | 1.3.3.1.1 | **1ST Lift** | 6d | 2011-07-02 | 2011-07-07 |  | 0d |
| 409 |  | Re-Bar Work | 1d | 2011-07-02 | 2011-07-02 | 405 | 0d |
| 410 |  | Form Work | 1d | 2011-07-03 | 2011-07-03 | 409 | 0d |
| 411 |  | Concrete | 1d | 2011-07-04 | 2011-07-04 | 410 | 0d |
| 412 |  | De-shuttering | 1d | 2011-07-07 | 2011-07-07 | 411FS+2d | 0d |
| 413 | 1.3.3.1.2 | **2nd Lift** | 6d | 2011-07-08 | 2011-07-13 |  | 0d |
| 414 |  | Re-Bar Work | 1d | 2011-07-08 | 2011-07-08 | 412 | 0d |
| 415 |  | Form Work | 1d | 2011-07-09 | 2011-07-09 | 414 | 0d |
| 416 |  | Concrete | 1d | 2011-07-10 | 2011-07-10 | 415 | 0d |
| 417 |  | De-shuttering | 1d | 2011-07-13 | 2011-07-13 | 416FS+2d | 0d |
| 418 | 1.3.3.2 | **Shear Wall** | 12d | 2011-07-02 | 2011-07-13 |  | 0d |
| 419 | 1.3.3.2.1 | **1st Lift** | 6d | 2011-07-02 | 2011-07-07 |  | 0d |
| 420 |  | Re-Bar Work | 1d | 2011-07-02 | 2011-07-02 | 405 | 0d |

| ID | WBS | Task | Duration | Start | Finish | Predecessors | Total float |
| --- | --- | --- | --- | --- | --- | --- | --- |
| 421 |  | Form Work | 1d | 2011-07-03 | 2011-07-03 | 420 | 0d |
| 422 |  | Concrete | 1d | 2011-07-04 | 2011-07-04 | 421 | 0d |
| 423 |  | De-shuttering | 1d | 2011-07-07 | 2011-07-07 | 422FS+2d | 0d |
| 424 | 1.3.3.2.2 | **2nd Lift** | 6d | 2011-07-08 | 2011-07-13 |  | 0d |
| 425 |  | Re-Bar Work | 1d | 2011-07-08 | 2011-07-08 | 423 | 0d |
| 426 |  | Form Work | 1d | 2011-07-09 | 2011-07-09 | 425 | 0d |
| 427 |  | Concrete | 1d | 2011-07-10 | 2011-07-10 | 426 | 0d |
| 428 |  | De-shuttering | 1d | 2011-07-13 | 2011-07-13 | 427FS+2d | 0d |
| 429 | 1.3.3.3 | **Stair - 1 & 2** | 7d | 2011-07-02 | 2011-07-08 |  | 5d |
| 430 | 1.3.3.3.1 | **1st Flight** | 4d | 2011-07-02 | 2011-07-05 |  | 5d |
| 431 |  | Brick Work | 1d | 2011-07-02 | 2011-07-02 | 405 | 5d |
| 432 |  | Form Work | 1d | 2011-07-03 | 2011-07-03 | 431 | 5d |
| 433 |  | Re-bar Work | 1d | 2011-07-04 | 2011-07-04 | 432 | 5d |
| 434 |  | Concrete | 1d | 2011-07-05 | 2011-07-05 | 433 | 5d |
| 435 | 1.3.3.3.2 | **2nd Flight** | 3d | 2011-07-06 | 2011-07-08 |  | 5d |
| 436 |  | Form Work | 1d | 2011-07-06 | 2011-07-06 | 434 | 5d |
| 437 |  | Re-bar | 1d | 2011-07-07 | 2011-07-07 | 436 | 5d |
| 438 |  | Concrete | 1d | 2011-07-08 | 2011-07-08 | 437 | 5d |
| 439 | 1.3.3.4 | **Roof Slab** | 13d | 2011-07-14 | 2011-07-26 |  | 0d |
| 440 |  | Form Work | 5d | 2011-07-14 | 2011-07-18 | 417, 428, 438 | 0d |
| 441 |  | Re-bar | 4d | 2011-07-19 | 2011-07-22 | 440 | 0d |
| 442 |  | MEP Work | 1d | 2011-07-23 | 2011-07-23 | 441 | 0d |
| 443 |  | Inspection | 1d | 2011-07-24 | 2011-07-24 | 442 | 0d |
| 444 |  | Concrete | 2d | 2011-07-25 | 2011-07-26 | 443 | 0d |
| 445 | 1.3.4 | **3RD FLOOR** | 25d | 2011-07-27 | 2011-08-20 |  | 0d |
| 446 | 1.3.4.1 | **Column** | 12d | 2011-07-27 | 2011-08-07 |  | 0d |
| 447 | 1.3.4.1.1 | **1ST Lift** | 6d | 2011-07-27 | 2011-08-01 |  | 0d |
| 448 |  | Re-Bar Work | 1d | 2011-07-27 | 2011-07-27 | 444 | 0d |
| 449 |  | Form Work | 1d | 2011-07-28 | 2011-07-28 | 448 | 0d |
| 450 |  | Concrete | 1d | 2011-07-29 | 2011-07-29 | 449 | 0d |
| 451 |  | De-shuttering | 1d | 2011-08-01 | 2011-08-01 | 450FS+2d | 0d |
| 452 | 1.3.4.1.2 | **2nd Lift** | 6d | 2011-08-02 | 2011-08-07 |  | 0d |
| 453 |  | Re-Bar Work | 1d | 2011-08-02 | 2011-08-02 | 451 | 0d |
| 454 |  | Form Work | 1d | 2011-08-03 | 2011-08-03 | 453 | 0d |
| 455 |  | Concrete | 1d | 2011-08-04 | 2011-08-04 | 454 | 0d |
| 456 |  | De-shuttering | 1d | 2011-08-07 | 2011-08-07 | 455FS+2d | 0d |
| 457 | 1.3.4.2 | **Shear Wall** | 12d | 2011-07-27 | 2011-08-07 |  | 0d |
| 458 | 1.3.4.2.1 | **1st Lift** | 6d | 2011-07-27 | 2011-08-01 |  | 0d |
| 459 |  | Re-Bar Work | 1d | 2011-07-27 | 2011-07-27 | 444 | 0d |
| 460 |  | Form Work | 1d | 2011-07-28 | 2011-07-28 | 459 | 0d |
| 461 |  | Concrete | 1d | 2011-07-29 | 2011-07-29 | 460 | 0d |
| 462 |  | De-shuttering | 1d | 2011-08-01 | 2011-08-01 | 461FS+2d | 0d |
| 463 | 1.3.4.2.2 | **2nd Lift** | 6d | 2011-08-02 | 2011-08-07 |  | 0d |
| 464 |  | Re-Bar Work | 1d | 2011-08-02 | 2011-08-02 | 462 | 0d |
| 465 |  | Form Work | 1d | 2011-08-03 | 2011-08-03 | 464 | 0d |
| 466 |  | Concrete | 1d | 2011-08-04 | 2011-08-04 | 465 | 0d |
| 467 |  | De-shuttering | 1d | 2011-08-07 | 2011-08-07 | 466FS+2d | 0d |
| 468 | 1.3.4.3 | **Stair - 1 & 2** | 7d | 2011-07-27 | 2011-08-02 |  | 5d |
| 469 | 1.3.4.3.1 | **1st Flight** | 4d | 2011-07-27 | 2011-07-30 |  | 5d |
| 470 |  | Brick Work | 1d | 2011-07-27 | 2011-07-27 | 444 | 5d |
| 471 |  | Form Work | 1d | 2011-07-28 | 2011-07-28 | 470 | 5d |
| 472 |  | Re-bar Work | 1d | 2011-07-29 | 2011-07-29 | 471 | 5d |
| 473 |  | Concrete | 1d | 2011-07-30 | 2011-07-30 | 472 | 5d |
| 474 | 1.3.4.3.2 | **2nd Flight** | 3d | 2011-07-31 | 2011-08-02 |  | 5d |
| 475 |  | Form Work | 1d | 2011-07-31 | 2011-07-31 | 473 | 5d |
| 476 |  | Re-bar | 1d | 2011-08-01 | 2011-08-01 | 475 | 5d |
| 477 |  | Concrete | 1d | 2011-08-02 | 2011-08-02 | 476 | 5d |
| 478 | 1.3.4.4 | **Roof Slab** | 13d | 2011-08-08 | 2011-08-20 |  | 0d |
| 479 |  | Form Work | 5d | 2011-08-08 | 2011-08-12 | 456, 467, 477 | 0d |
| 480 |  | Re-bar | 4d | 2011-08-13 | 2011-08-16 | 479 | 0d |
| 481 |  | MEP Work | 1d | 2011-08-17 | 2011-08-17 | 480 | 0d |
| 482 |  | Inspection | 1d | 2011-08-18 | 2011-08-18 | 481 | 0d |
| 483 |  | Concrete | 2d | 2011-08-19 | 2011-08-20 | 482 | 0d |
| 484 | 1.3.5 | **4TH FLOOR** | 25d | 2011-08-21 | 2011-09-22 |  | 0d |
| 485 | 1.3.5.1 | **Column** | 12d | 2011-08-21 | 2011-09-09 |  | 0d |
| 486 | 1.3.5.1.1 | **1ST Lift** | 6d | 2011-08-21 | 2011-09-03 |  | 0d |
| 487 |  | Re-Bar Work | 1d | 2011-08-21 | 2011-08-21 | 483 | 0d |
| 488 |  | Form Work | 1d | 2011-08-22 | 2011-08-22 | 487 | 0d |
| 489 |  | Concrete | 1d | 2011-08-23 | 2011-08-23 | 488 | 0d |
| 490 |  | De-shuttering | 1d | 2011-09-03 | 2011-09-03 | 489FS+2d | 0d |

| ID | WBS | Task | Duration | Start | Finish | Predecessors | Total float |
| --- | --- | --- | --- | --- | --- | --- | --- |
| 491 | 1.3.5.1.2 | **2nd Lift** | 6d | 2011-09-04 | 2011-09-09 |  | 0d |
| 492 |  | Re-Bar Work | 1d | 2011-09-04 | 2011-09-04 | 490 | 0d |
| 493 |  | Form Work | 1d | 2011-09-05 | 2011-09-05 | 492 | 0d |
| 494 |  | Concrete | 1d | 2011-09-06 | 2011-09-06 | 493 | 0d |
| 495 |  | De-shuttering | 1d | 2011-09-09 | 2011-09-09 | 494FS+2d | 0d |
| 496 | 1.3.5.2 | **Shear Wall** | 12d | 2011-08-21 | 2011-09-09 |  | 0d |
| 497 | 1.3.5.2.1 | **1st Lift** | 6d | 2011-08-21 | 2011-09-03 |  | 0d |
| 498 |  | Re-Bar Work | 1d | 2011-08-21 | 2011-08-21 | 483 | 0d |
| 499 |  | Form Work | 1d | 2011-08-22 | 2011-08-22 | 498 | 0d |
| 500 |  | Concrete | 1d | 2011-08-23 | 2011-08-23 | 499 | 0d |
| 501 |  | De-shuttering | 1d | 2011-09-03 | 2011-09-03 | 500FS+2d | 0d |
| 502 | 1.3.5.2.2 | **2nd Lift** | 6d | 2011-09-04 | 2011-09-09 |  | 0d |
| 503 |  | Re-Bar Work | 1d | 2011-09-04 | 2011-09-04 | 501 | 0d |
| 504 |  | Form Work | 1d | 2011-09-05 | 2011-09-05 | 503 | 0d |
| 505 |  | Concrete | 1d | 2011-09-06 | 2011-09-06 | 504 | 0d |
| 506 |  | De-shuttering | 1d | 2011-09-09 | 2011-09-09 | 505FS+2d | 0d |
| 507 | 1.3.5.3 | **Stair - 1 & 2** | 7d | 2011-08-21 | 2011-09-04 |  | 5d |
| 508 | 1.3.5.3.1 | **1st Flight** | 4d | 2011-08-21 | 2011-08-24 |  | 5d |
| 509 |  | Brick Work | 1d | 2011-08-21 | 2011-08-21 | 483 | 5d |
| 510 |  | Form Work | 1d | 2011-08-22 | 2011-08-22 | 509 | 5d |
| 511 |  | Re-bar Work | 1d | 2011-08-23 | 2011-08-23 | 510 | 5d |
| 512 |  | Concrete | 1d | 2011-08-24 | 2011-08-24 | 511 | 5d |
| 513 | 1.3.5.3.2 | **2nd Flight** | 3d | 2011-08-25 | 2011-09-04 |  | 5d |
| 514 |  | Form Work | 1d | 2011-08-25 | 2011-08-25 | 512 | 5d |
| 515 |  | Re-bar | 1d | 2011-09-03 | 2011-09-03 | 514 | 5d |
| 516 |  | Concrete | 1d | 2011-09-04 | 2011-09-04 | 515 | 5d |
| 517 | 1.3.5.4 | **Roof Slab** | 13d | 2011-09-10 | 2011-09-22 |  | 0d |
| 518 |  | Form Work | 5d | 2011-09-10 | 2011-09-14 | 495, 506, 516 | 0d |
| 519 |  | Re-bar | 4d | 2011-09-15 | 2011-09-18 | 518 | 0d |
| 520 |  | MEP Work | 1d | 2011-09-19 | 2011-09-19 | 519 | 0d |
| 521 |  | Inspection | 1d | 2011-09-20 | 2011-09-20 | 520 | 0d |
| 522 |  | Concrete | 2d | 2011-09-21 | 2011-09-22 | 521 | 0d |
| 523 | 1.3.6 | **5TH FLOOR** | 25d | 2011-09-23 | 2011-10-17 |  | 0d |
| 524 | 1.3.6.1 | **Column** | 12d | 2011-09-23 | 2011-10-04 |  | 0d |
| 525 | 1.3.6.1.1 | **1ST Lift** | 6d | 2011-09-23 | 2011-09-28 |  | 0d |
| 526 |  | Re-Bar Work | 1d | 2011-09-23 | 2011-09-23 | 522 | 0d |
| 527 |  | Form Work | 1d | 2011-09-24 | 2011-09-24 | 526 | 0d |
| 528 |  | Concrete | 1d | 2011-09-25 | 2011-09-25 | 527 | 0d |
| 529 |  | De-shuttering | 1d | 2011-09-28 | 2011-09-28 | 528FS+2d | 0d |
| 530 | 1.3.6.1.2 | **2nd Lift** | 6d | 2011-09-29 | 2011-10-04 |  | 0d |
| 531 |  | Re-Bar Work | 1d | 2011-09-29 | 2011-09-29 | 529 | 0d |
| 532 |  | Form Work | 1d | 2011-09-30 | 2011-09-30 | 531 | 0d |
| 533 |  | Concrete | 1d | 2011-10-01 | 2011-10-01 | 532 | 0d |
| 534 |  | De-shuttering | 1d | 2011-10-04 | 2011-10-04 | 533FS+2d | 0d |
| 535 | 1.3.6.2 | **Shear Wall** | 12d | 2011-09-23 | 2011-10-04 |  | 0d |
| 536 | 1.3.6.2.1 | **1st Lift** | 6d | 2011-09-23 | 2011-09-28 |  | 0d |
| 537 |  | Re-Bar Work | 1d | 2011-09-23 | 2011-09-23 | 522 | 0d |
| 538 |  | Form Work | 1d | 2011-09-24 | 2011-09-24 | 537 | 0d |
| 539 |  | Concrete | 1d | 2011-09-25 | 2011-09-25 | 538 | 0d |
| 540 |  | De-shuttering | 1d | 2011-09-28 | 2011-09-28 | 539FS+2d | 0d |
| 541 | 1.3.6.2.2 | **2nd Lift** | 6d | 2011-09-29 | 2011-10-04 |  | 0d |
| 542 |  | Re-Bar Work | 1d | 2011-09-29 | 2011-09-29 | 540 | 0d |
| 543 |  | Form Work | 1d | 2011-09-30 | 2011-09-30 | 542 | 0d |
| 544 |  | Concrete | 1d | 2011-10-01 | 2011-10-01 | 543 | 0d |
| 545 |  | De-shuttering | 1d | 2011-10-04 | 2011-10-04 | 544FS+2d | 0d |
| 546 | 1.3.6.3 | **Stair - 1 & 2** | 7d | 2011-09-23 | 2011-09-29 |  | 5d |
| 547 | 1.3.6.3.1 | **1st Flight** | 4d | 2011-09-23 | 2011-09-26 |  | 5d |
| 548 |  | Brick Work | 1d | 2011-09-23 | 2011-09-23 | 522 | 5d |
| 549 |  | Form Work | 1d | 2011-09-24 | 2011-09-24 | 548 | 5d |
| 550 |  | Re-bar Work | 1d | 2011-09-25 | 2011-09-25 | 549 | 5d |
| 551 |  | Concrete | 1d | 2011-09-26 | 2011-09-26 | 550 | 5d |
| 552 | 1.3.6.3.2 | **2nd Flight** | 3d | 2011-09-27 | 2011-09-29 |  | 5d |
| 553 |  | Form Work | 1d | 2011-09-27 | 2011-09-27 | 551 | 5d |
| 554 |  | Re-bar | 1d | 2011-09-28 | 2011-09-28 | 553 | 5d |
| 555 |  | Concrete | 1d | 2011-09-29 | 2011-09-29 | 554 | 5d |
| 556 | 1.3.6.4 | **Roof Slab** | 13d | 2011-10-05 | 2011-10-17 |  | 0d |
| 557 |  | Form Work | 5d | 2011-10-05 | 2011-10-09 | 534, 545, 555 | 0d |
| 558 |  | Re-bar | 4d | 2011-10-10 | 2011-10-13 | 557 | 0d |
| 559 |  | MEP Work | 1d | 2011-10-14 | 2011-10-14 | 558 | 0d |
| 560 |  | Inspection | 1d | 2011-10-15 | 2011-10-15 | 559 | 0d |

| ID | WBS | Task | Duration | Start | Finish | Predecessors | Total float |
| --- | --- | --- | --- | --- | --- | --- | --- |
| 561 |  | Concrete | 2d | 2011-10-16 | 2011-10-17 | 560 | 0d |
| 562 | 1.3.7 | **6TH FLOOR** | 25d | 2011-10-18 | 2011-11-19 |  | 0d |
| 563 | 1.3.7.1 | **Column** | 12d | 2011-10-18 | 2011-10-29 |  | 0d |
| 564 | 1.3.7.1.1 | **1ST Lift** | 6d | 2011-10-18 | 2011-10-23 |  | 0d |
| 565 |  | Re-Bar Work | 1d | 2011-10-18 | 2011-10-18 | 561 | 0d |
| 566 |  | Form Work | 1d | 2011-10-19 | 2011-10-19 | 565 | 0d |
| 567 |  | Concrete | 1d | 2011-10-20 | 2011-10-20 | 566 | 0d |
| 568 |  | De-shuttering | 1d | 2011-10-23 | 2011-10-23 | 567FS+2d | 0d |
| 569 | 1.3.7.1.2 | **2nd Lift** | 6d | 2011-10-24 | 2011-10-29 |  | 0d |
| 570 |  | Re-Bar Work | 1d | 2011-10-24 | 2011-10-24 | 568 | 0d |
| 571 |  | Form Work | 1d | 2011-10-25 | 2011-10-25 | 570 | 0d |
| 572 |  | Concrete | 1d | 2011-10-26 | 2011-10-26 | 571 | 0d |
| 573 |  | De-shuttering | 1d | 2011-10-29 | 2011-10-29 | 572FS+2d | 0d |
| 574 | 1.3.7.2 | **Shear Wall** | 12d | 2011-10-18 | 2011-10-29 |  | 0d |
| 575 | 1.3.7.2.1 | **1st Lift** | 6d | 2011-10-18 | 2011-10-23 |  | 0d |
| 576 |  | Re-Bar Work | 1d | 2011-10-18 | 2011-10-18 | 561 | 0d |
| 577 |  | Form Work | 1d | 2011-10-19 | 2011-10-19 | 576 | 0d |
| 578 |  | Concrete | 1d | 2011-10-20 | 2011-10-20 | 577 | 0d |
| 579 |  | De-shuttering | 1d | 2011-10-23 | 2011-10-23 | 578FS+2d | 0d |
| 580 | 1.3.7.2.2 | **2nd Lift** | 6d | 2011-10-24 | 2011-10-29 |  | 0d |
| 581 |  | Re-Bar Work | 1d | 2011-10-24 | 2011-10-24 | 579 | 0d |
| 582 |  | Form Work | 1d | 2011-10-25 | 2011-10-25 | 581 | 0d |
| 583 |  | Concrete | 1d | 2011-10-26 | 2011-10-26 | 582 | 0d |
| 584 |  | De-shuttering | 1d | 2011-10-29 | 2011-10-29 | 583FS+2d | 0d |
| 585 | 1.3.7.3 | **Stair - 1 & 2** | 7d | 2011-10-18 | 2011-10-24 |  | 5d |
| 586 | 1.3.7.3.1 | **1st Flight** | 4d | 2011-10-18 | 2011-10-21 |  | 5d |
| 587 |  | Brick Work | 1d | 2011-10-18 | 2011-10-18 | 561 | 5d |
| 588 |  | Form Work | 1d | 2011-10-19 | 2011-10-19 | 587 | 5d |
| 589 |  | Re-bar Work | 1d | 2011-10-20 | 2011-10-20 | 588 | 5d |
| 590 |  | Concrete | 1d | 2011-10-21 | 2011-10-21 | 589 | 5d |
| 591 | 1.3.7.3.2 | **2nd Flight** | 3d | 2011-10-22 | 2011-10-24 |  | 5d |
| 592 |  | Form Work | 1d | 2011-10-22 | 2011-10-22 | 590 | 5d |
| 593 |  | Re-bar | 1d | 2011-10-23 | 2011-10-23 | 592 | 5d |
| 594 |  | Concrete | 1d | 2011-10-24 | 2011-10-24 | 593 | 5d |
| 595 | 1.3.7.4 | **Roof Slab** | 13d | 2011-10-30 | 2011-11-19 |  | 0d |
| 596 |  | Form Work | 5d | 2011-10-30 | 2011-11-03 | 573, 584, 594 | 0d |
| 597 |  | Re-bar | 4d | 2011-11-04 | 2011-11-07 | 596 | 0d |
| 598 |  | MEP Work | 1d | 2011-11-08 | 2011-11-08 | 597 | 0d |
| 599 |  | Inspection | 1d | 2011-11-09 | 2011-11-09 | 598 | 0d |
| 600 |  | Concrete | 2d | 2011-11-10 | 2011-11-19 | 599 | 0d |
| 601 | 1.3.8 | **7TH FLOOR** | 25d | 2011-11-20 | 2011-12-14 |  | 0d |
| 602 | 1.3.8.1 | **Column** | 12d | 2011-11-20 | 2011-12-01 |  | 0d |
| 603 | 1.3.8.1.1 | **1ST Lift** | 6d | 2011-11-20 | 2011-11-25 |  | 0d |
| 604 |  | Re-Bar Work | 1d | 2011-11-20 | 2011-11-20 | 600 | 0d |
| 605 |  | Form Work | 1d | 2011-11-21 | 2011-11-21 | 604 | 0d |
| 606 |  | Concrete | 1d | 2011-11-22 | 2011-11-22 | 605 | 0d |
| 607 |  | De-shuttering | 1d | 2011-11-25 | 2011-11-25 | 606FS+2d | 0d |
| 608 | 1.3.8.1.2 | **2nd Lift** | 6d | 2011-11-26 | 2011-12-01 |  | 0d |
| 609 |  | Re-Bar Work | 1d | 2011-11-26 | 2011-11-26 | 607 | 0d |
| 610 |  | Form Work | 1d | 2011-11-27 | 2011-11-27 | 609 | 0d |
| 611 |  | Concrete | 1d | 2011-11-28 | 2011-11-28 | 610 | 0d |
| 612 |  | De-shuttering | 1d | 2011-12-01 | 2011-12-01 | 611FS+2d | 0d |
| 613 | 1.3.8.2 | **Shear Wall** | 12d | 2011-11-20 | 2011-12-01 |  | 0d |
| 614 | 1.3.8.2.1 | **1st Lift** | 6d | 2011-11-20 | 2011-11-25 |  | 0d |
| 615 |  | Re-Bar Work | 1d | 2011-11-20 | 2011-11-20 | 600 | 0d |
| 616 |  | Form Work | 1d | 2011-11-21 | 2011-11-21 | 615 | 0d |
| 617 |  | Concrete | 1d | 2011-11-22 | 2011-11-22 | 616 | 0d |
| 618 |  | De-shuttering | 1d | 2011-11-25 | 2011-11-25 | 617FS+2d | 0d |
| 619 | 1.3.8.2.2 | **2nd Lift** | 6d | 2011-11-26 | 2011-12-01 |  | 0d |
| 620 |  | Re-Bar Work | 1d | 2011-11-26 | 2011-11-26 | 618 | 0d |
| 621 |  | Form Work | 1d | 2011-11-27 | 2011-11-27 | 620 | 0d |
| 622 |  | Concrete | 1d | 2011-11-28 | 2011-11-28 | 621 | 0d |
| 623 |  | De-shuttering | 1d | 2011-12-01 | 2011-12-01 | 622FS+2d | 0d |
| 624 | 1.3.8.3 | **Stair - 1 & 2** | 7d | 2011-11-20 | 2011-11-26 |  | 5d |
| 625 | 1.3.8.3.1 | **1st Flight** | 4d | 2011-11-20 | 2011-11-23 |  | 5d |
| 626 |  | Brick Work | 1d | 2011-11-20 | 2011-11-20 | 600 | 5d |
| 627 |  | Form Work | 1d | 2011-11-21 | 2011-11-21 | 626 | 5d |
| 628 |  | Re-bar Work | 1d | 2011-11-22 | 2011-11-22 | 627 | 5d |
| 629 |  | Concrete | 1d | 2011-11-23 | 2011-11-23 | 628 | 5d |
| 630 | 1.3.8.3.2 | **2nd Flight** | 3d | 2011-11-24 | 2011-11-26 |  | 5d |

| ID | WBS | Task | Duration | Start | Finish | Predecessors | Total float |
| --- | --- | --- | --- | --- | --- | --- | --- |
| 631 |  | Form Work | 1d | 2011-11-24 | 2011-11-24 | 629 | 5d |
| 632 |  | Re-bar | 1d | 2011-11-25 | 2011-11-25 | 631 | 5d |
| 633 |  | Concrete | 1d | 2011-11-26 | 2011-11-26 | 632 | 5d |
| 634 | 1.3.8.4 | **Roof Slab** | 13d | 2011-12-02 | 2011-12-14 |  | 0d |
| 635 |  | Form Work | 5d | 2011-12-02 | 2011-12-06 | 612, 623, 633 | 0d |
| 636 |  | Re-bar | 4d | 2011-12-07 | 2011-12-10 | 635 | 0d |
| 637 |  | MEP Work | 1d | 2011-12-11 | 2011-12-11 | 636 | 0d |
| 638 |  | Inspection | 1d | 2011-12-12 | 2011-12-12 | 637 | 0d |
| 639 |  | Concrete | 2d | 2011-12-13 | 2011-12-14 | 638 | 0d |
| 640 | 1.3.9 | **8TH FLOOR** | 25d | 2011-12-15 | 2012-01-08 |  | 0d |
| 641 | 1.3.9.1 | **Column** | 12d | 2011-12-15 | 2011-12-26 |  | 0d |
| 642 | 1.3.9.1.1 | **1ST Lift** | 6d | 2011-12-15 | 2011-12-20 |  | 0d |
| 643 |  | Re-Bar Work | 1d | 2011-12-15 | 2011-12-15 | 639 | 0d |
| 644 |  | Form Work | 1d | 2011-12-16 | 2011-12-16 | 643 | 0d |
| 645 |  | Concrete | 1d | 2011-12-17 | 2011-12-17 | 644 | 0d |
| 646 |  | De-shuttering | 1d | 2011-12-20 | 2011-12-20 | 645FS+2d | 0d |
| 647 | 1.3.9.1.2 | **2nd Lift** | 6d | 2011-12-21 | 2011-12-26 |  | 0d |
| 648 |  | Re-Bar Work | 1d | 2011-12-21 | 2011-12-21 | 646 | 0d |
| 649 |  | Form Work | 1d | 2011-12-22 | 2011-12-22 | 648 | 0d |
| 650 |  | Concrete | 1d | 2011-12-23 | 2011-12-23 | 649 | 0d |
| 651 |  | De-shuttering | 1d | 2011-12-26 | 2011-12-26 | 650FS+2d | 0d |
| 652 | 1.3.9.2 | **Shear Wall** | 12d | 2011-12-15 | 2011-12-26 |  | 0d |
| 653 | 1.3.9.2.1 | **1st Lift** | 6d | 2011-12-15 | 2011-12-20 |  | 0d |
| 654 |  | Re-Bar Work | 1d | 2011-12-15 | 2011-12-15 | 639 | 0d |
| 655 |  | Form Work | 1d | 2011-12-16 | 2011-12-16 | 654 | 0d |
| 656 |  | Concrete | 1d | 2011-12-17 | 2011-12-17 | 655 | 0d |
| 657 |  | De-shuttering | 1d | 2011-12-20 | 2011-12-20 | 656FS+2d | 0d |
| 658 | 1.3.9.2.2 | **2nd Lift** | 6d | 2011-12-21 | 2011-12-26 |  | 0d |
| 659 |  | Re-Bar Work | 1d | 2011-12-21 | 2011-12-21 | 657 | 0d |
| 660 |  | Form Work | 1d | 2011-12-22 | 2011-12-22 | 659 | 0d |
| 661 |  | Concrete | 1d | 2011-12-23 | 2011-12-23 | 660 | 0d |
| 662 |  | De-shuttering | 1d | 2011-12-26 | 2011-12-26 | 661FS+2d | 0d |
| 663 | 1.3.9.3 | **Stair - 1 & 2** | 7d | 2011-12-15 | 2011-12-21 |  | 5d |
| 664 | 1.3.9.3.1 | **1st Flight** | 4d | 2011-12-15 | 2011-12-18 |  | 5d |
| 665 |  | Brick Work | 1d | 2011-12-15 | 2011-12-15 | 639 | 5d |
| 666 |  | Form Work | 1d | 2011-12-16 | 2011-12-16 | 665 | 5d |
| 667 |  | Re-bar Work | 1d | 2011-12-17 | 2011-12-17 | 666 | 5d |
| 668 |  | Concrete | 1d | 2011-12-18 | 2011-12-18 | 667 | 5d |
| 669 | 1.3.9.3.2 | **2nd Flight** | 3d | 2011-12-19 | 2011-12-21 |  | 5d |
| 670 |  | Form Work | 1d | 2011-12-19 | 2011-12-19 | 668 | 5d |
| 671 |  | Re-bar | 1d | 2011-12-20 | 2011-12-20 | 670 | 5d |
| 672 |  | Concrete | 1d | 2011-12-21 | 2011-12-21 | 671 | 5d |
| 673 | 1.3.9.4 | **Roof Slab** | 13d | 2011-12-27 | 2012-01-08 |  | 0d |
| 674 |  | Form Work | 5d | 2011-12-27 | 2011-12-31 | 651, 662, 672 | 0d |
| 675 |  | Re-bar | 4d | 2012-01-01 | 2012-01-04 | 674 | 0d |
| 676 |  | MEP Work | 1d | 2012-01-05 | 2012-01-05 | 675 | 0d |
| 677 |  | Inspection | 1d | 2012-01-06 | 2012-01-06 | 676 | 0d |
| 678 |  | Concrete | 2d | 2012-01-07 | 2012-01-08 | 677 | 0d |
| 679 | 1.3.10 | **9TH FLOOR** | 25d | 2012-01-09 | 2012-02-02 |  | 0d |
| 680 | 1.3.10.1 | **Column** | 12d | 2012-01-09 | 2012-01-20 |  | 0d |
| 681 | 1.3.10.1.1 | **1ST Lift** | 6d | 2012-01-09 | 2012-01-14 |  | 0d |
| 682 |  | Re-Bar Work | 1d | 2012-01-09 | 2012-01-09 | 678 | 0d |
| 683 |  | Form Work | 1d | 2012-01-10 | 2012-01-10 | 682 | 0d |
| 684 |  | Concrete | 1d | 2012-01-11 | 2012-01-11 | 683 | 0d |
| 685 |  | De-shuttering | 1d | 2012-01-14 | 2012-01-14 | 684FS+2d | 0d |
| 686 | 1.3.10.1.2 | **2nd Lift** | 6d | 2012-01-15 | 2012-01-20 |  | 0d |
| 687 |  | Re-Bar Work | 1d | 2012-01-15 | 2012-01-15 | 685 | 0d |
| 688 |  | Form Work | 1d | 2012-01-16 | 2012-01-16 | 687 | 0d |
| 689 |  | Concrete | 1d | 2012-01-17 | 2012-01-17 | 688 | 0d |
| 690 |  | De-shuttering | 1d | 2012-01-20 | 2012-01-20 | 689FS+2d | 0d |
| 691 | 1.3.10.2 | **Shear Wall** | 12d | 2012-01-09 | 2012-01-20 |  | 0d |
| 692 | 1.3.10.2.1 | **1st Lift** | 6d | 2012-01-09 | 2012-01-14 |  | 0d |
| 693 |  | Re-Bar Work | 1d | 2012-01-09 | 2012-01-09 | 678 | 0d |
| 694 |  | Form Work | 1d | 2012-01-10 | 2012-01-10 | 693 | 0d |
| 695 |  | Concrete | 1d | 2012-01-11 | 2012-01-11 | 694 | 0d |
| 696 |  | De-shuttering | 1d | 2012-01-14 | 2012-01-14 | 695FS+2d | 0d |
| 697 | 1.3.10.2.2 | **2nd Lift** | 6d | 2012-01-15 | 2012-01-20 |  | 0d |
| 698 |  | Re-Bar Work | 1d | 2012-01-15 | 2012-01-15 | 696 | 0d |
| 699 |  | Form Work | 1d | 2012-01-16 | 2012-01-16 | 698 | 0d |
| 700 |  | Concrete | 1d | 2012-01-17 | 2012-01-17 | 699 | 0d |

| ID | WBS | Task | Duration | Start | Finish | Predecessors | Total float |
| --- | --- | --- | --- | --- | --- | --- | --- |
| 701 |  | De-shuttering | 1d | 2012-01-20 | 2012-01-20 | 700FS+2d | 0d |
| 702 | 1.3.10.3 | **Stair - 1 & 2** | 7d | 2012-01-09 | 2012-01-15 |  | 5d |
| 703 | 1.3.10.3.1 | **1st Flight** | 4d | 2012-01-09 | 2012-01-12 |  | 5d |
| 704 |  | Brick Work | 1d | 2012-01-09 | 2012-01-09 | 678 | 5d |
| 705 |  | Form Work | 1d | 2012-01-10 | 2012-01-10 | 704 | 5d |
| 706 |  | Re-bar Work | 1d | 2012-01-11 | 2012-01-11 | 705 | 5d |
| 707 |  | Concrete | 1d | 2012-01-12 | 2012-01-12 | 706 | 5d |
| 708 | 1.3.10.3.2 | **2nd Flight** | 3d | 2012-01-13 | 2012-01-15 |  | 5d |
| 709 |  | Form Work | 1d | 2012-01-13 | 2012-01-13 | 707 | 5d |
| 710 |  | Re-bar | 1d | 2012-01-14 | 2012-01-14 | 709 | 5d |
| 711 |  | Concrete | 1d | 2012-01-15 | 2012-01-15 | 710 | 5d |
| 712 | 1.3.10.4 | **Roof Slab** | 13d | 2012-01-21 | 2012-02-02 |  | 0d |
| 713 |  | Form Work | 5d | 2012-01-21 | 2012-01-25 | 690, 701, 711 | 0d |
| 714 |  | Re-bar | 4d | 2012-01-26 | 2012-01-29 | 713 | 0d |
| 715 |  | MEP Work | 1d | 2012-01-30 | 2012-01-30 | 714 | 0d |
| 716 |  | Inspection | 1d | 2012-01-31 | 2012-01-31 | 715 | 0d |
| 717 |  | Concrete | 2d | 2012-02-01 | 2012-02-02 | 716 | 0d |
| 718 | 1.3.11 | **10TH FLOOR** | 25d | 2012-02-03 | 2012-02-27 |  | 0d |
| 719 | 1.3.11.1 | **Column** | 12d | 2012-02-03 | 2012-02-14 |  | 0d |
| 720 | 1.3.11.1.1 | **1ST Lift** | 6d | 2012-02-03 | 2012-02-08 |  | 0d |
| 721 |  | Re-Bar Work | 1d | 2012-02-03 | 2012-02-03 | 717 | 0d |
| 722 |  | Form Work | 1d | 2012-02-04 | 2012-02-04 | 721 | 0d |
| 723 |  | Concrete | 1d | 2012-02-05 | 2012-02-05 | 722 | 0d |
| 724 |  | De-shuttering | 1d | 2012-02-08 | 2012-02-08 | 723FS+2d | 0d |
| 725 | 1.3.11.1.2 | **2nd Lift** | 6d | 2012-02-09 | 2012-02-14 |  | 0d |
| 726 |  | Re-Bar Work | 1d | 2012-02-09 | 2012-02-09 | 724 | 0d |
| 727 |  | Form Work | 1d | 2012-02-10 | 2012-02-10 | 726 | 0d |
| 728 |  | Concrete | 1d | 2012-02-11 | 2012-02-11 | 727 | 0d |
| 729 |  | De-shuttering | 1d | 2012-02-14 | 2012-02-14 | 728FS+2d | 0d |
| 730 | 1.3.11.2 | **Shear Wall** | 12d | 2012-02-03 | 2012-02-14 |  | 0d |
| 731 | 1.3.11.2.1 | **1st Lift** | 6d | 2012-02-03 | 2012-02-08 |  | 0d |
| 732 |  | Re-Bar Work | 1d | 2012-02-03 | 2012-02-03 | 717 | 0d |
| 733 |  | Form Work | 1d | 2012-02-04 | 2012-02-04 | 732 | 0d |
| 734 |  | Concrete | 1d | 2012-02-05 | 2012-02-05 | 733 | 0d |
| 735 |  | De-shuttering | 1d | 2012-02-08 | 2012-02-08 | 734FS+2d | 0d |
| 736 | 1.3.11.2.2 | **2nd Lift** | 6d | 2012-02-09 | 2012-02-14 |  | 0d |
| 737 |  | Re-Bar Work | 1d | 2012-02-09 | 2012-02-09 | 735 | 0d |
| 738 |  | Form Work | 1d | 2012-02-10 | 2012-02-10 | 737 | 0d |
| 739 |  | Concrete | 1d | 2012-02-11 | 2012-02-11 | 738 | 0d |
| 740 |  | De-shuttering | 1d | 2012-02-14 | 2012-02-14 | 739FS+2d | 0d |
| 741 | 1.3.11.3 | **Stair - 1 & 2** | 7d | 2012-02-03 | 2012-02-09 |  | 5d |
| 742 | 1.3.11.3.1 | **1st Flight** | 4d | 2012-02-03 | 2012-02-06 |  | 5d |
| 743 |  | Brick Work | 1d | 2012-02-03 | 2012-02-03 | 717 | 5d |
| 744 |  | Form Work | 1d | 2012-02-04 | 2012-02-04 | 743 | 5d |
| 745 |  | Re-bar Work | 1d | 2012-02-05 | 2012-02-05 | 744 | 5d |
| 746 |  | Concrete | 1d | 2012-02-06 | 2012-02-06 | 745 | 5d |
| 747 | 1.3.11.3.2 | **2nd Flight** | 3d | 2012-02-07 | 2012-02-09 |  | 5d |
| 748 |  | Form Work | 1d | 2012-02-07 | 2012-02-07 | 746 | 5d |
| 749 |  | Re-bar | 1d | 2012-02-08 | 2012-02-08 | 748 | 5d |
| 750 |  | Concrete | 1d | 2012-02-09 | 2012-02-09 | 749 | 5d |
| 751 | 1.3.11.4 | **Roof Slab** | 13d | 2012-02-15 | 2012-02-27 |  | 0d |
| 752 |  | Form Work | 5d | 2012-02-15 | 2012-02-19 | 729, 740, 750 | 0d |
| 753 |  | Re-bar | 4d | 2012-02-20 | 2012-02-23 | 752 | 0d |
| 754 |  | MEP Work | 1d | 2012-02-24 | 2012-02-24 | 753 | 0d |
| 755 |  | Inspection | 1d | 2012-02-25 | 2012-02-25 | 754 | 0d |
| 756 |  | Concrete | 2d | 2012-02-26 | 2012-02-27 | 755 | 0d |
| 757 | 1.3.12 | **11TH FLOOR** | 25d | 2012-02-28 | 2012-03-23 |  | 0d |
| 758 | 1.3.12.1 | **Column** | 12d | 2012-02-28 | 2012-03-10 |  | 0d |
| 759 | 1.3.12.1.1 | **1ST Lift** | 6d | 2012-02-28 | 2012-03-04 |  | 0d |
| 760 |  | Re-Bar Work | 1d | 2012-02-28 | 2012-02-28 | 756 | 0d |
| 761 |  | Form Work | 1d | 2012-02-29 | 2012-02-29 | 760 | 0d |
| 762 |  | Concrete | 1d | 2012-03-01 | 2012-03-01 | 761 | 0d |
| 763 |  | De-shuttering | 1d | 2012-03-04 | 2012-03-04 | 762FS+2d | 0d |
| 764 | 1.3.12.1.2 | **2nd Lift** | 6d | 2012-03-05 | 2012-03-10 |  | 0d |
| 765 |  | Re-Bar Work | 1d | 2012-03-05 | 2012-03-05 | 763 | 0d |
| 766 |  | Form Work | 1d | 2012-03-06 | 2012-03-06 | 765 | 0d |
| 767 |  | Concrete | 1d | 2012-03-07 | 2012-03-07 | 766 | 0d |
| 768 |  | De-shuttering | 1d | 2012-03-10 | 2012-03-10 | 767FS+2d | 0d |
| 769 | 1.3.12.2 | **Shear Wall** | 12d | 2012-02-28 | 2012-03-10 |  | 0d |
| 770 | 1.3.12.2.1 | **1st Lift** | 6d | 2012-02-28 | 2012-03-04 |  | 0d |

| ID | WBS | Task | Duration | Start | Finish | Predecessors | Total float |
| --- | --- | --- | --- | --- | --- | --- | --- |
| 771 |  | Re-Bar Work | 1d | 2012-02-28 | 2012-02-28 | 756 | 0d |
| 772 |  | Form Work | 1d | 2012-02-29 | 2012-02-29 | 771 | 0d |
| 773 |  | Concrete | 1d | 2012-03-01 | 2012-03-01 | 772 | 0d |
| 774 |  | De-shuttering | 1d | 2012-03-04 | 2012-03-04 | 773FS+2d | 0d |
| 775 | 1.3.12.2.2 | **2nd Lift** | 6d | 2012-03-05 | 2012-03-10 |  | 0d |
| 776 |  | Re-Bar Work | 1d | 2012-03-05 | 2012-03-05 | 774 | 0d |
| 777 |  | Form Work | 1d | 2012-03-06 | 2012-03-06 | 776 | 0d |
| 778 |  | Concrete | 1d | 2012-03-07 | 2012-03-07 | 777 | 0d |
| 779 |  | De-shuttering | 1d | 2012-03-10 | 2012-03-10 | 778FS+2d | 0d |
| 780 | 1.3.12.3 | **Stair - 1 & 2** | 7d | 2012-02-28 | 2012-03-05 |  | 5d |
| 781 | 1.3.12.3.1 | **1st Flight** | 4d | 2012-02-28 | 2012-03-02 |  | 5d |
| 782 |  | Brick Work | 1d | 2012-02-28 | 2012-02-28 | 756 | 5d |
| 783 |  | Form Work | 1d | 2012-02-29 | 2012-02-29 | 782 | 5d |
| 784 |  | Re-bar Work | 1d | 2012-03-01 | 2012-03-01 | 783 | 5d |
| 785 |  | Concrete | 1d | 2012-03-02 | 2012-03-02 | 784 | 5d |
| 786 | 1.3.12.3.2 | **2nd Flight** | 3d | 2012-03-03 | 2012-03-05 |  | 5d |
| 787 |  | Form Work | 1d | 2012-03-03 | 2012-03-03 | 785 | 5d |
| 788 |  | Re-bar | 1d | 2012-03-04 | 2012-03-04 | 787 | 5d |
| 789 |  | Concrete | 1d | 2012-03-05 | 2012-03-05 | 788 | 5d |
| 790 | 1.3.12.4 | **Roof Slab** | 13d | 2012-03-11 | 2012-03-23 |  | 0d |
| 791 |  | Form Work | 5d | 2012-03-11 | 2012-03-15 | 768, 779, 789 | 0d |
| 792 |  | Re-bar | 4d | 2012-03-16 | 2012-03-19 | 791 | 0d |
| 793 |  | MEP Work | 1d | 2012-03-20 | 2012-03-20 | 792 | 0d |
| 794 |  | Inspection | 1d | 2012-03-21 | 2012-03-21 | 793 | 0d |
| 795 |  | Concrete | 2d | 2012-03-22 | 2012-03-23 | 794 | 0d |
| 796 | 1.3.13 | **12TH FLOOR** | 25d | 2012-03-24 | 2012-04-17 |  | 0d |
| 797 | 1.3.13.1 | **Column** | 12d | 2012-03-24 | 2012-04-04 |  | 0d |
| 798 | 1.3.13.1.1 | **1ST Lift** | 6d | 2012-03-24 | 2012-03-29 |  | 0d |
| 799 |  | Re-Bar Work | 1d | 2012-03-24 | 2012-03-24 | 795 | 0d |
| 800 |  | Form Work | 1d | 2012-03-25 | 2012-03-25 | 799 | 0d |
| 801 |  | Concrete | 1d | 2012-03-26 | 2012-03-26 | 800 | 0d |
| 802 |  | De-shuttering | 1d | 2012-03-29 | 2012-03-29 | 801FS+2d | 0d |
| 803 | 1.3.13.1.2 | **2nd Lift** | 6d | 2012-03-30 | 2012-04-04 |  | 0d |
| 804 |  | Re-Bar Work | 1d | 2012-03-30 | 2012-03-30 | 802 | 0d |
| 805 |  | Form Work | 1d | 2012-03-31 | 2012-03-31 | 804 | 0d |
| 806 |  | Concrete | 1d | 2012-04-01 | 2012-04-01 | 805 | 0d |
| 807 |  | De-shuttering | 1d | 2012-04-04 | 2012-04-04 | 806FS+2d | 0d |
| 808 | 1.3.13.2 | **Shear Wall** | 12d | 2012-03-24 | 2012-04-04 |  | 0d |
| 809 | 1.3.13.2.1 | **1st Lift** | 6d | 2012-03-24 | 2012-03-29 |  | 0d |
| 810 |  | Re-Bar Work | 1d | 2012-03-24 | 2012-03-24 | 795 | 0d |
| 811 |  | Form Work | 1d | 2012-03-25 | 2012-03-25 | 810 | 0d |
| 812 |  | Concrete | 1d | 2012-03-26 | 2012-03-26 | 811 | 0d |
| 813 |  | De-shuttering | 1d | 2012-03-29 | 2012-03-29 | 812FS+2d | 0d |
| 814 | 1.3.13.2.2 | **2nd Lift** | 6d | 2012-03-30 | 2012-04-04 |  | 0d |
| 815 |  | Re-Bar Work | 1d | 2012-03-30 | 2012-03-30 | 813 | 0d |
| 816 |  | Form Work | 1d | 2012-03-31 | 2012-03-31 | 815 | 0d |
| 817 |  | Concrete | 1d | 2012-04-01 | 2012-04-01 | 816 | 0d |
| 818 |  | De-shuttering | 1d | 2012-04-04 | 2012-04-04 | 817FS+2d | 0d |
| 819 | 1.3.13.3 | **Stair - 1 & 2** | 7d | 2012-03-24 | 2012-03-30 |  | 5d |
| 820 | 1.3.13.3.1 | **1st Flight** | 4d | 2012-03-24 | 2012-03-27 |  | 5d |
| 821 |  | Brick Work | 1d | 2012-03-24 | 2012-03-24 | 795 | 5d |
| 822 |  | Form Work | 1d | 2012-03-25 | 2012-03-25 | 821 | 5d |
| 823 |  | Re-bar Work | 1d | 2012-03-26 | 2012-03-26 | 822 | 5d |
| 824 |  | Concrete | 1d | 2012-03-27 | 2012-03-27 | 823 | 5d |
| 825 | 1.3.13.3.2 | **2nd Flight** | 3d | 2012-03-28 | 2012-03-30 |  | 5d |
| 826 |  | Form Work | 1d | 2012-03-28 | 2012-03-28 | 824 | 5d |
| 827 |  | Re-bar | 1d | 2012-03-29 | 2012-03-29 | 826 | 5d |
| 828 |  | Concrete | 1d | 2012-03-30 | 2012-03-30 | 827 | 5d |
| 829 | 1.3.13.4 | **Roof Slab** | 13d | 2012-04-05 | 2012-04-17 |  | 0d |
| 830 |  | Form Work | 5d | 2012-04-05 | 2012-04-09 | 807, 818, 828 | 0d |
| 831 |  | Re-bar | 4d | 2012-04-10 | 2012-04-13 | 830 | 0d |
| 832 |  | MEP Work | 1d | 2012-04-14 | 2012-04-14 | 831 | 0d |
| 833 |  | Inspection | 1d | 2012-04-15 | 2012-04-15 | 832 | 0d |
| 834 |  | Concrete | 2d | 2012-04-16 | 2012-04-17 | 833 | 0d |
| 835 | 1.3.14 | **13TH FLOOR** | 25d | 2012-04-18 | 2012-05-12 |  | 0d |
| 836 | 1.3.14.1 | **Column** | 12d | 2012-04-18 | 2012-04-29 |  | 0d |
| 837 | 1.3.14.1.1 | **1ST Lift** | 6d | 2012-04-18 | 2012-04-23 |  | 0d |
| 838 |  | Re-Bar Work | 1d | 2012-04-18 | 2012-04-18 | 834 | 0d |
| 839 |  | Form Work | 1d | 2012-04-19 | 2012-04-19 | 838 | 0d |
| 840 |  | Concrete | 1d | 2012-04-20 | 2012-04-20 | 839 | 0d |

| ID | WBS | Task | Duration | Start | Finish | Predecessors | Total float |
| --- | --- | --- | --- | --- | --- | --- | --- |
| 841 |  | De-shuttering | 1d | 2012-04-23 | 2012-04-23 | 840FS+2d | 0d |
| 842 | 1.3.14.1.2 | **2nd Lift** | 6d | 2012-04-24 | 2012-04-29 |  | 0d |
| 843 |  | Re-Bar Work | 1d | 2012-04-24 | 2012-04-24 | 841 | 0d |
| 844 |  | Form Work | 1d | 2012-04-25 | 2012-04-25 | 843 | 0d |
| 845 |  | Concrete | 1d | 2012-04-26 | 2012-04-26 | 844 | 0d |
| 846 |  | De-shuttering | 1d | 2012-04-29 | 2012-04-29 | 845FS+2d | 0d |
| 847 | 1.3.14.2 | **Shear Wall** | 12d | 2012-04-18 | 2012-04-29 |  | 0d |
| 848 | 1.3.14.2.1 | **1st Lift** | 6d | 2012-04-18 | 2012-04-23 |  | 0d |
| 849 |  | Re-Bar Work | 1d | 2012-04-18 | 2012-04-18 | 834 | 0d |
| 850 |  | Form Work | 1d | 2012-04-19 | 2012-04-19 | 849 | 0d |
| 851 |  | Concrete | 1d | 2012-04-20 | 2012-04-20 | 850 | 0d |
| 852 |  | De-shuttering | 1d | 2012-04-23 | 2012-04-23 | 851FS+2d | 0d |
| 853 | 1.3.14.2.2 | **2nd Lift** | 6d | 2012-04-24 | 2012-04-29 |  | 0d |
| 854 |  | Re-Bar Work | 1d | 2012-04-24 | 2012-04-24 | 852 | 0d |
| 855 |  | Form Work | 1d | 2012-04-25 | 2012-04-25 | 854 | 0d |
| 856 |  | Concrete | 1d | 2012-04-26 | 2012-04-26 | 855 | 0d |
| 857 |  | De-shuttering | 1d | 2012-04-29 | 2012-04-29 | 856FS+2d | 0d |
| 858 | 1.3.14.3 | **Stair - 1 & 2** | 7d | 2012-04-18 | 2012-04-24 |  | 5d |
| 859 | 1.3.14.3.1 | **1st Flight** | 4d | 2012-04-18 | 2012-04-21 |  | 5d |
| 860 |  | Brick Work | 1d | 2012-04-18 | 2012-04-18 | 834 | 5d |
| 861 |  | Form Work | 1d | 2012-04-19 | 2012-04-19 | 860 | 5d |
| 862 |  | Re-bar Work | 1d | 2012-04-20 | 2012-04-20 | 861 | 5d |
| 863 |  | Concrete | 1d | 2012-04-21 | 2012-04-21 | 862 | 5d |
| 864 | 1.3.14.3.2 | **2nd Flight** | 3d | 2012-04-22 | 2012-04-24 |  | 5d |
| 865 |  | Form Work | 1d | 2012-04-22 | 2012-04-22 | 863 | 5d |
| 866 |  | Re-bar | 1d | 2012-04-23 | 2012-04-23 | 865 | 5d |
| 867 |  | Concrete | 1d | 2012-04-24 | 2012-04-24 | 866 | 5d |
| 868 | 1.3.14.4 | **Roof Slab** | 13d | 2012-04-30 | 2012-05-12 |  | 0d |
| 869 |  | Form Work | 5d | 2012-04-30 | 2012-05-04 | 846, 857, 867 | 0d |
| 870 |  | Re-bar | 4d | 2012-05-05 | 2012-05-08 | 869 | 0d |
| 871 |  | MEP Work | 1d | 2012-05-09 | 2012-05-09 | 870 | 0d |
| 872 |  | Inspection | 1d | 2012-05-10 | 2012-05-10 | 871 | 0d |
| 873 |  | Concrete | 2d | 2012-05-11 | 2012-05-12 | 872 | 0d |
| 874 | 1.3.15 | **MACHINE FLOOR** | 20d | 2012-05-13 | 2012-06-01 |  | 0d |
| 875 | 1.3.15.1 | **Column** | 12d | 2012-05-13 | 2012-05-24 |  | 0d |
| 876 | 1.3.15.1.1 | **1st Lift** | 6d | 2012-05-13 | 2012-05-18 | 873 | 0d |
| 877 |  | Re-Bar Work | 1d | 2012-05-13 | 2012-05-13 |  | 0d |
| 878 |  | Form Work | 1d | 2012-05-14 | 2012-05-14 | 877 | 0d |
| 879 |  | Concrete | 1d | 2012-05-15 | 2012-05-15 | 878 | 0d |
| 880 |  | De-shuttering | 1d | 2012-05-18 | 2012-05-18 | 879FS+2d | 0d |
| 881 | 1.3.15.1.2 | **2nd Lift** | 6d | 2012-05-19 | 2012-05-24 |  | 102d |
| 882 |  | Re-Bar Work | 1d | 2012-05-19 | 2012-05-19 | 880 | 102d |
| 883 |  | Form Work | 1d | 2012-05-20 | 2012-05-20 | 882 | 102d |
| 884 |  | Concrete | 1d | 2012-05-21 | 2012-05-21 | 883 | 102d |
| 885 |  | De-shuttering | 1d | 2012-05-24 | 2012-05-24 | 884FS+2d | 102d |
| 886 |  | Brcik Work upto M/c Room Bot Slab | 1d | 2012-05-13 | 2012-05-13 | 873 | 5d |
| 887 | 1.3.15.3 | **M/c Room Bottom Slab** | 3d | 2012-05-19 | 2012-05-21 |  | 0d |
| 888 |  | Form work | 1d | 2012-05-19 | 2012-05-19 | 886, 880 | 0d |
| 889 |  | Re-bar | 1d | 2012-05-20 | 2012-05-20 | 888 | 0d |
| 890 |  | Concrete | 1d | 2012-05-21 | 2012-05-21 | 889 | 0d |
| 891 |  | Brick Work upto Top Slab | 1d | 2012-05-22 | 2012-05-22 | 890 | 0d |
| 892 | 1.3.15.5 | **Top slab** | 10d | 2012-05-23 | 2012-06-01 |  | 0d |
| 893 |  | Form Work | 5d | 2012-05-23 | 2012-05-27 | 891, 886 | 0d |
| 894 |  | Re-bar Work | 3d | 2012-05-28 | 2012-05-30 | 893 | 0d |
| 895 |  | Inspection | 1d | 2012-05-31 | 2012-05-31 | 894 | 0d |
| 896 |  | Concrete | 1d | 2012-06-01 | 2012-06-01 | 895 | 0d |
| 897 | 1.3.15.6 | **Swimming Pool** | 5d | 2012-05-13 | 2012-05-17 |  | 109d |
| 898 | 1.3.15.6.1 | **Vertical Wall** | 5d | 2012-05-13 | 2012-05-17 |  | 109d |
| 899 |  | Re-bar | 2d | 2012-05-13 | 2012-05-14 | 873 | 109d |
| 900 |  | Formwork | 2d | 2012-05-15 | 2012-05-16 | 899 | 109d |
| 901 |  | Concrete | 1d | 2012-05-17 | 2012-05-17 | 900 | 109d |
| 902 | 1.3.15.7 | **Planter Box** | 6d | 2012-05-13 | 2012-05-18 |  | 103d |
| 903 | 1.3.15.7.1 | **Vertical Wall** | 6d | 2012-05-13 | 2012-05-18 |  | 103d |
| 904 |  | Re-bar | 2d | 2012-05-13 | 2012-05-14 | 873 | 103d |
| 905 |  | Formwork | 2d | 2012-05-15 | 2012-05-16 | 904 | 103d |
| 906 |  | Concrete | 2d | 2012-05-17 | 2012-05-18 | 905 | 108d |
| 907 | 1.4 | **FINISHING WORK** | 459d | 2011-04-15 | 2012-08-01 |  | 0d |
| 908 | 1.4.1 | **BASEMENT-3** | 77d | 2011-04-15 | 2011-06-30 |  | 382d |
| 909 |  | De-shuttering Roof Slab | 3d | 2011-04-15 | 2011-04-17 | 188FS+21d | 382d |
| 910 |  | Brick Work | 14d | 2011-04-18 | 2011-05-01 | 909 | 384d |

| ID | WBS | Task | Duration | Start | Finish | Predecessors | Total float |
| --- | --- | --- | --- | --- | --- | --- | --- |
| 911 |  | Plaster | 14d | 2011-04-25 | 2011-05-08 | 910FF+7d | 384d |
| 912 |  | Column Guard/ Car Stopper | 7d | 2011-06-02 | 2011-06-09 | 914SF | 404d |
| 913 |  | Stair/Other Railing | 15d | 2011-05-25 | 2011-06-09 | 914SF | 404d |
| 914 |  | Resin Floor | 15d | 2011-06-09 | 2011-06-23 | 1194FF+7d | 382d |
| 915 |  | Painting | 30d | 2011-06-01 | 2011-06-30 | 914FF+7d, 911FS+21d | 382d |
| 916 | 1.4.2 | **BASEMENT-2** | 77d | 2011-05-09 | 2011-07-24 |  | 358d |
| 917 |  | De-shuttering Roof Slab | 3d | 2011-05-09 | 2011-05-11 | 257FS+21d | 358d |
| 918 |  | Brick Work | 14d | 2011-05-12 | 2011-05-25 | 917 | 360d |
| 919 |  | Plaster | 14d | 2011-05-19 | 2011-06-01 | 918FF+7d | 360d |
| 920 |  | Column Guard/ Car Stopper | 7d | 2011-06-26 | 2011-07-03 | 922SF | 380d |
| 921 |  | Stair/Other Railing | 15d | 2011-06-18 | 2011-07-03 | 922SF | 380d |
| 922 |  | Resin Floor | 15d | 2011-07-03 | 2011-07-17 | 1195FF+7d | 358d |
| 923 |  | Painting | 30d | 2011-06-25 | 2011-07-24 | 922FF+7d, 919FS+21d | 358d |
| 924 | 1.4.3 | **BASEMENT-1** | 77d | 2011-06-03 | 2011-08-18 |  | 333d |
| 925 |  | De-shuttering Roof Slab | 3d | 2011-06-03 | 2011-06-05 | 326FS+21d | 333d |
| 926 |  | Brick Work | 14d | 2011-06-06 | 2011-06-19 | 925 | 335d |
| 927 |  | Plaster | 14d | 2011-06-13 | 2011-06-26 | 926FF+7d | 335d |
| 928 |  | Column Guard/ Car Stopper | 7d | 2011-07-21 | 2011-07-28 | 930SF | 355d |
| 929 |  | Stair/Other Railing | 15d | 2011-07-13 | 2011-07-28 | 930SF | 355d |
| 930 |  | Resin Floor | 15d | 2011-07-28 | 2011-08-11 | 1196FF+7d | 333d |
| 931 |  | Painting | 30d | 2011-07-20 | 2011-08-18 | 930FF+7d, 927FS+21d | 333d |
| 932 | 1.4.4 | **GROUND FLOOR** | 62d | 2011-06-28 | 2011-09-05 |  | 323d |
| 933 |  | De-shuttering Roof Slab | 3d | 2011-06-28 | 2011-06-30 | 366FS+21d | 323d |
| 934 |  | Brick Work | 7d | 2011-07-01 | 2011-07-07 | 933 | 323d |
| 935 |  | Plaster | 7d | 2011-07-08 | 2011-07-14 | 934FF+7d | 323d |
| 936 | 1.4.4.4 | **Toilet Cubicals** | 11d | 2011-07-15 | 2011-07-25 |  | 357d |
| 937 |  | Water/ Sewarage Pipe Lines | 3d | 2011-07-15 | 2011-07-17 | 935 | 357d |
| 938 |  | Water Proofing Works | 1d | 2011-07-18 | 2011-07-18 | 937 | 357d |
| 939 |  | Tile Works/ Marble Top | 3d | 2011-07-19 | 2011-07-21 | 938 | 357d |
| 940 |  | Cubicals Install | 3d | 2011-07-22 | 2011-07-24 | 939 | 357d |
| 941 |  | Fitting & Fixtures | 1d | 2011-07-25 | 2011-07-25 | 940 | 357d |
| 942 |  | False Ceiling Works | 15d | 2011-08-14 | 2011-09-05 | 1197 | 323d |
| 943 |  | Paver Works | 15d | 2011-07-15 | 2011-07-29 | 935 | 353d |
| 944 |  | Sone/Wood/Glazing in Wall | 14d | 2011-07-23 | 2011-08-06 | 947SF | 346d |
| 945 |  | Stair/Other Railing | 15d | 2011-07-22 | 2011-08-06 | 947SF | 346d |
| 946 |  | Granite Flooring | 10d | 2011-08-08 | 2011-08-17 | 947FF-3d | 334d |
| 947 |  | Resin Floor | 15d | 2011-08-06 | 2011-08-20 | 1197FF+7d | 324d |
| 948 |  | Fire Door Installation | 7d | 2011-08-17 | 2011-08-23 | 947FF+3d | 328d |
| 949 |  | Painting | 15d | 2011-08-13 | 2011-09-04 | 947FF+7d, 935FS+21d | 324d |
| 950 | 1.4.5 | **1ST FLOOR** | 53d | 2011-07-23 | 2011-09-21 |  | 307d |
| 951 |  | De-shuttering Roof Slab | 3d | 2011-07-23 | 2011-07-25 | 405FS+21d | 307d |
| 952 |  | Brick Work | 7d | 2011-07-26 | 2011-08-01 | 951 | 307d |
| 953 |  | Plaster | 7d | 2011-08-02 | 2011-08-08 | 952FF+7d | 307d |
| 954 | 1.4.5.4 | **Toilet Cubicals** | 11d | 2011-08-09 | 2011-08-19 |  | 332d |
| 955 |  | Water/ Sewarage Pipe Lines | 3d | 2011-08-09 | 2011-08-11 | 953 | 332d |
| 956 |  | Water Proofing Works | 1d | 2011-08-12 | 2011-08-12 | 955 | 332d |
| 957 |  | Tile Works/ Marble Top | 3d | 2011-08-13 | 2011-08-15 | 956 | 332d |
| 958 |  | Cubicals Install | 3d | 2011-08-16 | 2011-08-18 | 957 | 332d |
| 959 |  | Fitting & Fixtures | 1d | 2011-08-19 | 2011-08-19 | 958 | 332d |
| 960 |  | False Ceiling Works | 15d | 2011-08-25 | 2011-09-16 | 1198 | 312d |
| 961 |  | Sone/Wood/Glazing in Wall | 14d | 2011-08-03 | 2011-08-17 | 964SF | 335d |
| 962 |  | Stair/Other Railing | 15d | 2011-08-02 | 2011-08-17 | 964SF | 335d |
| 963 |  | Granite Flooring | 10d | 2011-08-19 | 2011-09-05 | 964FF-3d | 323d |
| 964 |  | Resin Floor | 15d | 2011-08-17 | 2011-09-08 | 1198FF+7d | 313d |
| 965 |  | Fire Door Installation | 7d | 2011-09-05 | 2011-09-11 | 964FF+3d | 317d |
| 966 |  | Painting | 15d | 2011-09-07 | 2011-09-21 | 964FF+7d, 953FS+21d | 307d |
| 967 | 1.4.6 | **2ND FLOOR** | 53d | 2011-08-17 | 2011-10-16 |  | 282d |
| 968 |  | De-shuttering Roof Slab | 3d | 2011-08-17 | 2011-08-19 | 444FS+21d | 282d |
| 969 |  | Brick Work | 7d | 2011-08-20 | 2011-09-03 | 968 | 282d |
| 970 |  | Plaster | 7d | 2011-09-04 | 2011-09-10 | 969FF+7d | 282d |
| 971 | 1.4.6.4 | **Toilet Cubicals** | 11d | 2011-09-11 | 2011-09-21 |  | 307d |
| 972 |  | Water/ Sewarage Pipe Lines | 3d | 2011-09-11 | 2011-09-13 | 970 | 307d |
| 973 |  | Water Proofing Works | 1d | 2011-09-14 | 2011-09-14 | 972 | 307d |
| 974 |  | Tile Works/ Marble Top | 3d | 2011-09-15 | 2011-09-17 | 973 | 307d |
| 975 |  | Cubicals Install | 3d | 2011-09-18 | 2011-09-20 | 974 | 307d |
| 976 |  | Fitting & Fixtures | 1d | 2011-09-21 | 2011-09-21 | 975 | 307d |
| 977 |  | False Ceiling Works | 15d | 2011-09-27 | 2011-10-11 | 1199 | 287d |
| 978 |  | Sone/Wood/Glazing in Wall | 14d | 2011-09-05 | 2011-09-19 | 981SF | 310d |
| 979 |  | Stair/Other Railing | 15d | 2011-09-04 | 2011-09-19 | 981SF | 310d |
| 980 |  | Granite Flooring | 10d | 2011-09-21 | 2011-09-30 | 981FF-3d | 298d |

| ID | WBS | Task | Duration | Start | Finish | Predecessors | Total float |
| --- | --- | --- | --- | --- | --- | --- | --- |
| 981 |  | Resin Floor | 15d | 2011-09-19 | 2011-10-03 | 1199FF+7d | 288d |
| 982 |  | Fire Door Installation | 7d | 2011-09-30 | 2011-10-06 | 981FF+3d | 292d |
| 983 |  | Painting | 15d | 2011-10-02 | 2011-10-16 | 981FF+7d, 970FS+21d | 282d |
| 984 | 1.4.7 | **3RD FLOOR** | 53d | 2011-09-19 | 2011-11-10 |  | 257d |
| 985 |  | De-shuttering Roof Slab | 3d | 2011-09-19 | 2011-09-21 | 483FS+21d | 257d |
| 986 |  | Brick Work | 7d | 2011-09-22 | 2011-09-28 | 985 | 257d |
| 987 |  | Plaster | 7d | 2011-09-29 | 2011-10-05 | 986FF+7d | 257d |
| 988 | 1.4.7.4 | **Toilet Cubicals** | 11d | 2011-10-06 | 2011-10-16 |  | 282d |
| 989 |  | Water/ Sewarage Pipe Lines | 3d | 2011-10-06 | 2011-10-08 | 987 | 282d |
| 990 |  | Water Proofing Works | 1d | 2011-10-09 | 2011-10-09 | 989 | 282d |
| 991 |  | Tile Works/ Marble Top | 3d | 2011-10-10 | 2011-10-12 | 990 | 282d |
| 992 |  | Cubicals Install | 3d | 2011-10-13 | 2011-10-15 | 991 | 282d |
| 993 |  | Fitting & Fixtures | 1d | 2011-10-16 | 2011-10-16 | 992 | 282d |
| 994 |  | False Ceiling Works | 15d | 2011-10-22 | 2011-11-05 | 1200 | 262d |
| 995 |  | Sone/Wood/Glazing in Wall | 14d | 2011-09-30 | 2011-10-14 | 998SF | 285d |
| 996 |  | Stair/Other Railing | 15d | 2011-09-29 | 2011-10-14 | 998SF | 285d |
| 997 |  | Granite Flooring | 10d | 2011-10-16 | 2011-10-25 | 998FF-3d | 273d |
| 998 |  | Resin Floor | 15d | 2011-10-14 | 2011-10-28 | 1200FF+7d | 263d |
| 999 |  | Fire Door Installation | 7d | 2011-10-25 | 2011-10-31 | 998FF+3d | 267d |
| 1000 |  | Painting | 15d | 2011-10-27 | 2011-11-10 | 998FF+7d, 987FS+21d | 257d |
| 1001 | 1.4.8 | **4TH FLOOR** | 53d | 2011-10-14 | 2011-12-13 |  | 232d |
| 1002 |  | De-shuttering Roof Slab | 3d | 2011-10-14 | 2011-10-16 | 522FS+21d | 232d |
| 1003 |  | Brick Work | 7d | 2011-10-17 | 2011-10-23 | 1002 | 232d |
| 1004 |  | Plaster | 7d | 2011-10-24 | 2011-10-30 | 1003FF+7d | 232d |
| 1005 | 1.4.8.4 | **Toilet Cubicals** | 11d | 2011-10-31 | 2011-11-10 |  | 257d |
| 1006 |  | Water/ Sewarage Pipe Lines | 3d | 2011-10-31 | 2011-11-02 | 1004 | 257d |
| 1007 |  | Water Proofing Works | 1d | 2011-11-03 | 2011-11-03 | 1006 | 257d |
| 1008 |  | Tile Works/ Marble Top | 3d | 2011-11-04 | 2011-11-06 | 1007 | 257d |
| 1009 |  | Cubicals Install | 3d | 2011-11-07 | 2011-11-09 | 1008 | 257d |
| 1010 |  | Fitting & Fixtures | 1d | 2011-11-10 | 2011-11-10 | 1009 | 257d |
| 1011 |  | False Ceiling Works | 15d | 2011-11-24 | 2011-12-08 | 1201 | 237d |
| 1012 |  | Sone/Wood/Glazing in Wall | 14d | 2011-10-25 | 2011-11-08 | 1015SF | 260d |
| 1013 |  | Stair/Other Railing | 15d | 2011-10-24 | 2011-11-08 | 1015SF | 260d |
| 1014 |  | Granite Flooring | 10d | 2011-11-10 | 2011-11-27 | 1015FF-3d | 248d |
| 1015 |  | Resin Floor | 15d | 2011-11-08 | 2011-11-30 | 1201FF+7d | 238d |
| 1016 |  | Fire Door Installation | 7d | 2011-11-27 | 2011-12-03 | 1015FF+3d | 242d |
| 1017 |  | Painting | 15d | 2011-11-29 | 2011-12-13 | 1015FF+7d, 1004FS+21d | 232d |
| 1018 | 1.4.9 | **5TH FLOOR** | 53d | 2011-11-08 | 2012-01-07 |  | 207d |
| 1019 |  | De-shuttering Roof Slab | 3d | 2011-11-08 | 2011-11-10 | 561FS+21d | 207d |
| 1020 |  | Brick Work | 7d | 2011-11-19 | 2011-11-25 | 1019 | 207d |
| 1021 |  | Plaster | 7d | 2011-11-26 | 2011-12-02 | 1020FF+7d | 207d |
| 1022 | 1.4.9.4 | **Toilet Cubicals** | 11d | 2011-12-03 | 2011-12-13 |  | 232d |
| 1023 |  | Water/ Sewarage Pipe Lines | 3d | 2011-12-03 | 2011-12-05 | 1021 | 232d |
| 1024 |  | Water Proofing Works | 1d | 2011-12-06 | 2011-12-06 | 1023 | 232d |
| 1025 |  | Tile Works/ Marble Top | 3d | 2011-12-07 | 2011-12-09 | 1024 | 232d |
| 1026 |  | Cubicals Install | 3d | 2011-12-10 | 2011-12-12 | 1025 | 232d |
| 1027 |  | Fitting & Fixtures | 1d | 2011-12-13 | 2011-12-13 | 1026 | 232d |
| 1028 |  | False Ceiling Works | 15d | 2011-12-19 | 2012-01-02 | 1202 | 212d |
| 1029 |  | Sone/Wood/Glazing in Wall | 14d | 2011-11-27 | 2011-12-11 | 1032SF | 235d |
| 1030 |  | Stair/Other Railing | 15d | 2011-11-26 | 2011-12-11 | 1032SF | 235d |
| 1031 |  | Granite Flooring | 10d | 2011-12-13 | 2011-12-22 | 1032FF-3d | 223d |
| 1032 |  | Resin Floor | 15d | 2011-12-11 | 2011-12-25 | 1202FF+7d | 213d |
| 1033 |  | Fire Door Installation | 7d | 2011-12-22 | 2011-12-28 | 1032FF+3d | 217d |
| 1034 |  | Painting | 15d | 2011-12-24 | 2012-01-07 | 1032FF+7d, 1021FS+21d | 207d |
| 1035 | 1.4.10 | **6TH FLOOR** | 53d | 2011-12-11 | 2012-02-01 |  | 182d |
| 1036 |  | De-shuttering Roof Slab | 3d | 2011-12-11 | 2011-12-13 | 600FS+21d | 182d |
| 1037 |  | Brick Work | 7d | 2011-12-14 | 2011-12-20 | 1036 | 182d |
| 1038 |  | Plaster | 7d | 2011-12-21 | 2011-12-27 | 1037FF+7d | 182d |
| 1039 | 1.4.10.4 | **Toilet Cubicals** | 11d | 2011-12-28 | 2012-01-07 |  | 207d |
| 1040 |  | Water/ Sewarage Pipe Lines | 3d | 2011-12-28 | 2011-12-30 | 1038 | 207d |
| 1041 |  | Water Proofing Works | 1d | 2011-12-31 | 2011-12-31 | 1040 | 207d |
| 1042 |  | Tile Works/ Marble Top | 3d | 2012-01-01 | 2012-01-03 | 1041 | 207d |
| 1043 |  | Cubicals Install | 3d | 2012-01-04 | 2012-01-06 | 1042 | 207d |
| 1044 |  | Fitting & Fixtures | 1d | 2012-01-07 | 2012-01-07 | 1043 | 207d |
| 1045 |  | False Ceiling Works | 15d | 2012-01-13 | 2012-01-27 | 1203 | 187d |
| 1046 |  | Sone/Wood/Glazing in Wall | 14d | 2011-12-22 | 2012-01-05 | 1049SF | 210d |
| 1047 |  | Stair/Other Railing | 15d | 2011-12-21 | 2012-01-05 | 1049SF | 210d |
| 1048 |  | Granite Flooring | 10d | 2012-01-07 | 2012-01-16 | 1049FF-3d | 198d |
| 1049 |  | Resin Floor | 15d | 2012-01-05 | 2012-01-19 | 1203FF+7d | 188d |
| 1050 |  | Fire Door Installation | 7d | 2012-01-16 | 2012-01-22 | 1049FF+3d | 192d |

| ID | WBS | Task | Duration | Start | Finish | Predecessors | Total float |
| --- | --- | --- | --- | --- | --- | --- | --- |
| 1051 |  | Painting | 15d | 2012-01-18 | 2012-02-01 | 1049FF+7d, 1038FS+21d | 182d |
| 1052 | 1.4.11 | **7TH FLOOR** | 53d | 2012-01-05 | 2012-02-26 |  | 157d |
| 1053 |  | De-shuttering Roof Slab | 3d | 2012-01-05 | 2012-01-07 | 639FS+21d | 157d |
| 1054 |  | Brick Work | 7d | 2012-01-08 | 2012-01-14 | 1053 | 157d |
| 1055 |  | Plaster | 7d | 2012-01-15 | 2012-01-21 | 1054FF+7d | 157d |
| 1056 | 1.4.11.4 | **Toilet Cubicals** | 11d | 2012-01-22 | 2012-02-01 |  | 182d |
| 1057 |  | Water/ Sewarage Pipe Lines | 3d | 2012-01-22 | 2012-01-24 | 1055 | 182d |
| 1058 |  | Water Proofing Works | 1d | 2012-01-25 | 2012-01-25 | 1057 | 182d |
| 1059 |  | Tile Works/ Marble Top | 3d | 2012-01-26 | 2012-01-28 | 1058 | 182d |
| 1060 |  | Cubicals Install | 3d | 2012-01-29 | 2012-01-31 | 1059 | 182d |
| 1061 |  | Fitting & Fixtures | 1d | 2012-02-01 | 2012-02-01 | 1060 | 182d |
| 1062 |  | False Ceiling Works | 15d | 2012-02-07 | 2012-02-21 | 1204 | 162d |
| 1063 |  | Sone/Wood/Glazing in Wall | 14d | 2012-01-16 | 2012-01-30 | 1066SF | 185d |
| 1064 |  | Stair/Other Railing | 15d | 2012-01-15 | 2012-01-30 | 1066SF | 185d |
| 1065 |  | Granite Flooring | 10d | 2012-02-01 | 2012-02-10 | 1066FF-3d | 173d |
| 1066 |  | Resin Floor | 15d | 2012-01-30 | 2012-02-13 | 1204FF+7d | 163d |
| 1067 |  | Fire Door Installation | 7d | 2012-02-10 | 2012-02-16 | 1066FF+3d | 167d |
| 1068 |  | Painting | 15d | 2012-02-12 | 2012-02-26 | 1066FF+7d, 1055FS+21d | 157d |
| 1069 | 1.4.12 | **8TH FLOOR** | 53d | 2012-02-11 | 2012-04-03 |  | 120d |
| 1070 |  | De-shuttering Roof Slab | 3d | 2012-02-11 | 2012-02-13 | 680FS+21d | 120d |
| 1071 |  | Brick Work | 7d | 2012-02-14 | 2012-02-20 | 1070 | 120d |
| 1072 |  | Plaster | 7d | 2012-02-21 | 2012-02-27 | 1071FF+7d | 120d |
| 1073 | 1.4.12.4 | **Toilet Cubicals** | 11d | 2012-02-28 | 2012-03-09 |  | 145d |
| 1074 |  | Water/ Sewarage Pipe Lines | 3d | 2012-02-28 | 2012-03-01 | 1072 | 145d |
| 1075 |  | Water Proofing Works | 1d | 2012-03-02 | 2012-03-02 | 1074 | 145d |
| 1076 |  | Tile Works/ Marble Top | 3d | 2012-03-03 | 2012-03-05 | 1075 | 145d |
| 1077 |  | Cubicals Install | 3d | 2012-03-06 | 2012-03-08 | 1076 | 145d |
| 1078 |  | Fitting & Fixtures | 1d | 2012-03-09 | 2012-03-09 | 1077 | 145d |
| 1079 |  | False Ceiling Works | 15d | 2012-03-15 | 2012-03-29 | 1205 | 125d |
| 1080 |  | Sone/Wood/Glazing in Wall | 14d | 2012-02-22 | 2012-03-07 | 1083SF | 148d |
| 1081 |  | Stair/Other Railing | 15d | 2012-02-21 | 2012-03-07 | 1083SF | 148d |
| 1082 |  | Granite Flooring | 10d | 2012-03-09 | 2012-03-18 | 1083FF-3d | 136d |
| 1083 |  | Resin Floor | 15d | 2012-03-07 | 2012-03-21 | 1205FF+7d | 126d |
| 1084 |  | Fire Door Installation | 7d | 2012-03-18 | 2012-03-24 | 1083FF+3d | 130d |
| 1085 |  | Painting | 15d | 2012-03-20 | 2012-04-03 | 1083FF+7d, 1072FS+21d | 120d |
| 1086 | 1.4.13 | **9TH FLOOR** | 53d | 2012-02-24 | 2012-04-16 |  | 107d |
| 1087 |  | De-shuttering Roof Slab | 3d | 2012-02-24 | 2012-02-26 | 717FS+21d | 107d |
| 1088 |  | Brick Work | 7d | 2012-02-27 | 2012-03-04 | 1087 | 107d |
| 1089 |  | Plaster | 7d | 2012-03-05 | 2012-03-11 | 1088FF+7d | 107d |
| 1090 | 1.4.13.4 | **Toilet Cubicals** | 11d | 2012-03-12 | 2012-03-22 |  | 132d |
| 1091 |  | Water/ Sewarage Pipe Lines | 3d | 2012-03-12 | 2012-03-14 | 1089 | 132d |
| 1092 |  | Water Proofing Works | 1d | 2012-03-15 | 2012-03-15 | 1091 | 132d |
| 1093 |  | Tile Works/ Marble Top | 3d | 2012-03-16 | 2012-03-18 | 1092 | 132d |
| 1094 |  | Cubicals Install | 3d | 2012-03-19 | 2012-03-21 | 1093 | 132d |
| 1095 |  | Fitting & Fixtures | 1d | 2012-03-22 | 2012-03-22 | 1094 | 132d |
| 1096 |  | False Ceiling Works | 15d | 2012-03-28 | 2012-04-11 | 1206 | 112d |
| 1097 |  | Sone/Wood/Glazing in Wall | 14d | 2012-03-06 | 2012-03-20 | 1100SF | 135d |
| 1098 |  | Stair/Other Railing | 15d | 2012-03-05 | 2012-03-20 | 1100SF | 135d |
| 1099 |  | Granite Flooring | 10d | 2012-03-22 | 2012-03-31 | 1100FF-3d | 123d |
| 1100 |  | Resin Floor | 15d | 2012-03-20 | 2012-04-03 | 1206FF+7d | 113d |
| 1101 |  | Fire Door Installation | 7d | 2012-03-31 | 2012-04-06 | 1100FF+3d | 117d |
| 1102 |  | Painting | 15d | 2012-04-02 | 2012-04-16 | 1100FF+7d, 1089FS+21d | 107d |
| 1103 | 1.4.14 | **10TH FLOOR** | 53d | 2012-03-20 | 2012-05-11 |  | 82d |
| 1104 |  | De-shuttering Roof Slab | 3d | 2012-03-20 | 2012-03-22 | 756FS+21d | 82d |
| 1105 |  | Brick Work | 7d | 2012-03-23 | 2012-03-29 | 1104 | 82d |
| 1106 |  | Plaster | 7d | 2012-03-30 | 2012-04-05 | 1105FF+7d | 82d |
| 1107 | 1.4.14.4 | **Toilet Cubicals** | 11d | 2012-04-06 | 2012-04-16 |  | 107d |
| 1108 |  | Water/ Sewarage Pipe Lines | 3d | 2012-04-06 | 2012-04-08 | 1106 | 107d |
| 1109 |  | Water Proofing Works | 1d | 2012-04-09 | 2012-04-09 | 1108 | 107d |
| 1110 |  | Tile Works/ Marble Top | 3d | 2012-04-10 | 2012-04-12 | 1109 | 107d |
| 1111 |  | Cubicals Install | 3d | 2012-04-13 | 2012-04-15 | 1110 | 107d |
| 1112 |  | Fitting & Fixtures | 1d | 2012-04-16 | 2012-04-16 | 1111 | 107d |
| 1113 |  | False Ceiling Works | 15d | 2012-04-22 | 2012-05-06 | 1207 | 87d |
| 1114 |  | Sone/Wood/Glazing in Wall | 14d | 2012-03-31 | 2012-04-14 | 1117SF | 110d |
| 1115 |  | Stair/Other Railing | 15d | 2012-03-30 | 2012-04-14 | 1117SF | 110d |
| 1116 |  | Granite Flooring | 10d | 2012-04-16 | 2012-04-25 | 1117FF-3d | 98d |
| 1117 |  | Resin Floor | 15d | 2012-04-14 | 2012-04-28 | 1207FF+7d | 88d |
| 1118 |  | Fire Door Installation | 7d | 2012-04-25 | 2012-05-01 | 1117FF+3d | 92d |
| 1119 |  | Painting | 15d | 2012-04-27 | 2012-05-11 | 1117FF+7d, 1106FS+21d | 82d |
| 1120 | 1.4.15 | **11TH FLOOR** | 53d | 2012-04-14 | 2012-06-05 |  | 57d |

| ID | WBS | Task | Duration | Start | Finish | Predecessors | Total float |
| --- | --- | --- | --- | --- | --- | --- | --- |
| 1121 |  | De-shuttering Roof Slab | 3d | 2012-04-14 | 2012-04-16 | 795FS+21d | 57d |
| 1122 |  | Brick Work | 7d | 2012-04-17 | 2012-04-23 | 1121 | 57d |
| 1123 |  | Plaster | 7d | 2012-04-24 | 2012-04-30 | 1122FF+7d | 57d |
| 1124 | 1.4.15.4 | **Toilet Cubicals** | 11d | 2012-05-01 | 2012-05-11 |  | 82d |
| 1125 |  | Water/ Sewarage Pipe Lines | 3d | 2012-05-01 | 2012-05-03 | 1123 | 82d |
| 1126 |  | Water Proofing Works | 1d | 2012-05-04 | 2012-05-04 | 1125 | 82d |
| 1127 |  | Tile Works/ Marble Top | 3d | 2012-05-05 | 2012-05-07 | 1126 | 82d |
| 1128 |  | Cubicals Install | 3d | 2012-05-08 | 2012-05-10 | 1127 | 82d |
| 1129 |  | Fitting & Fixtures | 1d | 2012-05-11 | 2012-05-11 | 1128 | 82d |
| 1130 |  | False Ceiling Works | 15d | 2012-05-17 | 2012-05-31 | 1208 | 62d |
| 1131 |  | Sone/Wood/Glazing in Wall | 14d | 2012-04-25 | 2012-05-09 | 1134SF | 85d |
| 1132 |  | Stair/Other Railing | 15d | 2012-04-24 | 2012-05-09 | 1134SF | 85d |
| 1133 |  | Granite Flooring | 10d | 2012-05-11 | 2012-05-20 | 1134FF-3d | 73d |
| 1134 |  | Resin Floor | 15d | 2012-05-09 | 2012-05-23 | 1208FF+7d | 63d |
| 1135 |  | Fire Door Installation | 7d | 2012-05-20 | 2012-05-26 | 1134FF+3d | 67d |
| 1136 |  | Painting | 15d | 2012-05-22 | 2012-06-05 | 1134FF+7d, 1123FS+21d | 57d |
| 1137 | 1.4.16 | **12TH FLOOR** | 53d | 2012-05-09 | 2012-06-30 |  | 32d |
| 1138 |  | De-shuttering Roof Slab | 3d | 2012-05-09 | 2012-05-11 | 834FS+21d | 32d |
| 1139 |  | Brick Work | 7d | 2012-05-12 | 2012-05-18 | 1138 | 32d |
| 1140 |  | Plaster | 7d | 2012-05-19 | 2012-05-25 | 1139FF+7d | 32d |
| 1141 | 1.4.16.4 | **Toilet Cubicals** | 11d | 2012-05-26 | 2012-06-05 |  | 57d |
| 1142 |  | Water/ Sewarage Pipe Lines | 3d | 2012-05-26 | 2012-05-28 | 1140 | 57d |
| 1143 |  | Water Proofing Works | 1d | 2012-05-29 | 2012-05-29 | 1142 | 57d |
| 1144 |  | Tile Works/ Marble Top | 3d | 2012-05-30 | 2012-06-01 | 1143 | 57d |
| 1145 |  | Cubicals Install | 3d | 2012-06-02 | 2012-06-04 | 1144 | 57d |
| 1146 |  | Fitting & Fixtures | 1d | 2012-06-05 | 2012-06-05 | 1145 | 57d |
| 1147 |  | False Ceiling Works | 15d | 2012-06-11 | 2012-06-25 | 1209 | 37d |
| 1148 |  | Sone/Wood/Glazing in Wall | 14d | 2012-05-20 | 2012-06-03 | 1151SF | 60d |
| 1149 |  | Stair/Other Railing | 15d | 2012-05-19 | 2012-06-03 | 1151SF | 60d |
| 1150 |  | Granite Flooring | 10d | 2012-06-05 | 2012-06-14 | 1151FF-3d | 48d |
| 1151 |  | Resin Floor | 15d | 2012-06-03 | 2012-06-17 | 1209FF+7d | 38d |
| 1152 |  | Fire Door Installation | 7d | 2012-06-14 | 2012-06-20 | 1151FF+3d | 42d |
| 1153 |  | Painting | 15d | 2012-06-16 | 2012-06-30 | 1151FF+7d, 1140FS+21d | 32d |
| 1154 | 1.4.17 | **13TH FLOOR** | 48d | 2012-06-03 | 2012-07-20 |  | 12d |
| 1155 |  | De-shuttering Roof Slab | 3d | 2012-06-03 | 2012-06-05 | 873FS+21d | 12d |
| 1156 |  | Brick Work | 7d | 2012-06-06 | 2012-06-12 | 1155 | 22d |
| 1157 |  | Plaster | 7d | 2012-06-13 | 2012-06-19 | 1156FF+7d | 22d |
| 1158 | 1.4.17.4 | **Toilet Cubicals** | 11d | 2012-06-20 | 2012-06-30 |  | 32d |
| 1159 |  | Water/ Sewarage Pipe Lines | 3d | 2012-06-20 | 2012-06-22 | 1157 | 32d |
| 1160 |  | Water Proofing Works | 1d | 2012-06-23 | 2012-06-23 | 1159 | 32d |
| 1161 |  | Tile Works/ Marble Top | 3d | 2012-06-24 | 2012-06-26 | 1160 | 32d |
| 1162 |  | Cubicals Install | 3d | 2012-06-27 | 2012-06-29 | 1161 | 32d |
| 1163 |  | Fitting & Fixtures | 1d | 2012-06-30 | 2012-06-30 | 1162 | 32d |
| 1164 |  | False Ceiling Works | 15d | 2012-07-06 | 2012-07-20 | 1210 | 12d |
| 1165 |  | Sone/Wood/Glazing in Wall | 14d | 2012-06-14 | 2012-06-28 | 1168SF | 35d |
| 1166 |  | Stair/Other Railing | 15d | 2012-06-13 | 2012-06-28 | 1168SF | 35d |
| 1167 |  | Granite Flooring | 10d | 2012-06-30 | 2012-07-09 | 1168FF-3d | 23d |
| 1168 |  | Resin Floor | 15d | 2012-06-28 | 2012-07-12 | 1210FF+7d | 13d |
| 1169 |  | Fire Door Installation | 7d | 2012-07-09 | 2012-07-15 | 1168FF+3d | 17d |
| 1170 |  | Painting | 15d | 2012-07-05 | 2012-07-19 | 1168FF+7d, 1157FF+21d | 13d |
| 1171 | 1.4.18 | **MACHINE FLOOR** | 40d | 2012-06-23 | 2012-08-01 |  | 0d |
| 1172 |  | Brick Work | 7d | 2012-06-23 | 2012-06-29 | 896FS+21d | 0d |
| 1173 |  | Plaster | 5d | 2012-06-30 | 2012-07-04 | 1172 | 0d |
| 1174 |  | Painting | 7d | 2012-07-26 | 2012-08-01 | 1211FF+7d, 1173FS+21d | 0d |
| 1175 | 1.4.18.4 | **Sweeming Pool** | 31d | 2012-06-23 | 2012-07-23 |  | 9d |
| 1176 |  | Deshuttering | 1d | 2012-06-23 | 2012-06-23 | 1172SS | 9d |
| 1177 |  | Making Steps | 3d | 2012-06-24 | 2012-06-26 | 1176 | 9d |
| 1178 |  | Water Proofing | 10d | 2012-06-27 | 2012-07-06 | 1177 | 9d |
| 1179 |  | Lean Concrete | 1d | 2012-07-07 | 2012-07-07 | 1178 | 9d |
| 1180 |  | Granaite Plaster | 3d | 2012-07-08 | 2012-07-10 | 1179 | 9d |
| 1181 |  | Tile Work | 10d | 2012-07-11 | 2012-07-20 | 1180 | 9d |
| 1182 |  | MEP Fittings | 3d | 2012-07-21 | 2012-07-23 | 1181 | 9d |
| 1183 | 1.4.18.5 | **Planter Box** | 24d | 2012-07-05 | 2012-07-28 |  | 4d |
| 1184 |  | Water Proofing | 10d | 2012-07-05 | 2012-07-14 | 1173 | 4d |
| 1185 |  | Making Bed For Plantation | 7d | 2012-07-15 | 2012-07-21 | 1184 | 4d |
| 1186 |  | Plantation | 7d | 2012-07-22 | 2012-07-28 | 1185 | 4d |
| 1187 | 1.4.18.6 | **Open Terrace** | 20d | 2012-07-05 | 2012-07-24 |  | 8d |
| 1188 |  | Water Proofing | 10d | 2012-07-05 | 2012-07-14 | 1173 | 8d |
| 1189 |  | Paver Fixing | 10d | 2012-07-15 | 2012-07-24 | 1188 | 8d |
| 1190 | 1.4.19 | **TOP ROOF SLAB** | 20d | 2012-07-05 | 2012-07-24 |  | 8d |

| ID | WBS | Task | Duration | Start | Finish | Predecessors | Total float |
| --- | --- | --- | --- | --- | --- | --- | --- |
| 1191 |  | Water proofing | 10d | 2012-07-05 | 2012-07-14 | 1173, 1218 | 8d |
| 1192 |  | Paver Fixing | 10d | 2012-07-15 | 2012-07-24 | 1191 | 8d |
| 1193 | 1.5 | **MEP WORKS** | 443d | 2011-04-18 | 2012-07-19 |  | 30d |
| 1194 |  | BASEMENT-3 | 60d | 2011-04-18 | 2011-06-16 | 909 | 382d |
| 1195 |  | BASEMENT-2 | 60d | 2011-05-12 | 2011-07-10 | 917 | 358d |
| 1196 |  | BASEMENT-1 | 60d | 2011-06-06 | 2011-08-04 | 925 | 333d |
| 1197 |  | GROUND FLOOR | 30d | 2011-07-15 | 2011-08-13 | 935 | 323d |
| 1198 |  | 1ST FLOOR | 30d | 2011-07-26 | 2011-08-24 | 951 | 312d |
| 1199 |  | 2ND FLOOR | 30d | 2011-08-20 | 2011-09-26 | 968 | 287d |
| 1200 |  | 3RD FLOOR | 30d | 2011-09-22 | 2011-10-21 | 985 | 262d |
| 1201 |  | 4TH FLOOR | 30d | 2011-10-17 | 2011-11-23 | 1002 | 237d |
| 1202 |  | 5TH FLOOR | 30d | 2011-11-19 | 2011-12-18 | 1019 | 212d |
| 1203 |  | 6TH FLOOR | 30d | 2011-12-14 | 2012-01-12 | 1036 | 187d |
| 1204 |  | 7TH FLOOR | 30d | 2012-01-08 | 2012-02-06 | 1053 | 162d |
| 1205 |  | 8TH FLOOR | 30d | 2012-02-14 | 2012-03-14 | 1070 | 125d |
| 1206 |  | 9TH FLOOR | 30d | 2012-02-27 | 2012-03-27 | 1087 | 112d |
| 1207 |  | 10 TH FLOOR | 30d | 2012-03-23 | 2012-04-21 | 1104 | 87d |
| 1208 |  | 11TH FLOOR | 30d | 2012-04-17 | 2012-05-16 | 1121 | 62d |
| 1209 |  | 12TH FLOOR | 30d | 2012-05-12 | 2012-06-10 | 1138 | 37d |
| 1210 |  | 13TH FLOOR | 30d | 2012-06-06 | 2012-07-05 | 1155 | 12d |
| 1211 |  | MACHINE FLOOR | 60d | 2012-05-21 | 2012-07-19 | 1173FF+15d | 6d |
| 1212 |  | MEP WORKS - OUTSIDE | 60d | 2012-05-21 | 2012-07-19 | 1211FF | 30d |
| 1213 | 1.6 | **OUTSIDE FINISHING** | 67d | 2012-06-01 | 2012-08-06 |  | 28d |
| 1214 |  | PLASTER REPAIR | 15d | 2012-06-01 | 2012-06-15 | 895 | 28d |
| 1215 |  | CURTAIN WALL | 45d | 2012-06-16 | 2012-07-30 | 1214 | 28d |
| 1216 |  | TITANIUM | 15d | 2012-06-16 | 2012-06-30 | 1214 | 65d |
| 1217 |  | LOUVER FIXING | 7d | 2012-07-31 | 2012-08-06 | 1215 | 28d |
| 1218 |  | CLOSING SLAB AFTER TC DISMANTLING | 30d | 2012-06-04 | 2012-07-03 | 48 | 9d |
| 1219 |  | LAND SCAPING | 60d | 2012-07-05 | 2012-09-10 | 1212FF+15d, 47FF+15d | 0d |
| 1220 |  | PROJECT COMPLETE | 1d | 2012-09-11 | 2012-09-11 | 1219 | 0d |

## Version 2 (data date 2011-01-31, saved 2011-02-02, file 04. Ekushey Bhaban Program-Progress (Rev-3.0) 22 Jan 2011.mpp)

Last finish 2012-09-11 → 2012-09-19 (+8d). Complete tasks 23 → 120.

Added:

| ID | Task | Duration | Start | Finish | Predecessors | Constraint | Resources |
| --- | --- | --- | --- | --- | --- | --- | --- |
| 62 | MS Pipe | 1d | 2010-10-11 A | 2010-10-11 A |  |  | King Post- MS Pipe -250mm dia [8 ton]; MS Plate-12mm thick [2.5 ton] |
| 63 | MS Joist -1 | 1d | 2010-10-20 A | 2010-10-20 A |  | must finish on 2010-10-20 | I Joist (6"x14"/6"x16"x10/12mm) [17 ton]; Anchor Bolt-1/2" dia 6" Long [350 Nos]; Anchor Bolt-1/2" dia 7" Long [100 Nos.]; Anchor Bolt-1/2" dia 8" Long [1000 Nos.]; Rowel Bolt-1/2" dia 4" Long [200 Nos.] |
| 64 | MS Joist -2 | 1d | 2010-10-27 A | 2010-10-27 A |  | must finish on 2010-10-27 | I Joist (6"x14"/6"x16"x10/12mm) [16 ton] |
| 65 | MS Joist -3 | 1d | 2010-11-03 A | 2010-11-03 A |  | must finish on 2010-11-03 | I Joist (6"x14"/6"x16"x10/12mm) [20.5 ton] |
| 66 | MS Joist -4 | 0.5d | 2010-12-01 A | 2010-12-01 A |  | must start on 2010-12-01 | I Joist (6"x14"/6"x16"x10/12mm) [26.5 ton] |
| 67 | MS Joist -5 | 1d | 2010-12-01 A | 2010-12-01 A |  | must finish on 2010-12-01 |  |
| 69 | Section # a/d : East to west 0' to 30' span | 4d | 2010-10-04 A | 2010-10-07 A | 60SS+2d |  | Excavation up to 10ft [20775.2 cft]; Excavation from 11ft to 20 ft [10388.1 cft] |
| 70 | Section # b/c : East to west 31' to 60' span | 4d | 2010-10-08 A | 2010-10-11 A | 69 |  | Excavation up to 10ft [20777.2 cft]; Excavation from 11ft to 20 ft [10388.1 cft] |
| 71 | Section # c/b : East to west 61' to 90' span | 4d | 2010-10-12 A | 2010-10-15 A | 70 |  | Excavation up to 10ft [20776.2 cft]; Excavation from 11ft to 20 ft [10388.1 cft] |
| 72 | Section # d/a : East to west 91' to 112' span | 7d | 2010-10-16 A | 2010-10-22 A | 71 |  | Excavation up to 10ft [20776.2 cft]; Excavation from 11ft to 20 ft [10388.1 cft] |
| 74 | **Pipe driving work** | 18d | 2010-10-14 A | 2010-10-31 A |  |  |  |
| 75 | Section # d : East to west 0' to 30' span | 6d | 2010-10-14 A | 2010-10-19 A | 70FS+2d |  | Bracing-MS Pipe Driving [3 nos] |
| 76 | Section # c : East to west 31' to 60' span | 6d | 2010-10-18 A | 2010-10-23 A | 75FF+4d |  | Bracing-MS Pipe Driving [3 nos] |
| 77 | Section # b : East to west 61' to 90' span | 6d | 2010-10-22 A | 2010-10-27 A | 76FF+4d |  | Bracing-MS Pipe Driving [3 nos] |
| 78 | Section # a : East to west 91' to 112' span | 6d | 2010-10-26 A | 2010-10-31 A | 77FF+4d |  | Bracing-MS Pipe Driving [3 nos] |
| 79 | **Peripheral joist setting work** | 18d | 2010-10-17 A | 2010-11-03 A |  |  |  |
| 80 | Section # d : East to west 0' to 30' span | 6d | 2010-10-17 A | 2010-10-22 A | 75SS+3d |  | Bracing-MS Joist Fixing [12000 kg] |
| 81 | Section # c : East to west 31' to 60' span | 6d | 2010-10-21 A | 2010-10-26 A | 80FF+4d |  | Bracing-MS Joist Fixing [12000 kg] |
| 82 | Section # b : East to west 61' to 90' span | 6d | 2010-10-25 A | 2010-10-30 A | 81FF+4d |  | Bracing-MS Joist Fixing [12000 kg] |
| 83 | Section # a : East to west 91' to 112' span | 6d | 2010-10-29 A | 2010-11-03 A | 82FF+4d |  | Bracing-MS Joist Fixing [12000 kg] |
| 85 | Section # d : East to west 0' to 30' span | 14d | 2010-10-15 A | 2010-10-28 A | 75SS+1d |  | Excavation from 11ft to 20 ft [10388.1 cft]; Excavation from 21ft to 30 ft [20776.2 cft] |
| 86 | Section # c : East to west 31' to 60' span | 14d | 2010-10-19 A | 2010-11-01 A | 85FF+4d |  | Excavation from 11ft to 20 ft [10388.1 cft]; Excavation from 21ft to 30 ft [20776.2 cft] |
| 87 | Section # b : East to west 61' to 90' span | 14d | 2010-10-23 A | 2010-11-05 A | 86FF+4d |  | Excavation from 11ft to 20 ft [10388.1 cft]; Excavation from 21ft to 30 ft [20776.2 cft] |
| 88 | Section # a : East to west 91' to 112' span | 14d | 2010-10-30 A | 2010-11-12 A | 87FF+7d |  | Excavation from 11ft to 20 ft [10388.1 cft]; Excavation from 21ft to 30 ft [20776.2 cft] |
| 89 | **Diagonal joist setting work** | 27d | 2010-10-24 A | 2010-11-27 A |  |  |  |
| 90 | Section # a : East to west 0' to 30' span | 10d | 2010-10-24 A | 2010-11-02 A | 80FS+1d |  | Bracing-MS Joist Fixing [9000 kg] |
| 91 | Section # b : East to west 31' to 60' span | 10d | 2010-10-28 A | 2010-11-06 A | 90FF+4d |  | Bracing-MS Joist Fixing [9000 kg] |
| 92 | Section # c : East to west 61' to 90' span | 10d | 2010-11-01 A | 2010-11-10 A | 91FF+4d |  | Bracing-MS Joist Fixing [9000 kg] |
| 93 | Section # d : East to west 91' to 112' span | 14d | 2010-11-06 A | 2010-11-27 A | 92FF+9d |  | Bracing-MS Joist Fixing [8250 kg] |
| 94 | **Earth excavn.-Phase 3: Barm+ extra** | 33d | 2010-10-26 A | 2010-12-05 A |  |  |  |
| 95 | Section # a/d : East to west 0' to 30' span | 15d | 2010-10-26 A | 2010-11-09 A | 90SS+2d |  | Excavation from 31ft to 33'-5" [7105.47 cft] |
| 96 | Section # b/c : East to west 31' to 60' span | 15d | 2010-10-29 A | 2010-11-12 A | 95FF+3d |  | Excavation from 31ft to 33'-5" [7105.47 cft] |
| 97 | Section # c/b : East to west 61' to 90' span | 15d | 2010-11-05 A | 2010-11-27 A | 96FF+7d |  | Excavation from 31ft to 33'-5" [7105.47 cft] |
| 98 | Section # d/a : East to west 91' to 112' span | 15d | 2010-11-13 A | 2010-12-05 A | 97FF+8d |  | Excavation from 31ft to 33'-5" [7105.47 cft]; Excavation above 0.0 [13267.5 cft] |

Changed:

| ID | Task | Start | Finish | Duration | Complete | Total float | Predecessors | Other |
| --- | --- | --- | --- | --- | --- | --- | --- | --- |
| 1 | **EKUSHEY BHABAN** | 2010-03-26 A → 2010-01-25 A (-60d) | 2012-09-11 → 2012-09-19 (+8d) | 862d → 927.86d | 6% → 18% |  |  | baseline start none → 2010-03-26; baseline finish none → 2012-09-12 |
| 2 | **PRELIMINARIES** | 2010-03-26 A → 2010-01-25 A (-60d) | 2012-08-20 → 2012-08-28 (+8d) | 846d → 911.86d | 32% → 87% |  |  | baseline start none → 2010-03-26; baseline finish none → 2012-08-21 |
| 3 | **MOBILIZATION-1-TEMPORARY OFFICE-SHED** | 2010-03-26 A → 2010-01-25 A (-60d) |  | 22d → 82d |  |  |  | baseline start none → 2010-03-26; baseline finish none → 2010-04-16 |
| 4 | Mud Tank | 2010-03-26 A → 2010-01-25 A (-60d) | 2010-04-03 A → 2010-02-02 A (-60d) |  |  |  |  | baseline start none → 2010-03-26; baseline finish none → 2010-03-26 |
| 5 | Land Development | 2010-04-04 A → 2010-02-03 A (-60d) | 2010-04-07 A → 2010-02-06 A (-60d) |  |  |  |  | baseline start none → 2010-04-04; baseline finish none → 2010-04-04 |
| 6 | Office Shed |  |  |  |  |  |  | baseline start none → 2010-04-08; baseline finish none → 2010-04-08 |
| 7 | Labour Shed |  |  |  |  |  |  | baseline start none → 2010-04-08; baseline finish none → 2010-04-08 |
| 8 | Cement Store |  |  |  |  |  |  | baseline start none → 2010-04-08; baseline finish none → 2010-04-08 |
| 9 | Staff Residence |  |  |  |  |  |  | baseline start none → 2010-04-08; baseline finish none → 2010-04-08 |
| 10 | Toilet |  |  |  |  |  |  | baseline start none → 2010-04-08; baseline finish none → 2010-04-08 |
| 11 | Main Gate-1 |  |  |  |  |  |  | baseline start none → 2010-04-04; baseline finish none → 2010-04-04 |
| 12 | Electrical Wiring |  |  |  |  |  |  | baseline start none → 2010-04-15; baseline finish none → 2010-04-15 |
| 13 | **MOBILIZATION-2 -INFRASTRUCTURE** |  | 2010-08-25 A |  | 89% → 100% | 701d → none |  | baseline start none → 2010-08-11; baseline finish none → 2010-08-25 |
| 14 | East Side Bed Preparation |  |  |  |  |  | 54FS-5d → 57FS-5d | baseline start none → 2010-08-11; baseline finish none → 2010-08-12 |
| 15 | Labour Shed & Kitchen Making |  | 2010-08-20 A |  | 90% → 100% | 706d → none |  | baseline start none → 2010-08-12; baseline finish none → 2010-08-20 |
| 16 | South Side Bed Preparation |  |  |  |  |  |  | baseline start none → 2010-08-12; baseline finish none → 2010-08-14 |
| 17 | Cement Shed, Residence, Office & Toilet Making |  | 2010-08-20 A |  | 85% → 100% | 706d → none |  | baseline start none → 2010-08-13; baseline finish none → 2010-08-20 |
| 18 | North Side Bed Preparation |  |  |  |  |  |  | baseline start none → 2010-08-22; baseline finish none → 2010-08-25 |
| 19 | Soling, CC for Woking Bed |  |  |  |  |  |  | baseline start none → 2010-08-23; baseline finish none → 2010-08-25 |
| 20 | West Side Bed Preparation |  |  |  |  |  |  | baseline start none → 2010-08-15; baseline finish none → 2010-08-17 |
| 21 | Security Room Making |  | 2010-08-22 A |  | 90% → 100% | 704d → none |  | baseline start none → 2010-08-16; baseline finish none → 2010-08-22 |
| 22 | Water Tank Tower Making & Shifting of Water Line From West to Est |  |  |  |  |  |  | baseline start none → 2010-08-12; baseline finish none → 2010-08-20 |
| 23 | Rain Water Drainage System (South) |  |  |  |  |  |  | baseline start none → 2010-08-13; baseline finish none → 2010-08-20 |
| 24 | Rain Water Drainage System (East) |  |  |  |  |  |  | baseline start none → 2010-08-12; baseline finish none → 2010-08-20 |
| 25 | Water Reservoir Making (North) |  |  |  |  |  |  | baseline start none → 2010-08-22; baseline finish none → 2010-08-25 |
| 26 | Generator Base Making |  |  |  |  |  |  | baseline start none → 2010-08-13; baseline finish none → 2010-08-20 |
| 27 | Electrical Pipe Wiring | 2010-08-20 A | 2010-08-25 A |  | 0% → 100% | 726d → none |  | baseline start none → 2010-08-20; baseline finish none → 2010-08-25 |
| 28 | **MOBILIZATION-3-GENERATOR & TOWER CRANE** | 2010-07-29 A | 2010-08-30 A |  | 0% → 100% | 699d → none |  | baseline start none → 2010-07-29; baseline finish none → 2010-08-30 |
| 29 | **Generator** | 2010-07-29 A | 2010-08-30 A |  | 0% → 100% | 699d → none |  | baseline start none → 2010-07-29; baseline finish none → 2010-08-30 |
| 30 | Supply | 2010-07-29 A | 2010-08-27 A |  | 0% → 100% | 724d → none |  | baseline start none → 2010-07-29; baseline finish none → 2010-08-27 |
| 31 | Installation | 2010-08-28 A | 2010-08-30 A |  | 0% → 100% | 721d → none |  | baseline start none → 2010-08-28; baseline finish none → 2010-08-30 |
| 32 | **PREPARATION FOR STRUCTURAL CONSTRUCTION** | 2010-08-21 A | 2010-12-30 → 2010-12-28 A (-2d) | 117d → 115d | 0% → 100% | 0d → none |  | was named PREPARTION FOR STRUCTURAL CONSTRUCTION; baseline start none → 2010-08-21; baseline finish none → 2010-12-31 |
| 33 | Selection of Civil Contractor | 2010-08-21 A | 2010-10-01 A |  | 0% → 100% | 0d → none |  | baseline start none → 2010-08-21; baseline finish none → 2010-10-01 |
| 34 | Develop of Construction Method | 2010-09-02 A | 2010-10-08 A |  | 0% → 100% | 672d → none | 33FF+7d → 103 | baseline start none → 2010-09-02; baseline finish none → 2010-10-08 |
| 35 | Selection of Ready-mix Supplier | 2010-09-17 → 2010-11-01 A (+45d) | 2010-09-23 → 2010-11-07 A (+45d) |  | 0% → 100% | 687d → none | 34SS+8d → 103SF-7d | baseline start none → 2010-09-17; baseline finish none → 2010-09-23 |
| 36 | Structural Design Vetting From BUET | 2010-08-25 → 2010-09-27 A (+33d) | 2010-10-15 → 2010-11-10 A (+26d) |  | 0% → 100% | 11d → none | none → 107SF-7d | baseline start none → 2010-08-25; baseline finish none → 2010-10-15 |
| 37 | Drill Work for Safety/ Safety Induction | 2010-11-30 → 2010-11-02 A (-28d) | 2010-12-01 → 2010-11-03 A (-28d) |  | 0% → 100% | 626d → none |  | was named Drill Work for Safety; baseline start none → 2010-11-30; baseline finish none → 2010-12-01 |
| 38 | Selection & Agreement With Clinic for Medical Service | 2010-10-09 → 2010-11-04 A (+26d) | 2010-10-15 → 2010-11-10 A (+26d) |  | 0% → 100% | 660d → none |  | baseline start none → 2010-10-09; baseline finish none → 2010-10-15 |
| 39 | Design Collection & Estimation of Structural Cost | 2010-11-04 → 2010-11-11 A (+7d) | 2010-12-01 → 2010-12-28 A (+27d) | 20d → 40d | 0% → 100% | 626d → none | 73FF → 36 | baseline start none → 2010-11-04; baseline finish none → 2010-12-01 |
| 40 | Selection of MEP Contractor | 2010-12-21 → 2010-11-04 A (-47d) | 2010-12-30 → 2010-11-13 A (-47d) |  | 0% → 100% | 597d → none |  | baseline start none → 2010-12-21; baseline finish none → 2010-12-30 |
| 41 | **MOBILIZATION-4-TOWER CRANE** | 2011-09-23 → 2011-09-28 (+5d) | 2011-10-24 → 2011-10-30 (+6d) |  |  |  |  | baseline start none → 2011-09-23; baseline finish none → 2011-10-25 |
| 42 | Selection | 2011-09-23 → 2011-09-28 (+5d) | 2011-10-08 → 2011-10-13 (+5d) |  |  |  |  | baseline start none → 2011-09-23; baseline finish none → 2011-10-09 |
| 43 | Foundation | 2011-10-08 → 2011-10-13 (+5d) | 2011-10-11 → 2011-10-16 (+5d) |  |  |  |  | baseline start none → 2011-10-08; baseline finish none → 2011-10-12 |
| 44 | Installation | 2011-10-18 → 2011-10-23 (+5d) | 2011-10-24 → 2011-10-30 (+6d) |  |  |  |  | baseline start none → 2011-10-18; baseline finish none → 2011-10-25 |
| 45 | **MOBILIZATION-5-LIFTING HOIST** | 2012-05-17 → 2012-05-22 (+5d) | 2012-05-23 → 2012-05-29 (+6d) |  |  |  |  | baseline start none → 2012-05-17; baseline finish none → 2012-05-24 |
| 46 | Lifting Hoist Installation | 2012-05-17 → 2012-05-22 (+5d) | 2012-05-23 → 2012-05-29 (+6d) |  |  |  |  | baseline start none → 2012-05-17; baseline finish none → 2012-05-24 |
| 47 | **DEMOBILIZATION** | 2012-06-02 → 2012-06-07 (+5d) | 2012-08-20 → 2012-08-28 (+8d) |  |  |  |  | baseline start none → 2012-06-02; baseline finish none → 2012-08-21 |
| 48 | Dismantling Tower Crane | 2012-06-02 → 2012-06-07 (+5d) | 2012-06-03 → 2012-06-09 (+6d) |  |  |  |  | baseline start none → 2012-06-02; baseline finish none → 2012-06-04 |
| 49 | Dismatle Lifting Hoist | 2012-08-02 → 2012-08-07 (+5d) | 2012-08-03 → 2012-08-09 (+6d) |  |  |  |  | baseline start none → 2012-08-02; baseline finish none → 2012-08-04 |
| 50 | Dismantling Infrastructure | 2012-08-04 → 2012-08-09 (+5d) | 2012-08-20 → 2012-08-28 (+8d) |  |  |  |  | baseline start none → 2012-08-04; baseline finish none → 2012-08-21 |
| 51 | **SUB-STRUCTURE** |  | 2011-05-12 → 2011-05-18 (+6d) | 375d → 380.86d | 22% → 62% |  |  | baseline start none → 2010-04-18; baseline finish none → 2011-05-13 |
| 52 | **PART-1** |  |  |  |  |  |  | baseline start none → 2010-04-18; baseline finish none → 2010-08-15 |
| 53 | SHORE PILING (50 ft) |  |  |  |  |  |  | baseline start none → 2010-04-18; baseline finish none → 2010-07-26 |
| 54 | **PERIMETER BEAM** |  |  |  |  |  |  | baseline start none → 2010-07-27; baseline finish none → 2010-08-15 |
| 55 | Excavation for PileHead Breaking |  |  |  |  |  |  | baseline start none → 2010-07-27; baseline finish none → 2010-08-10 |
| 56 | Pile Head Breaking |  |  |  |  |  |  | baseline start none → 2010-07-29; baseline finish none → 2010-08-12 |
| 57 | Re bar Work & Concreting | 2010-07-31 A → 2010-07-30 A (-1d) |  |  |  |  |  | baseline start none → 2010-07-31; baseline finish none → 2010-08-15 |
| 58 | **PART-2** | 2010-10-02 A | 2011-05-12 → 2011-05-18 (+6d) | 215d → 220.86d | 0% → 54% | 0d → 464d |  | baseline start none → 2010-10-02; baseline finish none → 2011-05-12 |
| 59 | **EXCAVATION** | 2010-10-02 A | 2010-12-31 → 2010-12-05 A (-26d) | 83d → 57d | 0% → 100% | 0d → none |  | baseline start none → 2010-10-02; baseline finish none → 2010-12-31 |
| 60 | Mobilization-1 (Equipment) | 2010-10-02 A | 2010-10-06 A |  | 0% → 100% | 0d → none |  | baseline start none → 2010-10-02; baseline finish none → 2010-10-06 |
| 61 | **Mobilization-2(Bracing)** | 2010-10-02 → 2010-10-11 A (+9d) | 2010-10-16 → 2010-12-01 A (+46d) | 15d → 44d | 0% → 100% | 68d → none |  | baseline start none → 2010-10-02; baseline finish none → 2010-10-16 |
| 68 | **Excavation-Part-1** | 2010-10-04 A | 2010-10-21 → 2010-10-22 A (+1d) | 18d → 19d | 0% → 100% | 0d → none | 60SS+2d → none | baseline start none → 2010-10-04; baseline finish none → 2010-10-21 |
| 73 | **Bracing** | 2010-10-21 → 2010-10-14 A (-7d) | 2010-12-01 → 2010-11-03 A (-28d) | 34d → 21d | 0% → 100% | 0d → none | 68FS-1d → none | baseline start none → 2010-10-21; baseline finish none → 2010-12-01 |
| 84 | **Earth excavation - Phase 2 : (16' to 32')** | 2010-10-26 → 2010-10-15 A (-11d) | 2010-12-31 → 2010-11-12 A (-49d) | 59d → 29d | 0% → 100% | 0d → none | 73SS+5d, 36FS-6d → none | was named Excvation- Part-2; baseline start none → 2010-10-26; baseline finish none → 2010-12-31 |
| 99 | **Mat Foundation** | 2010-12-25 → 2010-11-03 A (-52d) | 2011-02-07 → 2010-12-20 A (-49d) | 45d → 39.17d | 0% → 100% | 0d → none |  | baseline start none → 2010-12-25; baseline finish none → 2011-02-07 |
| 100 | **Part-1-Section # a : East to west 0' to 30' span** | 2010-12-25 → 2010-11-03 A (-52d) | 2011-01-16 → 2010-11-23 A (-54d) | 23d → 12.5d | 0% → 100% | 0d → none |  | was named Part-1; baseline start none → 2010-12-25; baseline finish none → 2011-01-16 |
| 101 | Bed Preparation | 2010-12-25 → 2010-11-03 A (-52d) | 2010-12-31 → 2010-11-10 A (-51d) | 7d → 3d | 0% → 100% | 0d → none | 59FS-7d → 95FF+1d | resources none → MS Rod - Grade 60 [47.5 ton]; baseline start none → 2010-12-25; baseline finish none → 2010-12-31 |
| 102 | 2-Layer Polythene | 2011-01-01 → 2010-11-10 A (-52d) | 2011-01-01 → 2010-11-10 A (-52d) | 1d → 0.5d | 0% → 100% | 22d → none | 101 → 101FF | resources none → Polythene (0.2mm thick) [3411.8 sft]; baseline start none → 2011-01-01; baseline finish none → 2011-01-01 |
| 103 | Lean Concrete | 2011-01-02 → 2010-11-11 A (-52d) | 2011-01-02 → 2010-11-11 A (-52d) | 1d → 0.5d | 0% → 100% | 22d → none |  | resources none → Readymix CC-2500 psi [882.88 cft]; baseline start none → 2011-01-02; baseline finish none → 2010-01-02 |
| 104 | Peripherial Brick Work | 2011-01-03 → 2010-11-11 A (-53d) | 2011-01-03 → 2010-11-11 A (-53d) | 1d → 0d | 0% → 100% | 22d → none | 103 → 103FF | baseline start none → 2011-01-03; baseline finish none → 2011-01-03 |

| ID | Task | Start | Finish | Duration | Complete | Total float | Predecessors | Other |
| --- | --- | --- | --- | --- | --- | --- | --- | --- |
| 105 | Plaster | 2011-01-04 → 2010-11-11 A (-54d) | 2011-01-04 → 2010-11-11 A (-54d) | 1d → 0d | 0% → 100% | 22d → none | 104 → 104FF | baseline start none → 2011-01-04; baseline finish none → 2011-01-04 |
| 106 | Water Proofing | 2011-01-08 → 2010-11-11 A (-58d) | 2011-01-09 → 2010-11-11 A (-59d) | 2d → 0d | 0% → 100% | 22d → none | 105FS+3d → 105FF | baseline start none → 2011-01-08; baseline finish none → 2011-01-09 |
| 107 | Re-Bar Fabrication | 2011-01-10 → 2010-11-11 A (-60d) | 2011-01-13 → 2010-11-14 A (-60d) | 4d → 3d | 0% → 100% | 22d → none |  | baseline start none → 2011-01-10; baseline finish none → 2011-01-13 |
| 108 | MEP Works | 2011-01-14 → 2010-11-10 A (-65d) | 2011-01-14 → 2010-11-11 A (-64d) |  | 0% → 100% | 22d → none | 107 → 106FF | baseline start none → 2011-01-14; baseline finish none → 2011-01-14 |
| 109 | Inspection | 2011-01-15 → 2010-11-13 A (-63d) | 2011-01-15 → 2010-11-14 A (-62d) |  | 0% → 100% | 22d → none | 108, 107 → 107FF | baseline start none → 2011-01-15; baseline finish none → 2011-01-15 |
| 110 | Concreteing | 2011-01-16 → 2010-11-14 A (-63d) | 2011-01-16 → 2010-11-23 A (-54d) |  | 0% → 100% | 22d → none |  | resources none → Structural Work-Mat [2688 sft]; Water Stopper-8" Width [100 rft]; Readymix Concrete-4500 psi [7292.55 cft]; baseline start none → 2011-01-16; baseline finish none → 2011-01-16 |
| 111 | **Part-2-Section # b : East to west 31' to 60' span** | 2011-01-01 → 2010-11-24 A (-38d) | 2011-01-24 → 2010-12-09 A (-46d) | 24d → 15.18d | 0% → 100% | 0d → none |  | was named Part-2; baseline start none → 2011-01-01; baseline finish none → 2011-01-24 |
| 112 | Bed Preparation | 2011-01-01 → 2010-11-24 A (-38d) | 2011-01-08 → 2010-12-01 A (-38d) | 8d → 7d | 0% → 100% | 0d → none | 101 → 101, 96FS+3d | resources none → MS Rod - Grade 60 [22.63 ton]; baseline start none → 2011-01-01; baseline finish none → 2011-01-08 |
| 113 | 2-Layer Polythene | 2011-01-09 → 2010-11-30 A (-40d) | 2011-01-09 → 2010-12-01 A (-39d) |  | 0% → 100% | 14d → none | 112 → 112FF | resources none → Polythene (0.2mm thick) [3411.8 sft]; baseline start none → 2011-01-09; baseline finish none → 2011-01-09 |
| 114 | Lean Concrete | 2011-01-10 → 2010-12-01 A (-40d) | 2011-01-10 → 2010-12-02 A (-39d) |  | 0% → 100% | 14d → none |  | resources none → Readymix CC-2500 psi [680.48 cft]; baseline start none → 2011-01-10; baseline finish none → 2011-01-10 |
| 115 | Peripherial Brick Work | 2011-01-11 → 2010-12-02 A (-40d) | 2011-01-11 → 2010-12-02 A (-40d) | 1d → 0d | 0% → 100% | 14d → none | 114 → 114FF | baseline start none → 2011-01-11; baseline finish none → 2011-01-11 |
| 116 | Plaster | 2011-01-12 → 2010-12-02 A (-41d) | 2011-01-12 → 2010-12-02 A (-41d) | 1d → 0d | 0% → 100% | 14d → none | 115 → 115FF | baseline start none → 2011-01-12; baseline finish none → 2011-01-12 |
| 117 | Water Proofing | 2011-01-16 → 2010-12-02 A (-45d) | 2011-01-17 → 2010-12-02 A (-46d) | 2d → 0d | 0% → 100% | 14d → none | 116FS+3d → 116FF | baseline start none → 2011-01-16; baseline finish none → 2011-01-17 |
| 118 | Re-Bar Fabrication | 2011-01-18 → 2010-12-02 A (-47d) | 2011-01-21 → 2010-12-07 A (-45d) | 4d → 5d | 0% → 100% | 14d → none |  | baseline start none → 2011-01-18; baseline finish none → 2011-01-21 |
| 119 | MEP Works | 2011-01-22 → 2010-12-06 A (-47d) | 2011-01-22 → 2010-12-07 A (-46d) |  | 0% → 100% | 14d → none | 118 → 118FF | baseline start none → 2011-01-22; baseline finish none → 2011-01-22 |
| 120 | Inspection | 2011-01-23 → 2010-12-06 A (-48d) | 2011-01-23 → 2010-12-07 A (-47d) |  | 0% → 100% | 14d → none | 118, 119 → 119FF | baseline start none → 2011-01-23; baseline finish none → 2011-01-23 |
| 121 | Concreteing | 2011-01-24 → 2010-12-06 A (-49d) | 2011-01-24 → 2010-12-09 A (-46d) | 1d → 3d | 0% → 100% | 14d → none | 120 → 120FF+2d | resources none → Structural Work-Mat [2688 sft]; Bonding Chemical [9.83 L]; Water Stopper-8" Width [100 rft]; Readymix Concrete-4500 psi [11935.9 cft]; baseline start none → 2011-01-24; baseline finish none → 2011-01-24 |
| 122 | **Part-3-Section # d : East to west 91' to 112' span** | 2011-01-09 → 2010-11-25 A (-45d) | 2011-01-31 → 2010-12-20 A (-42d) | 23d → 24.68d | 0% → 100% | 0d → none |  | was named Part-3; baseline start none → 2011-01-09; baseline finish none → 2011-01-31 |
| 123 | Bed Preparation | 2011-01-09 → 2010-11-25 A (-45d) | 2011-01-15 → 2010-12-09 A (-37d) | 7d → 8d | 0% → 100% | 0d → none | 112 → 112FF+8d, 97FF+1d | resources none → MS Rod - Grade 60 [22.63 ton]; baseline start none → 2011-01-09; baseline finish none → 2011-01-15 |
| 124 | 2-Layer Polythene | 2011-01-16 → 2010-12-09 A (-38d) | 2011-01-16 → 2010-12-10 A (-37d) |  | 0% → 100% | 7d → none |  | resources none → Polythene (0.2mm thick) [3411.8 sft]; baseline start none → 2011-01-16; baseline finish none → 2011-01-16 |
| 125 | Lean Concrete | 2011-01-17 → 2010-12-10 A (-38d) | 2011-01-17 → 2010-12-12 A (-36d) | 1d → 2d | 0% → 100% | 7d → none |  | resources none → Readymix CC-2500 psi [680.48 cft]; baseline start none → 2011-01-17; baseline finish none → 2011-01-17 |
| 126 | Peripherial Brick Work | 2011-01-18 → 2010-12-12 A (-37d) | 2011-01-18 → 2010-12-12 A (-37d) | 1d → 0d | 0% → 100% | 7d → none | 125 → 125FF | baseline start none → 2011-01-18; baseline finish none → 2011-01-18 |
| 127 | Plaster | 2011-01-19 → 2010-12-12 A (-38d) | 2011-01-19 → 2010-12-12 A (-38d) | 1d → 0d | 0% → 100% | 7d → none | 126 → 126FF | baseline start none → 2011-01-19; baseline finish none → 2011-01-19 |
| 128 | Water Proofing | 2011-01-23 → 2010-12-12 A (-42d) | 2011-01-24 → 2010-12-12 A (-43d) | 2d → 0d | 0% → 100% | 7d → none | 127FS+3d → 127FF | baseline start none → 2011-01-23; baseline finish none → 2011-01-24 |
| 129 | Re-Bar Fabrication | 2011-01-25 → 2010-12-12 A (-44d) | 2011-01-28 → 2010-12-18 A (-41d) | 4d → 6d | 0% → 100% | 7d → none |  | baseline start none → 2011-01-25; baseline finish none → 2011-01-28 |
| 130 | MEP Works | 2011-01-29 → 2010-12-17 A (-43d) | 2011-01-29 → 2010-12-18 A (-42d) |  | 0% → 100% | 7d → none | 129 → 129FF | baseline start none → 2011-01-29; baseline finish none → 2011-01-29 |
| 131 | Inspection | 2011-01-30 → 2010-12-17 A (-44d) | 2011-01-30 → 2010-12-18 A (-43d) |  | 0% → 100% | 7d → none | 129, 130 → 130FF | baseline start none → 2011-01-30; baseline finish none → 2011-01-30 |
| 132 | Concreteing | 2011-01-31 → 2010-12-17 A (-45d) | 2011-01-31 → 2010-12-20 A (-42d) | 1d → 3d | 0% → 100% | 7d → none | 131 → 131FF+2d | resources none → Structural Work-Mat [2688 sft]; Bonding Chemical [9.83 L]; Bracing-MS Joist Removing [83250 kg]; Readymix Concrete-4500 psi [11935.9 cft]; baseline start none → 2011-01-31; baseline finish none → 2011-01-31 |
| 133 | **Part-4-Section # d : East to west 91' to 112' span** | 2011-01-16 → 2010-12-20 A (-27d) | 2011-02-07 → 2010-12-20 A (-49d) | 23d → 0d | 0% → 100% | 0d → none |  | was named Part-4; baseline start none → 2011-01-16; baseline finish none → 2011-02-07 |
| 134 | Bed Preparation | 2011-01-16 → 2010-12-20 A (-27d) | 2011-01-22 → 2010-12-20 A (-33d) | 7d → 0d | 0% → 100% | 0d → none | 123 → 132FF | baseline start none → 2011-01-16; baseline finish none → 2011-01-22 |
| 135 | 2-Layer Polythene | 2011-01-23 → 2010-12-20 A (-34d) | 2011-01-23 → 2010-12-20 A (-34d) | 1d → 0d | 0% → 100% | 0d → none | 134 → 134FF | baseline start none → 2011-01-23; baseline finish none → 2011-01-23 |
| 136 | Lean Concrete | 2011-01-24 → 2010-12-20 A (-35d) | 2011-01-24 → 2010-12-20 A (-35d) | 1d → 0d | 0% → 100% | 0d → none | 135 → 135FF | baseline start none → 2011-01-24; baseline finish none → 2011-01-24 |
| 137 | Peripherial Brick Work | 2011-01-25 → 2010-12-20 A (-36d) | 2011-01-25 → 2010-12-20 A (-36d) | 1d → 0d | 0% → 100% | 0d → none | 136 → 136FF | baseline start none → 2011-01-25; baseline finish none → 2011-01-25 |
| 138 | Plaster | 2011-01-26 → 2010-12-20 A (-37d) | 2011-01-26 → 2010-12-20 A (-37d) | 1d → 0d | 0% → 100% | 0d → none | 137 → 137FF | baseline start none → 2011-01-26; baseline finish none → 2011-01-26 |
| 139 | Water Proofing | 2011-01-30 → 2010-12-20 A (-41d) | 2011-01-31 → 2010-12-20 A (-42d) | 2d → 0d | 0% → 100% | 0d → none | 138FS+3d → 138FF | baseline start none → 2011-01-30; baseline finish none → 2011-01-31 |
| 140 | Re-Bar Fabrication | 2011-02-01 → 2010-12-20 A (-43d) | 2011-02-04 → 2010-12-20 A (-46d) | 4d → 0d | 0% → 100% | 0d → none | 139 → 139FF | baseline start none → 2011-02-01; baseline finish none → 2011-02-04 |
| 141 | MEP Works | 2011-02-05 → 2010-12-20 A (-47d) | 2011-02-05 → 2010-12-20 A (-47d) | 1d → 0d | 0% → 100% | 0d → none | 140 → 140FF | baseline start none → 2011-02-05; baseline finish none → 2011-02-05 |
| 142 | Inspection | 2011-02-06 → 2010-12-20 A (-48d) | 2011-02-06 → 2010-12-20 A (-48d) | 1d → 0d | 0% → 100% | 0d → none | 140, 141 → 141FF | baseline start none → 2011-02-06; baseline finish none → 2011-02-06 |
| 143 | Concreteing | 2011-02-07 → 2010-12-20 A (-49d) | 2011-02-07 → 2010-12-20 A (-49d) | 1d → 0d | 0% → 100% | 0d → none | 142 → 142FF | baseline start none → 2011-02-07; baseline finish none → 2011-02-07 |
| 144 | **BASEMENT-3** | 2011-02-08 → 2010-12-20 A (-50d) | 2011-03-24 → 2011-02-08 (-44d) | 45d → 50.69d | 0% → 55% | 0d → 563d |  | baseline start none → 2011-02-08; baseline finish none → 2011-03-24 |
| 145 | **LIFT-1** | 2011-02-08 → 2010-12-20 A (-50d) | 2011-03-03 → 2011-01-28 (-34d) | 24d → 39.69d | 0% → 83% | 0d → 574d |  | was named PART-1; baseline start none → 2011-02-08; baseline finish none → 2011-03-03 |
| 146 | **Retaining Wall** | 2011-02-08 → 2010-12-20 A (-50d) | 2011-02-23 → 2011-01-23 (-31d) | 16d → 34d | 0% → 98% | 0d → 579.68d |  | baseline start none → 2011-02-08; baseline finish none → 2011-02-23 |
| 147 | Brick Wall | 2011-02-08 → 2010-12-20 A (-50d) | 2011-02-09 → 2011-01-04 A (-36d) | 2d → 15d | 0% → 100% | 0d → none | 99 → 132 | resources none → Brick [4000.59 nos]; Cement [19.42 bag]; Local Sand [128.02 cft]; MS Rod - Grade 60 [4.41 ton]; baseline start none → 2011-02-08; baseline finish none → 2011-02-09 |
| 148 | Plaster | 2011-02-10 → 2011-01-03 A (-38d) | 2011-02-10 → 2011-01-04 A (-37d) |  | 0% → 100% | 0d → none | 147 → 147FF | baseline start none → 2011-02-10; baseline finish none → 2011-02-10 |
| 149 | Water Proofing | 2011-02-17 → 2011-01-04 A (-44d) | 2011-02-17 → 2011-01-07 (-41d) | 1d → 3d | 0% → 98% | 0d → 592.42d | 148FF+7d → 147 | baseline start none → 2011-02-17; baseline finish none → 2011-02-17 |
| 150 | Re-bar Work | 2011-02-18 → 2011-01-07 A (-42d) | 2011-02-20 → 2011-01-13 (-38d) | 3d → 6d | 0% → 98% | 0d → 586.54d |  | baseline start none → 2011-02-18; baseline finish none → 2011-02-20 |
| 151 | Form Work | 2011-02-20 → 2011-01-13 A (-38d) | 2011-02-21 → 2011-01-18 (-34d) | 2d → 5d | 0% → 98% | 0d → 581.64d | 150FF+1d → 150 | resources none → Polythene (0.2mm thick) [1 sft]; baseline start none → 2011-02-20; baseline finish none → 2011-02-21 |
| 152 | Conreting | 2011-02-22 → 2011-01-19 A (-34d) | 2011-02-22 → 2011-01-21 (-32d) | 1d → 2d | 0% → 98% |  | 151FF+1d → 151FS+1d | resources none → Water Stopper-6" Width [1000 rft]; Bonding Chemical [1.87 L]; Readymix Concrete-4500 psi [2097.08 cft]; baseline start none → 2011-02-22; baseline finish none → 2011-02-22 |
| 153 | De-shuttering | 2011-02-23 → 2011-01-22 A (-32d) | 2011-02-23 → 2011-01-23 (-31d) |  | 0% → 70% | 0d → 579.68d | 152FF+1d → 152FF+2d | baseline start none → 2011-02-23; baseline finish none → 2011-02-23 |
| 154 | **Water Reservoir** | 2011-02-08 → 2011-01-11 A (-28d) | 2011-02-17 → 2011-01-24 (-24d) | 10d → 14d | 0% → 90% | 548d → 577.86d |  | baseline start none → 2011-02-08; baseline finish none → 2011-02-17 |
| 155 | **Vertical Wall** | 2011-02-08 → 2011-01-11 A (-28d) | 2011-02-13 → 2011-01-21 A (-23d) | 6d → 11d | 0% → 100% | 548d → none |  | baseline start none → 2011-02-08; baseline finish none → 2011-02-13 |
| 156 | Re-bar Work | 2011-02-08 → 2011-01-11 A (-28d) | 2011-02-10 → 2011-01-13 A (-28d) |  | 0% → 100% | 548d → none | 99 → none | constraint none → start no earlier than 2011-01-11; resources none → MS Rod - Grade 60 [2.88 ton]; baseline start none → 2011-02-08; baseline finish none → 2011-02-10 |
| 157 | Form Work | 2011-02-09 → 2011-01-14 A (-26d) | 2011-02-11 → 2011-01-16 A (-26d) |  | 0% → 100% | 548d → none | 156FF+1d → 156 | baseline start none → 2011-02-09; baseline finish none → 2011-02-11 |
| 158 | Concrete | 2011-02-11 → 2011-01-17 A (-25d) | 2011-02-12 → 2011-01-19 A (-24d) | 2d → 3d | 0% → 100% | 548d → none | 157FF+1d → 157 | resources none → Brick [1 nos]; Cement [1 bag]; Local Sand [1 cft]; Water Stopper-6" Width [1 rft]; Readymix Concrete-4500 psi [1 cft]; baseline start none → 2011-02-11; baseline finish none → 2011-02-12 |
| 159 | De Shuttering | 2011-02-12 → 2011-01-20 A (-23d) | 2011-02-13 → 2011-01-21 A (-23d) |  | 0% → 100% | 552d → none | 158FF+1d → 158FF+2d | baseline start none → 2011-02-12; baseline finish none → 2011-02-13 |
| 160 | **Top Slab** | 2011-02-13 → 2011-01-21 A (-23d) | 2011-02-17 → 2011-01-24 (-24d) | 5d → 4d | 0% → 68% | 548d → 577.86d |  | baseline start none → 2011-02-13; baseline finish none → 2011-02-17 |
| 161 | Form Work | 2011-02-13 → 2011-01-21 A (-23d) | 2011-02-15 → 2011-01-22 (-24d) | 3d → 2d | 0% → 90% | 548d → 577.86d |  | constraint none → start no earlier than 2011-01-20; baseline start none → 2011-02-13; baseline finish none → 2011-02-15 |
| 162 | Re-bar Work | 2011-02-14 → 2011-01-22 A (-23d) | 2011-02-16 → 2011-01-23 (-24d) | 3d → 2d | 0% → 80% | 548d → 577.86d |  | constraint none → start no earlier than 2011-01-20; baseline start none → 2011-02-14; baseline finish none → 2011-02-16 |
| 163 | Concrete | 2011-02-17 → 2011-01-24 (-24d) | 2011-02-17 → 2011-01-24 (-24d) |  |  | 548d → 577.86d |  | constraint none → start no earlier than 2011-01-20; resources none → Readymix Concrete-4500 psi [1820.77 cft]; baseline start none → 2011-02-17; baseline finish none → 2011-02-17 |
| 164 | **Column** | 2011-02-08 → 2011-01-12 A (-27d) | 2011-02-15 → 2011-01-25 (-21d) | 8d → 13d | 0% → 87% | 8d → 573.68d |  | baseline start none → 2011-02-08; baseline finish none → 2011-02-15 |
| 165 | Re-Bar Work | 2011-02-08 → 2011-01-12 A (-27d) | 2011-02-09 → 2011-01-17 A (-23d) | 2d → 5d | 0% → 100% | 8d → none | 99 → 150FF+4d | resources none → MS Rod - Grade 60 [9.8 ton]; baseline start none → 2011-02-08; baseline finish none → 2011-02-09 |
| 166 | Form Work | 2011-02-10 → 2011-01-17 A (-24d) | 2011-02-11 → 2011-01-20 (-22d) | 2d → 3d | 0% → 85% | 8d → 414.24d |  | baseline start none → 2011-02-10; baseline finish none → 2011-02-11 |
| 167 | Concrete | 2011-02-12 → 2011-01-20 A (-23d) | 2011-02-13 → 2011-01-23 (-21d) | 2d → 3d | 0% → 85% | 8d → 411.69d |  | resources none → Readymix Concrete-4500 psi [565.39 cft]; baseline start none → 2011-02-12; baseline finish none → 2011-02-13 |
| 168 | De-shuttering | 2011-02-14 → 2011-01-23 A (-22d) | 2011-02-15 → 2011-01-25 (-21d) |  | 0% → 60% | 8d → 573.68d | 167 → 167FF+2d | constraint none → start no earlier than 2011-01-20; baseline start none → 2011-02-14; baseline finish none → 2011-02-15 |
| 169 | **Shear Wall** | 2011-02-08 → 2010-12-20 A (-50d) | 2011-02-19 → 2011-01-27 (-23d) | 12d → 38.69d | 0% → 54% | 4d → 406d |  | baseline start none → 2011-02-08; baseline finish none → 2011-02-19 |
| 170 | Re-Bar Work | 2011-02-08 → 2010-12-20 A (-50d) | 2011-02-10 → 2011-01-22 (-19d) |  | 0% → 65% | 4d → 408d |  | resources none → MS Rod - Grade 60 [5.15 ton]; baseline start none → 2011-02-08; baseline finish none → 2011-02-10 |
| 171 | Form Work | 2011-02-11 → 2011-01-21 A (-21d) | 2011-02-13 → 2011-01-24 (-20d) |  | 0% → 20% | 4d → 408d | 170 → 170FF+2d | baseline start none → 2011-02-11; baseline finish none → 2011-02-13 |
| 172 | Concrete | 2011-02-14 → 2011-01-23 A (-22d) | 2011-02-16 → 2011-01-25 (-22d) | 3d → 2d | 0% → 20% | 4d → 408d | 171 → 171FF+1d | resources none → Readymix Concrete-4500 psi [409.19 cft]; baseline start none → 2011-02-14; baseline finish none → 2011-02-16 |
| 173 | De-shuttering | 2011-02-17 → 2011-01-24 A (-24d) | 2011-02-19 → 2011-01-27 A (-23d) |  | 0% → 100% | 4d → none | 172 → 172FF+2d | baseline start none → 2011-02-17; baseline finish none → 2011-02-19 |
| 174 | **Stair - 1** | 2011-02-08 → 2011-01-21 A (-18d) | 2011-02-11 → 2011-01-24 (-18d) |  | 0% → 69% | 399d → 411.86d |  | baseline start none → 2011-02-08; baseline finish none → 2011-02-11 |

| ID | Task | Start | Finish | Duration | Complete | Total float | Predecessors | Other |
| --- | --- | --- | --- | --- | --- | --- | --- | --- |
| 175 | **1st Flight** | 2011-02-08 → 2011-01-21 A (-18d) | 2011-02-11 → 2011-01-24 (-18d) |  | 0% → 69% | 399d → 411.86d |  | baseline start none → 2011-02-08; baseline finish none → 2011-02-11 |
| 176 | Brick Work | 2011-02-08 → 2011-01-21 A (-18d) | 2011-02-08 → 2011-01-21 A (-18d) |  | 0% → 100% | 399d → none |  | constraint none → start no earlier than 2011-01-20; baseline start none → 2011-02-08; baseline finish none → 2011-02-08 |
| 177 | Form Work | 2011-02-09 → 2011-01-22 A (-18d) | 2011-02-09 → 2011-01-22 (-18d) |  | 0% → 60% | 399d → 413d |  | constraint none → start no earlier than 2011-01-20; resources none → MS Rod - Grade 60 [2.79 ton]; baseline start none → 2011-02-09; baseline finish none → 2011-02-09 |
| 178 | Re-bar Work | 2011-02-10 → 2011-01-23 A (-18d) | 2011-02-10 → 2011-01-23 (-18d) |  | 0% → 60% | 399d → 412.4d |  | constraint none → start no earlier than 2011-01-20; baseline start none → 2011-02-10; baseline finish none → 2011-02-10 |
| 179 | Concrete | 2011-02-11 → 2011-01-24 A (-18d) | 2011-02-11 → 2011-01-24 (-18d) |  | 0% → 54% | 399d → 411.86d |  | constraint none → start no earlier than 2011-01-20; resources none → Readymix Concrete-3500 psi [121.06 cft]; baseline start none → 2011-02-11; baseline finish none → 2011-02-11 |
| 180 | **Ramp** | 2011-02-26 → 2011-01-22 (-35d) | 2011-02-27 → 2011-01-23 (-35d) |  |  | 538d → 578.86d |  | baseline start none → 2011-02-26; baseline finish none → 2011-02-27 |
| 181 | Form Work | 2011-02-26 → 2011-01-22 (-35d) | 2011-02-26 → 2011-01-22 (-35d) |  |  | 538d → 578.86d | 184FF → 177FF | resources none → MS Rod - Grade 60 [2.48 ton]; baseline start none → 2011-02-26; baseline finish none → 2011-02-26 |
| 182 | Re-Bar | 2011-02-27 → 2011-01-23 (-35d) | 2011-02-27 → 2011-01-23 (-35d) |  |  | 538d → 578.86d |  | baseline start none → 2011-02-27; baseline finish none → 2011-02-27 |
| 183 | **Roof Slab** | 2011-02-24 → 2011-01-27 (-28d) | 2011-03-03 → 2011-01-28 (-34d) | 8d → 1d |  | 0d → 571d |  | baseline start none → 2011-02-24; baseline finish none → 2011-03-03 |
| 184 | Form Work | 2011-02-24 → 2011-01-27 (-28d) | 2011-02-26 → 2011-01-27 (-30d) | 3d → 0d |  | 0d → 571d |  | constraint none → start no earlier than 2011-01-20; resources none → MS Rod - Grade 60; baseline start none → 2011-02-24; baseline finish none → 2011-02-26 |
| 185 | Re-bar | 2011-02-26 → 2011-01-27 (-30d) | 2011-02-28 → 2011-01-27 (-32d) | 3d → 0d |  | 0d → 571d | 184FF+2d → 184FF | constraint none → start no earlier than 2011-01-20; baseline start none → 2011-02-26; baseline finish none → 2011-03-28 |
| 186 | MEP Work | 2011-03-01 → 2011-01-27 (-33d) | 2011-03-01 → 2011-01-27 (-33d) | 1d → 0d |  | 0d → 571d | 185 → 185FF | constraint none → start no earlier than 2011-01-20; baseline start none → 2011-03-01; baseline finish none → 2011-03-01 |
| 187 | Inspection | 2011-03-02 → 2011-01-27 (-34d) | 2011-03-02 → 2011-01-27 (-34d) | 1d → 0d |  | 0d → 571d | 186 → 186FF | constraint none → start no earlier than 2011-01-20; baseline start none → 2011-03-02; baseline finish none → 2011-03-02 |
| 188 | Concrete | 2011-03-03 → 2011-01-27 (-35d) | 2011-03-03 → 2011-01-28 (-34d) |  |  | 0d → 571d |  | constraint none → start no earlier than 2011-01-20; resources none → Structural Work-B2 Slab [1 sft]; Filling Sand [1 cft]; Readymix Concrete-3500 psi [1 cft]; baseline start none → 2011-03-03; baseline finish none → 2011-03-03 |
| 189 | **LIFT-2** | 2011-03-04 → 2011-01-15 A (-48d) | 2011-03-24 → 2011-02-08 (-44d) | 21d → 24.68d | 0% → 11% | 368d → 563d | 188 → none | was named PART-2; baseline start none → 2011-03-04; baseline finish none → 2011-03-24 |
| 190 | **Retaining Wall** | 2011-03-04 → 2011-01-15 A (-48d) | 2011-03-17 → 2011-01-28 (-48d) | 14d → 13d | 0% → 24% | 368d → 411.69d |  | baseline start none → 2011-03-04; baseline finish none → 2011-03-17 |
| 191 | Brick Wall | 2011-03-04 → 2011-01-15 A (-48d) | 2011-03-05 → 2011-01-23 (-41d) | 2d → 8d | 0% → 50% | 368d → 0d | 188FF+1d → 152FF+2d, 152 | resources none → Brick [1 nos]; Cement [1 bag]; Local Sand [1 cft]; baseline start none → 2011-03-04; baseline finish none → 2011-03-05 |
| 192 | Plaster | 2011-03-05 → 2011-01-23 (-41d) | 2011-03-06 → 2011-01-23 (-42d) | 2d → 0d |  | 368d → 0d | 191FF+1d → 191FF | baseline start none → 2011-03-05; baseline finish none → 2011-03-06 |
| 193 | Water Proofing | 2011-03-12 → 2011-01-22 (-49d) | 2011-03-13 → 2011-01-23 (-49d) | 2d → 1d |  | 368d → 411.69d | 192FF+7d → 191FF, 191FF+1d | baseline start none → 2011-03-12; baseline finish none → 2011-03-13 |
| 194 | Re-bar Work | 2011-03-13 → 2011-01-22 (-50d) | 2011-03-14 → 2011-01-24 (-49d) |  |  | 368d → 411.69d |  | baseline start none → 2011-03-13; baseline finish none → 2011-03-14 |
| 195 | Form Work | 2011-03-14 → 2011-01-23 (-50d) | 2011-03-15 → 2011-01-25 (-49d) |  |  | 368d → 411.69d |  | resources none → Polythene (0.2mm thick) [2263.2 sft]; baseline start none → 2011-03-14; baseline finish none → 2011-03-15 |
| 196 | Conreting | 2011-03-15 → 2011-01-24 (-50d) | 2011-03-16 → 2011-01-26 (-49d) |  |  | 368d → 411.69d |  | resources none → Water Stopper-6" Width [1000 rft]; Readymix Concrete-4500 psi [2097.08 cft]; baseline start none → 2011-03-15; baseline finish none → 2011-03-16 |
| 197 | De-shuttering | 2011-03-16 → 2011-01-26 (-49d) | 2011-03-17 → 2011-01-28 (-48d) |  |  | 368d → 411.69d | 196FF+1d → 196FF+2d | baseline start none → 2011-03-16; baseline finish none → 2011-03-17 |
| 198 | **Column** | 2011-03-04 → 2011-01-23 A (-40d) | 2011-03-08 → 2011-01-28 (-39d) |  | 0% → 5% | 377d → 411.69d |  | baseline start none → 2011-03-04; baseline finish none → 2011-03-08 |
| 199 | Form Work | 2011-03-05 → 2011-01-23 (-41d) | 2011-03-06 → 2011-01-25 (-40d) |  |  | 377d → 411.69d | 200FF+1d → 167 | baseline start none → 2011-03-05; baseline finish none → 2011-03-06 |
| 200 | Re-Bar Work | 2011-03-04 → 2011-01-23 A (-40d) | 2011-03-05 → 2011-01-24 (-40d) | 2d → 1d | 0% → 35% | 377d → 415.69d | 188FF+1d → 167 | baseline start none → 2011-03-04; baseline finish none → 2011-03-05 |
| 201 | Concrete | 2011-03-06 → 2011-01-24 (-41d) | 2011-03-07 → 2011-01-26 (-40d) |  |  | 377d → 411.69d |  | constraint none → start no earlier than 2011-01-20; resources none → Readymix Concrete-4500 psi [565.39 cft]; baseline start none → 2011-03-06; baseline finish none → 2011-03-07 |
| 202 | De-shuttering | 2011-03-07 → 2011-01-26 (-40d) | 2011-03-08 → 2011-01-28 (-39d) |  |  | 377d → 411.69d | 201FF+1d → 201FF+2d | constraint none → start no earlier than 2011-01-20; baseline start none → 2011-03-07; baseline finish none → 2011-03-08 |
| 203 | **Shear Wall** | 2011-03-04 → 2011-01-24 A (-39d) | 2011-03-09 → 2011-01-31 (-37d) | 6d → 7d | 0% → 8% | 376d → 408d |  | baseline start none → 2011-03-04; baseline finish none → 2011-03-09 |
| 204 | Re-Bar Work | 2011-03-04 → 2011-01-24 A (-39d) | 2011-03-06 → 2011-01-27 (-38d) |  | 0% → 30% | 376d → 408d | 188FF+1d → 172FF+2d | baseline start none → 2011-03-04; baseline finish none → 2011-03-06 |
| 205 | Form Work | 2011-03-05 → 2011-01-25 (-39d) | 2011-03-07 → 2011-01-28 (-38d) |  |  | 376d → 408d |  | constraint none → start no earlier than 2011-01-20; baseline start none → 2011-03-05; baseline finish none → 2011-03-07 |
| 206 | Concrete | 2011-03-06 → 2011-01-26 (-39d) | 2011-03-08 → 2011-01-29 (-38d) |  |  | 376d → 408d |  | constraint none → start no earlier than 2011-01-20; resources none → Readymix Concrete-4500 psi [409.19 cft]; baseline start none → 2011-03-06; baseline finish none → 2011-03-08 |
| 207 | De-shuttering | 2011-03-07 → 2011-01-28 (-38d) | 2011-03-09 → 2011-01-31 (-37d) |  |  | 376d → 408d | 206FF+1d → 206FF+2d | constraint none → start no earlier than 2011-01-20; baseline start none → 2011-03-07; baseline finish none → 2011-03-09 |
| 208 | **Stair - 1** | 2011-03-04 → 2011-01-25 (-38d) | 2011-03-06 → 2011-01-27 (-38d) |  |  | 379d → 411.86d |  | baseline start none → 2011-03-04; baseline finish none → 2011-03-06 |
| 209 | **2nd Flight** | 2011-03-04 → 2011-01-25 (-38d) | 2011-03-06 → 2011-01-27 (-38d) |  |  | 379d → 411.86d |  | baseline start none → 2011-03-04; baseline finish none → 2011-03-06 |
| 210 | Brick Work | 2011-03-04 → 2011-01-25 (-38d) | 2011-03-04 → 2011-01-25 (-38d) |  |  | 379d → 411.86d |  | constraint none → start no earlier than 2011-01-20; baseline start none → 2011-03-04; baseline finish none → 2011-03-04 |
| 211 | Form Work | 2011-03-05 → 2011-01-26 (-38d) | 2011-03-05 → 2011-01-26 (-38d) |  |  | 379d → 411.86d |  | constraint none → start no earlier than 2011-01-20; baseline start none → 2011-03-05; baseline finish none → 2011-03-05 |
| 212 | Re-bar Work | 2011-03-06 → 2011-01-27 (-38d) | 2011-03-06 → 2011-01-27 (-38d) |  |  | 379d → 411.86d |  | constraint none → start no earlier than 2011-01-20; baseline start none → 2011-03-06; baseline finish none → 2011-03-06 |
| 213 | **Ramp** | 2011-03-04 → 2011-01-28 (-35d) | 2011-03-06 → 2011-01-31 (-34d) |  |  | 531d → 571d |  | baseline start none → 2011-03-04; baseline finish none → 2011-03-06 |
| 214 | Form Work | 2011-03-04 → 2011-01-28 (-35d) | 2011-03-04 → 2011-01-29 (-34d) |  |  | 531d → 571d |  | constraint none → start no earlier than 2011-01-20; baseline start none → 2011-03-04; baseline finish none → 2011-03-04 |
| 215 | Re-Bar | 2011-03-05 → 2011-01-29 (-35d) | 2011-03-05 → 2011-01-30 (-34d) |  |  | 531d → 571d |  | constraint none → start no earlier than 2011-01-20; baseline start none → 2011-03-05; baseline finish none → 2011-03-05 |
| 216 | Concrete | 2011-03-06 → 2011-01-30 (-35d) | 2011-03-06 → 2011-01-31 (-34d) |  |  | 531d → 571d |  | constraint none → start no earlier than 2011-01-20; baseline start none → 2011-03-06; baseline finish none → 2011-03-06 |
| 217 | **Roof Slab** | 2011-03-18 → 2011-01-31 (-46d) | 2011-03-24 → 2011-02-08 (-44d) | 7d → 8d |  | 368d → 408d |  | baseline start none → 2011-03-18; baseline finish none → 2011-03-24 |
| 218 | Form Work | 2011-03-18 → 2011-01-31 (-46d) | 2011-03-19 → 2011-02-02 (-45d) |  |  | 368d → 408d |  | baseline start none → 2011-03-18; baseline finish none → 2011-03-19 |
| 219 | Re-bar | 2011-03-20 → 2011-02-02 (-46d) | 2011-03-21 → 2011-02-05 (-44d) | 2d → 3d |  | 368d → 408d | 218FF+2d → 218FF+3d | baseline start none → 2011-03-20; baseline finish none → 2011-03-21 |
| 220 | MEP Work | 2011-03-22 → 2011-02-05 (-45d) | 2011-03-22 → 2011-02-06 (-44d) |  |  | 368d → 408d |  | baseline start none → 2011-03-22; baseline finish none → 2011-03-22 |
| 221 | Inspection | 2011-03-23 → 2011-02-06 (-45d) | 2011-03-23 → 2011-02-07 (-44d) |  |  | 368d → 408d |  | baseline start none → 2011-03-23; baseline finish none → 2011-03-23 |
| 222 | Concrete | 2011-03-24 → 2011-02-07 (-45d) | 2011-03-24 → 2011-02-08 (-44d) |  |  | 368d → 408d |  | resources none → Structural Work-B2 Slab [4032 sft]; Filling Sand [2000 cft]; Readymix Concrete-3500 psi [2665.53 cft]; baseline start none → 2011-03-24; baseline finish none → 2011-03-24 |
| 223 | **BASEMENT-2** | 2011-03-04 → 2011-01-28 A (-35d) | 2011-04-17 → 2011-03-20 (-28d) | 45d → 51d | 0% → 9% | 0d → 523d |  | baseline start none → 2011-03-04; baseline finish none → 2011-04-17 |
| 224 | **PART-1** | 2011-03-04 → 2011-01-28 A (-35d) | 2011-03-28 → 2011-02-25 (-31d) | 25d → 28d | 0% → 17% | 0d → 546d |  | baseline start none → 2011-03-04; baseline finish none → 2011-03-28 |
| 225 | **Retaining Wall** | 2011-03-04 → 2011-01-28 A (-35d) | 2011-03-21 → 2011-02-08 (-41d) | 18d → 11d | 0% → 26% | 0d → 1d |  | baseline start none → 2011-03-04; baseline finish none → 2011-03-21 |
| 226 | Brick Wall | 2011-03-04 → 2011-01-28 A (-35d) | 2011-03-06 → 2011-01-31 A (-34d) |  | 0% → 100% | 0d → none |  | constraint none → start no earlier than 2011-01-20; resources none → Brick [9334.72 nos]; Cement [45.31 bag]; Local Sand [298.71 cft]; MS Rod - Grade 60 [10.33 ton]; baseline start none → 2011-03-04; baseline finish none → 2011-03-06 |
| 227 | Plaster | 2011-03-07 → 2011-01-31 A (-35d) | 2011-03-08 → 2011-02-02 (-34d) |  | 0% → 7% | 0d → 1d |  | constraint none → start no earlier than 2011-01-20; baseline start none → 2011-03-07; baseline finish none → 2011-03-08 |
| 228 | Water Proofing | 2011-03-15 → 2011-02-02 (-41d) | 2011-03-15 → 2011-02-02 (-41d) | 1d → 0d |  | 0d → 1d | 227FF+7d → 227FF | constraint none → start no earlier than 2011-01-20; baseline start none → 2011-03-15; baseline finish none → 2011-03-15 |
| 229 | Re-bar Work | 2011-03-16 → 2011-02-02 (-42d) | 2011-03-18 → 2011-02-05 (-41d) |  |  | 0d → 1d |  | constraint none → start no earlier than 2011-01-20; baseline start none → 2011-03-16; baseline finish none → 2011-03-18 |
| 230 | Form Work | 2011-03-18 → 2011-02-04 (-42d) | 2011-03-19 → 2011-02-06 (-41d) |  |  | 0d → 1d |  | resources none → Polythene (0.2mm thick) [2263.2 sft]; baseline start none → 2011-03-18; baseline finish none → 2011-03-19 |
| 231 | Conreting | 2011-03-20 → 2011-02-06 (-42d) | 2011-03-20 → 2011-02-07 (-41d) |  |  | 0d → 1d |  | resources none → Water Stopper-6" Width [1000 rft]; Bonding Chemical [1.87 L]; Readymix Concrete-4500 psi [1650.58 cft]; baseline start none → 2011-03-20; baseline finish none → 2011-03-20 |
| 232 | De-shuttering | 2011-03-21 → 2011-02-07 (-42d) | 2011-03-21 → 2011-02-08 (-41d) |  |  | 0d → 1d |  | baseline start none → 2011-03-21; baseline finish none → 2011-03-21 |
| 233 | **Column** | 2011-03-04 → 2011-01-28 A (-35d) | 2011-03-11 → 2011-02-05 (-34d) |  | 0% → 39% | 10d → 4d |  | baseline start none → 2011-03-04; baseline finish none → 2011-03-11 |
| 234 | Re-Bar Work | 2011-03-04 → 2011-01-28 A (-35d) | 2011-03-05 → 2011-01-30 A (-34d) |  | 0% → 100% | 10d → none |  | constraint none → start no earlier than 2011-01-20; resources none → MS Rod - Grade 60 [9.8 ton]; baseline start none → 2011-03-04; baseline finish none → 2011-03-05 |
| 235 | Form Work | 2011-03-06 → 2011-01-30 A (-35d) | 2011-03-07 → 2011-02-01 (-34d) |  | 0% → 57% | 10d → 4d |  | constraint none → start no earlier than 2011-01-20; baseline start none → 2011-03-06; baseline finish none → 2011-03-07 |
| 236 | Concrete | 2011-03-08 → 2011-02-01 (-35d) | 2011-03-09 → 2011-02-03 (-34d) |  |  | 10d → 4d |  | constraint none → start no earlier than 2011-01-20; resources none → Readymix Concrete-4500 psi [556.26 cft]; baseline start none → 2011-03-08; baseline finish none → 2011-03-09 |
| 237 | De-shuttering | 2011-03-10 → 2011-02-03 (-35d) | 2011-03-11 → 2011-02-05 (-34d) |  |  | 10d → 4d |  | constraint none → start no earlier than 2011-01-20; baseline start none → 2011-03-10; baseline finish none → 2011-03-11 |
| 238 | **Shear Wall** | 2011-03-04 → 2011-01-28 A (-35d) | 2011-03-15 → 2011-02-09 (-34d) |  | 0% → 26% | 6d → 0d |  | baseline start none → 2011-03-04; baseline finish none → 2011-03-15 |
| 239 | Re-Bar Work | 2011-03-04 → 2011-01-28 A (-35d) | 2011-03-06 → 2011-01-31 A (-34d) |  | 0% → 100% | 6d → none |  | constraint none → start no earlier than 2011-01-20; resources none → MS Rod - Grade 60 [5.15 ton]; baseline start none → 2011-03-04; baseline finish none → 2011-03-06 |
| 240 | Form Work | 2011-03-07 → 2011-01-31 A (-35d) | 2011-03-09 → 2011-02-03 (-34d) |  | 0% → 5% | 6d → 0d |  | constraint none → start no earlier than 2011-01-20; baseline start none → 2011-03-07; baseline finish none → 2011-03-09 |
| 241 | Concrete | 2011-03-10 → 2011-02-03 (-35d) | 2011-03-12 → 2011-02-06 (-34d) |  |  | 6d → 0d |  | constraint none → start no earlier than 2011-01-20; resources none → Readymix Concrete-4500 psi [402.58 cft]; baseline start none → 2011-03-10; baseline finish none → 2011-03-12 |
| 242 | De-shuttering | 2011-03-13 → 2011-02-06 (-35d) | 2011-03-15 → 2011-02-09 (-34d) |  |  | 6d → 0d |  | baseline start none → 2011-03-13; baseline finish none → 2011-03-15 |
| 243 | **Stair - 1** | 2011-03-25 → 2011-02-08 (-45d) | 2011-03-28 → 2011-02-12 (-44d) |  |  | 368d → 408d |  | baseline start none → 2011-03-25; baseline finish none → 2011-03-28 |
| 244 | **1st Flight** | 2011-03-25 → 2011-02-08 (-45d) | 2011-03-28 → 2011-02-12 (-44d) |  |  | 368d → 408d |  | baseline start none → 2011-03-25; baseline finish none → 2011-03-28 |

| ID | Task | Start | Finish | Duration | Total float | Predecessors | Other |
| --- | --- | --- | --- | --- | --- | --- | --- |
| 245 | Brick Work | 2011-03-25 → 2011-02-08 (-45d) | 2011-03-25 → 2011-02-09 (-44d) |  | 368d → 408d |  | baseline start none → 2011-03-25; baseline finish none → 2011-03-25 |
| 246 | Form Work | 2011-03-26 → 2011-02-09 (-45d) | 2011-03-26 → 2011-02-10 (-44d) |  | 368d → 408d |  | resources none → MS Rod - Grade 60 [2.79 ton]; baseline start none → 2011-03-26; baseline finish none → 2011-03-26 |
| 247 | Re-bar Work | 2011-03-27 → 2011-02-10 (-45d) | 2011-03-27 → 2011-02-11 (-44d) |  | 368d → 408d |  | baseline start none → 2011-03-27; baseline finish none → 2011-03-27 |
| 248 | Concrete | 2011-03-28 → 2011-02-11 (-45d) | 2011-03-28 → 2011-02-12 (-44d) |  | 368d → 408d |  | resources none → Readymix Concrete-3500 psi [121.06 cft]; baseline start none → 2011-03-28; baseline finish none → 2011-03-28 |
| 249 | **Ramp** | 2011-03-23 → 2011-02-14 (-37d) | 2011-03-24 → 2011-02-16 (-36d) |  | 513d → 555d |  | baseline start none → 2011-03-23; baseline finish none → 2011-03-24 |
| 250 | Form Work | 2011-03-23 → 2011-02-14 (-37d) | 2011-03-23 → 2011-02-15 (-36d) |  | 513d → 555d |  | resources none → MS Rod - Grade 60 [2.48 ton]; baseline start none → 2011-03-23; baseline finish none → 2011-03-23 |
| 251 | Re-Bar | 2011-03-24 → 2011-02-15 (-37d) | 2011-03-24 → 2011-02-16 (-36d) |  | 513d → 555d |  | baseline start none → 2011-03-24; baseline finish none → 2011-03-24 |
| 252 | **Roof Slab** | 2011-03-22 → 2011-02-09 (-41d) | 2011-03-28 → 2011-02-25 (-31d) | 7d → 16d |  |  | baseline start none → 2011-03-22; baseline finish none → 2011-03-28 |
| 253 | Form Work | 2011-03-22 → 2011-02-09 (-41d) | 2011-03-23 → 2011-02-15 (-36d) | 2d → 6d |  |  | resources none → MS Rod - Grade 60 [12.76 ton]; baseline start none → 2011-03-22; baseline finish none → 2011-03-23 |
| 254 | Re-bar | 2011-03-24 → 2011-02-15 (-37d) | 2011-03-25 → 2011-02-22 (-31d) | 2d → 7d |  | 253FF+2d → 253FF+7d | baseline start none → 2011-03-24; baseline finish none → 2011-03-25 |
| 255 | MEP Work | 2011-03-26 → 2011-02-22 (-32d) | 2011-03-26 → 2011-02-23 (-31d) |  |  |  | baseline start none → 2011-03-26; baseline finish none → 2011-03-26 |
| 256 | Inspection | 2011-03-27 → 2011-02-23 (-32d) | 2011-03-27 → 2011-02-24 (-31d) |  |  |  | baseline start none → 2011-03-27; baseline finish none → 2011-03-27 |
| 257 | Concrete | 2011-03-28 → 2011-02-24 (-32d) | 2011-03-28 → 2011-02-25 (-31d) |  |  |  | resources none → Structural Work-B1 Slab [4032 sft]; Filling Sand [2000 cft]; Readymix Concrete-3500 psi [2570.5 cft]; baseline start none → 2011-03-28; baseline finish none → 2011-03-28 |
| 258 | **PART-2** | 2011-03-27 → 2011-02-12 (-43d) | 2011-04-17 → 2011-03-20 (-28d) | 22d → 36d | 359d → 404d |  | baseline start none → 2011-03-27; baseline finish none → 2011-04-17 |
| 259 | **Retaining Wall** | 2011-03-28 → 2011-02-24 (-32d) | 2011-04-10 → 2011-03-03 (-38d) | 14d → 7d | 358d → 392d |  | baseline start none → 2011-03-28; baseline finish none → 2011-04-10 |
| 260 | Brick Wall | 2011-03-28 → 2011-02-24 (-32d) | 2011-03-29 → 2011-02-26 (-31d) |  | 358d → 392d |  | resources none → Brick [9334.72 nos]; Cement [45.31 bag]; Local Sand [298.71 cft]; baseline start none → 2011-03-28; baseline finish none → 2011-03-29 |
| 261 | Plaster | 2011-03-29 → 2011-02-25 (-32d) | 2011-03-30 → 2011-02-27 (-31d) |  | 358d → 392d |  | baseline start none → 2011-03-29; baseline finish none → 2011-03-30 |
| 262 | Water Proofing | 2011-04-05 → 2011-02-27 (-37d) | 2011-04-06 → 2011-02-27 (-38d) | 2d → 0d | 358d → 392d | 261FF+7d → 261FF | baseline start none → 2011-04-05; baseline finish none → 2011-04-06 |
| 263 | Re-bar Work | 2011-04-06 → 2011-02-26 (-39d) | 2011-04-07 → 2011-02-28 (-38d) |  | 358d → 392d |  | baseline start none → 2011-04-06; baseline finish none → 2011-04-07 |
| 264 | Form Work | 2011-04-07 → 2011-02-27 (-39d) | 2011-04-08 → 2011-03-01 (-38d) |  | 358d → 392d |  | resources none → Polythene (0.2mm thick) [2263.2 sft]; baseline start none → 2011-04-07; baseline finish none → 2011-04-08 |
| 265 | Conreting | 2011-04-08 → 2011-02-28 (-39d) | 2011-04-09 → 2011-03-02 (-38d) |  | 358d → 392d |  | resources none → Water Stopper-6" Width [1000 rft]; Readymix Concrete-4500 psi [1650.58 cft]; baseline start none → 2011-04-08; baseline finish none → 2011-04-09 |
| 266 | De-shuttering | 2011-04-09 → 2011-03-01 (-39d) | 2011-04-10 → 2011-03-03 (-38d) |  | 358d → 392d |  | baseline start none → 2011-04-09; baseline finish none → 2011-04-10 |
| 267 | **Column** | 2011-03-28 → 2011-02-24 (-32d) | 2011-04-01 → 2011-03-01 (-31d) |  | 367d → 394d |  | baseline start none → 2011-03-28; baseline finish none → 2011-04-01 |
| 268 | Re-Bar Work | 2011-03-28 → 2011-02-24 (-32d) | 2011-03-29 → 2011-02-26 (-31d) |  | 367d → 394d |  | baseline start none → 2011-03-28; baseline finish none → 2011-03-29 |
| 269 | Form Work | 2011-03-29 → 2011-02-25 (-32d) | 2011-03-30 → 2011-02-27 (-31d) |  | 367d → 394d |  | baseline start none → 2011-03-29; baseline finish none → 2011-03-30 |
| 270 | Concrete | 2011-03-30 → 2011-02-26 (-32d) | 2011-03-31 → 2011-02-28 (-31d) |  | 367d → 394d |  | resources none → Readymix Concrete-4500 psi [556.26 cft]; baseline start none → 2011-03-30; baseline finish none → 2011-03-31 |
| 271 | De-shuttering | 2011-03-31 → 2011-02-27 (-32d) | 2011-04-01 → 2011-03-01 (-31d) |  | 367d → 394d |  | baseline start none → 2011-03-31; baseline finish none → 2011-04-01 |
| 272 | **Shear Wall** | 2011-03-27 → 2011-02-23 (-32d) | 2011-04-01 → 2011-03-01 (-31d) |  | 367d → 394d |  | baseline start none → 2011-03-27; baseline finish none → 2011-04-01 |
| 273 | Re-Bar Work | 2011-03-27 → 2011-02-23 (-32d) | 2011-03-29 → 2011-02-26 (-31d) |  | 367d → 394d |  | baseline start none → 2011-03-27; baseline finish none → 2011-03-29 |
| 274 | Form Work | 2011-03-28 → 2011-02-24 (-32d) | 2011-03-30 → 2011-02-27 (-31d) |  | 367d → 394d |  | baseline start none → 2011-03-28; baseline finish none → 2011-03-30 |
| 275 | Concrete | 2011-03-29 → 2011-02-25 (-32d) | 2011-03-31 → 2011-02-28 (-31d) |  | 367d → 394d |  | resources none → Readymix Concrete-4500 psi [402.58 cft]; baseline start none → 2011-03-29; baseline finish none → 2011-03-31 |
| 276 | De-shuttering | 2011-03-30 → 2011-02-26 (-32d) | 2011-04-01 → 2011-03-01 (-31d) |  | 367d → 394d |  | baseline start none → 2011-03-30; baseline finish none → 2011-04-01 |
| 277 | **Stair - 1** | 2011-03-29 → 2011-02-12 (-45d) | 2011-03-31 → 2011-02-15 (-44d) |  | 368d → 408d |  | baseline start none → 2011-03-29; baseline finish none → 2011-03-31 |
| 278 | **2nd Flight** | 2011-03-29 → 2011-02-12 (-45d) | 2011-03-31 → 2011-02-15 (-44d) |  | 368d → 408d |  | baseline start none → 2011-03-29; baseline finish none → 2011-03-31 |
| 279 | Brick Work | 2011-03-29 → 2011-02-12 (-45d) | 2011-03-29 → 2011-02-13 (-44d) |  | 368d → 408d |  | baseline start none → 2011-03-29; baseline finish none → 2011-03-29 |
| 280 | Form Work | 2011-03-30 → 2011-02-13 (-45d) | 2011-03-30 → 2011-02-14 (-44d) |  | 368d → 408d |  | baseline start none → 2011-03-30; baseline finish none → 2011-03-30 |
| 281 | Re-bar Work | 2011-03-31 → 2011-02-14 (-45d) | 2011-03-31 → 2011-02-15 (-44d) |  | 368d → 408d |  | baseline start none → 2011-03-31; baseline finish none → 2011-03-31 |
| 282 | **Ramp** | 2011-03-29 → 2011-02-25 (-32d) | 2011-03-31 → 2011-02-28 (-31d) |  | 506d → 543d |  | baseline start none → 2011-03-29; baseline finish none → 2011-03-31 |
| 283 | Form Work | 2011-03-29 → 2011-02-25 (-32d) | 2011-03-29 → 2011-02-26 (-31d) |  | 506d → 543d |  | baseline start none → 2011-03-29; baseline finish none → 2011-03-29 |
| 284 | Re-Bar | 2011-03-30 → 2011-02-26 (-32d) | 2011-03-30 → 2011-02-27 (-31d) |  | 506d → 543d |  | baseline start none → 2011-03-30; baseline finish none → 2011-03-30 |
| 285 | Concrete | 2011-03-31 → 2011-02-27 (-32d) | 2011-03-31 → 2011-02-28 (-31d) |  | 506d → 543d |  | baseline start none → 2011-03-31; baseline finish none → 2011-03-31 |
| 286 | **Roof Slab** | 2011-04-11 → 2011-03-03 (-39d) | 2011-04-17 → 2011-03-20 (-28d) | 7d → 17d | 358d → 392d |  | baseline start none → 2011-04-11; baseline finish none → 2011-04-17 |
| 287 | Form Work | 2011-04-11 → 2011-03-03 (-39d) | 2011-04-12 → 2011-03-10 (-33d) | 2d → 7d | 358d → 392d |  | baseline start none → 2011-04-11; baseline finish none → 2011-04-12 |
| 288 | Re-bar | 2011-04-13 → 2011-03-10 (-34d) | 2011-04-14 → 2011-03-17 (-28d) | 2d → 7d | 358d → 392d | 287FF+2d → 287FF+7d | baseline start none → 2011-04-13; baseline finish none → 2011-04-14 |
| 289 | MEP Work | 2011-04-15 → 2011-03-17 (-29d) | 2011-04-15 → 2011-03-18 (-28d) |  | 358d → 392d |  | baseline start none → 2011-04-15; baseline finish none → 2011-04-15 |
| 290 | Inspection | 2011-04-16 → 2011-03-18 (-29d) | 2011-04-16 → 2011-03-19 (-28d) |  | 358d → 392d |  | baseline start none → 2011-04-16; baseline finish none → 2011-04-16 |
| 291 | Concrete | 2011-04-17 → 2011-03-19 (-29d) | 2011-04-17 → 2011-03-20 (-28d) |  | 358d → 392d |  | resources none → Structural Work-B1 Slab [4032 sft]; Filling Sand [2000 cft]; Readymix Concrete-3500 psi [2691.56 cft]; baseline start none → 2011-04-17; baseline finish none → 2011-04-17 |
| 292 | **BASEMENT-1** | 2011-03-29 → 2011-02-25 (-32d) | 2011-05-12 → 2011-05-18 (+6d) | 45d → 82d |  |  | baseline start none → 2011-03-29; baseline finish none → 2011-05-12 |
| 293 | **PART-1** | 2011-03-29 → 2011-02-25 (-32d) | 2011-04-22 → 2011-04-16 (-6d) | 25d → 50d |  |  | baseline start none → 2011-03-29; baseline finish none → 2011-04-22 |
| 294 | **Retaining Wall** | 2011-03-29 → 2011-02-25 (-32d) | 2011-04-15 → 2011-03-18 (-28d) | 18d → 21d |  |  | baseline start none → 2011-03-29; baseline finish none → 2011-04-15 |
| 295 | Brick Wall | 2011-03-29 → 2011-02-25 (-32d) | 2011-03-31 → 2011-03-07 (-24d) | 3d → 10d |  |  | resources none → Brick [9334.72 nos]; Cement [45.31 bag]; Local Sand [298.71 cft]; MS Rod - Grade 60 [10.33 ton]; baseline start none → 2011-03-29; baseline finish none → 2011-03-31 |
| 296 | Plaster | 2011-04-01 → 2011-03-07 (-25d) | 2011-04-02 → 2011-03-10 (-23d) | 2d → 3d |  |  | baseline start none → 2011-04-01; baseline finish none → 2011-04-02 |
| 297 | Water Proofing | 2011-04-09 → 2011-03-10 (-30d) | 2011-04-09 → 2011-03-10 (-30d) | 1d → 0d |  | 296FF+7d → 296FF | baseline start none → 2011-04-09; baseline finish none → 2011-04-09 |
| 298 | Re-bar Work | 2011-04-10 → 2011-03-10 (-31d) | 2011-04-12 → 2011-03-13 (-30d) |  |  |  | baseline start none → 2011-04-10; baseline finish none → 2011-04-12 |
| 299 | Form Work | 2011-04-12 → 2011-03-13 (-30d) | 2011-04-13 → 2011-03-16 (-28d) | 2d → 3d |  | 298FF+1d → 298FF+3d | resources none → Polythene (0.2mm thick) [2263.2 sft]; baseline start none → 2011-04-12; baseline finish none → 2011-04-13 |
| 300 | Conreting | 2011-04-14 → 2011-03-15 (-30d) | 2011-04-14 → 2011-03-17 (-28d) | 1d → 2d |  |  | resources none → Water Stopper-6" Width [1000 rft]; Bonding Chemical [1.87 L]; Readymix Concrete-4500 psi [1651 cft]; baseline start none → 2011-04-14; baseline finish none → 2011-04-14 |
| 301 | De-shuttering | 2011-04-15 → 2011-03-17 (-29d) | 2011-04-15 → 2011-03-18 (-28d) |  |  |  | baseline start none → 2011-04-15; baseline finish none → 2011-04-15 |
| 302 | **Column** | 2011-03-29 → 2011-02-25 (-32d) | 2011-04-05 → 2011-03-07 (-29d) | 8d → 10d | 10d → 11d |  | baseline start none → 2011-03-29; baseline finish none → 2011-04-05 |
| 303 | Re-Bar Work | 2011-03-29 → 2011-02-25 (-32d) | 2011-03-30 → 2011-02-27 (-31d) |  | 10d → 11d |  | resources none → MS Rod - Grade 60 [9.8 ton]; baseline start none → 2011-03-29; baseline finish none → 2011-03-30 |
| 304 | Form Work | 2011-03-31 → 2011-02-27 (-32d) | 2011-04-01 → 2011-03-01 (-31d) |  | 10d → 11d |  | baseline start none → 2011-03-31; baseline finish none → 2011-04-01 |
| 305 | Concrete | 2011-04-02 → 2011-03-01 (-32d) | 2011-04-03 → 2011-03-05 (-29d) | 2d → 4d | 10d → 11d |  | resources none → Readymix Concrete-4500 psi [670.37 cft]; baseline start none → 2011-04-02; baseline finish none → 2011-04-03 |
| 306 | De-shuttering | 2011-04-04 → 2011-03-05 (-30d) | 2011-04-05 → 2011-03-07 (-29d) |  | 10d → 11d |  | baseline start none → 2011-04-04; baseline finish none → 2011-04-05 |
| 307 | **Shear Wall** | 2011-03-29 → 2011-02-25 (-32d) | 2011-04-09 → 2011-03-15 (-25d) | 12d → 18d | 6d → 3d |  | baseline start none → 2011-03-29; baseline finish none → 2011-04-09 |
| 308 | Re-Bar Work | 2011-03-29 → 2011-02-25 (-32d) | 2011-03-31 → 2011-03-03 (-28d) | 3d → 6d | 6d → 3d |  | resources none → MS Rod - Grade 60 [5.15 ton]; baseline start none → 2011-03-29; baseline finish none → 2011-03-31 |
| 309 | Form Work | 2011-04-01 → 2011-03-03 (-29d) | 2011-04-03 → 2011-03-06 (-28d) |  | 6d → 3d |  | baseline start none → 2011-04-01; baseline finish none → 2011-04-03 |
| 310 | Concrete | 2011-04-04 → 2011-03-06 (-29d) | 2011-04-06 → 2011-03-12 (-25d) | 3d → 6d | 6d → 3d |  | resources none → Readymix Concrete-4500 psi [485.16 cft]; baseline start none → 2011-04-04; baseline finish none → 2011-04-06 |
| 311 | De-shuttering | 2011-04-07 → 2011-03-12 (-26d) | 2011-04-09 → 2011-03-15 (-25d) |  | 6d → 3d |  | baseline start none → 2011-04-07; baseline finish none → 2011-04-09 |
| 312 | **Stair - 1** | 2011-03-29 → 2011-02-25 (-32d) | 2011-04-01 → 2011-03-03 (-29d) | 4d → 6d | 31d → 55d |  | baseline start none → 2011-03-29; baseline finish none → 2011-04-01 |
| 313 | **1st Flight** | 2011-03-29 → 2011-02-25 (-32d) | 2011-04-01 → 2011-03-03 (-29d) | 4d → 6d | 31d → 55d |  | baseline start none → 2011-03-29; baseline finish none → 2011-04-01 |
| 314 | Brick Work | 2011-03-29 → 2011-02-25 (-32d) | 2011-03-29 → 2011-02-27 (-30d) | 1d → 2d | 31d → 55d |  | baseline start none → 2011-03-29; baseline finish none → 2011-03-29 |

| ID | Task | Start | Finish | Duration | Total float | Predecessors | Other |
| --- | --- | --- | --- | --- | --- | --- | --- |
| 315 | Form Work | 2011-03-30 → 2011-02-27 (-31d) | 2011-03-30 → 2011-02-28 (-30d) |  | 31d → 55d |  | resources none → MS Rod - Grade 60 [2.79 ton]; baseline start none → 2011-03-30; baseline finish none → 2011-03-30 |
| 316 | Re-bar Work | 2011-03-31 → 2011-02-28 (-31d) | 2011-03-31 → 2011-03-01 (-30d) |  | 31d → 55d |  | baseline start none → 2011-03-31; baseline finish none → 2011-03-31 |
| 317 | Concrete | 2011-04-01 → 2011-03-01 (-31d) | 2011-04-01 → 2011-03-03 (-29d) | 1d → 2d | 31d → 55d |  | resources none → Readymix Concrete-3500 psi [121.06 cft]; baseline start none → 2011-04-01; baseline finish none → 2011-04-01 |
| 318 | **Ramp** | 2011-04-17 → 2011-04-03 (-14d) | 2011-04-18 → 2011-04-06 (-12d) | 2d → 3d | 488d → 506d |  | baseline start none → 2011-04-17; baseline finish none → 2011-04-18 |
| 319 | Form Work | 2011-04-17 → 2011-04-03 (-14d) | 2011-04-17 → 2011-04-05 (-12d) | 1d → 2d | 488d → 506d |  | resources none → MS Rod - Grade 60 [2.48 ton]; baseline start none → 2011-04-17; baseline finish none → 2011-04-17 |
| 320 | Re-Bar | 2011-04-18 → 2011-04-05 (-13d) | 2011-04-18 → 2011-04-06 (-12d) |  | 488d → 506d |  | baseline start none → 2011-04-18; baseline finish none → 2011-04-18 |
| 321 | **Roof Slab** | 2011-04-16 → 2011-03-18 (-29d) | 2011-04-22 → 2011-04-16 (-6d) | 7d → 29d |  |  | baseline start none → 2011-04-16; baseline finish none → 2011-04-22 |
| 322 | Form Work | 2011-04-16 → 2011-03-18 (-29d) | 2011-04-17 → 2011-04-05 (-12d) | 2d → 18d |  |  | resources none → MS Rod - Grade 60 [12.78 ton]; baseline start none → 2011-04-16; baseline finish none → 2011-04-17 |
| 323 | Re-bar | 2011-04-18 → 2011-04-04 (-14d) | 2011-04-19 → 2011-04-12 (-7d) | 2d → 8d |  | 322FF+2d → 322FF+7d | baseline start none → 2011-04-18; baseline finish none → 2011-04-19 |
| 324 | MEP Work | 2011-04-20 → 2011-04-12 (-8d) | 2011-04-20 → 2011-04-13 (-7d) |  |  |  | baseline start none → 2011-04-20; baseline finish none → 2011-04-20 |
| 325 | Inspection | 2011-04-21 → 2011-04-13 (-8d) | 2011-04-21 → 2011-04-14 (-7d) |  |  |  | baseline start none → 2011-04-21; baseline finish none → 2011-04-21 |
| 326 | Concrete | 2011-04-22 → 2011-04-14 (-8d) | 2011-04-22 → 2011-04-16 (-6d) | 1d → 2d |  |  | resources none → Structural Work-GF Slab [4032 sft]; Filling Sand [2000 cft]; Readymix Concrete-3500 psi [2587.93 cft]; baseline start none → 2011-04-22; baseline finish none → 2011-04-22 |
| 327 | **PART-2** | 2011-04-02 → 2011-03-03 (-30d) | 2011-05-12 → 2011-05-18 (+6d) | 41d → 76d | 20d → 42d |  | baseline start none → 2011-04-02; baseline finish none → 2011-05-12 |
| 328 | **Retaining Wall** | 2011-04-22 → 2011-04-14 (-8d) | 2011-05-05 → 2011-04-30 (-5d) | 14d → 16d |  |  | baseline start none → 2011-04-22; baseline finish none → 2011-05-05 |
| 329 | Brick Wall | 2011-04-22 → 2011-04-14 (-8d) | 2011-04-23 → 2011-04-19 (-4d) | 2d → 5d |  | 326FF+1d → 326FF+3d | resources none → Brick [9334.72 nos]; Cement [45.31 bag]; Local Sand [298.71 cft]; baseline start none → 2011-04-22; baseline finish none → 2011-04-23 |
| 330 | Plaster | 2011-04-23 → 2011-04-19 (-4d) | 2011-04-24 → 2011-04-22 (-2d) | 2d → 3d |  | 329FF+1d → 329FF+3d | baseline start none → 2011-04-23; baseline finish none → 2011-04-24 |
| 331 | Water Proofing | 2011-04-30 → 2011-04-22 (-8d) | 2011-05-01 → 2011-04-22 (-9d) | 2d → 0d |  | 330FF+7d → 330FF | baseline start none → 2011-04-30; baseline finish none → 2011-05-01 |
| 332 | Re-bar Work | 2011-05-01 → 2011-04-20 (-11d) | 2011-05-02 → 2011-04-23 (-9d) | 2d → 3d |  |  | baseline start none → 2011-05-01; baseline finish none → 2011-05-02 |
| 333 | Form Work | 2011-05-02 → 2011-04-25 (-7d) | 2011-05-03 → 2011-04-28 (-5d) | 2d → 3d |  | 332FF+1d → 332FF+5d | resources none → Polythene (0.2mm thick) [2263.2 sft]; baseline start none → 2011-05-02; baseline finish none → 2011-05-03 |
| 334 | Conreting | 2011-05-03 → 2011-04-25 (-8d) | 2011-05-04 → 2011-04-29 (-5d) | 2d → 4d |  |  | resources none → Readymix Concrete-4500 psi [1651 cft]; baseline start none → 2011-05-03; baseline finish none → 2011-05-04 |
| 335 | De-shuttering | 2011-05-04 → 2011-04-28 (-6d) | 2011-05-05 → 2011-04-30 (-5d) |  |  |  | baseline start none → 2011-05-04; baseline finish none → 2011-05-05 |
| 336 | **Column** | 2011-04-22 → 2011-04-15 (-7d) | 2011-04-26 → 2011-04-20 (-6d) |  | 9d → 10d |  | baseline start none → 2011-04-22; baseline finish none → 2011-04-26 |
| 337 | Re-Bar Work | 2011-04-22 → 2011-04-15 (-7d) | 2011-04-23 → 2011-04-17 (-6d) |  | 9d → 10d |  | baseline start none → 2011-04-22; baseline finish none → 2011-04-23 |
| 338 | Form Work | 2011-04-23 → 2011-04-16 (-7d) | 2011-04-24 → 2011-04-18 (-6d) |  | 9d → 10d |  | baseline start none → 2011-04-23; baseline finish none → 2011-04-24 |
| 339 | Concrete | 2011-04-24 → 2011-04-15 (-9d) | 2011-04-25 → 2011-04-19 (-6d) | 2d → 4d | 9d → 10d |  | resources none → Readymix Concrete-4500 psi [670.37 cft]; baseline start none → 2011-04-24; baseline finish none → 2011-04-25 |
| 340 | De-shuttering | 2011-04-25 → 2011-04-18 (-7d) | 2011-04-26 → 2011-04-20 (-6d) |  | 9d → 10d |  | baseline start none → 2011-04-25; baseline finish none → 2011-04-26 |
| 341 | **Shear Wall** | 2011-04-21 → 2011-04-13 (-8d) | 2011-04-26 → 2011-04-20 (-6d) | 6d → 7d | 9d → 10d |  | baseline start none → 2011-04-21; baseline finish none → 2011-04-26 |
| 342 | Re-Bar Work | 2011-04-21 → 2011-04-14 (-7d) | 2011-04-23 → 2011-04-17 (-6d) |  | 9d → 10d |  | baseline start none → 2011-04-21; baseline finish none → 2011-04-23 |
| 343 | Form Work | 2011-04-22 → 2011-04-15 (-7d) | 2011-04-24 → 2011-04-18 (-6d) |  | 9d → 10d |  | baseline start none → 2011-04-22; baseline finish none → 2011-04-24 |
| 344 | Concrete | 2011-04-23 → 2011-04-13 (-10d) | 2011-04-25 → 2011-04-19 (-6d) | 3d → 6d | 9d → 10d |  | resources none → Readymix Concrete-4500 psi [485.16 cft]; baseline start none → 2011-04-23; baseline finish none → 2011-04-25 |
| 345 | De-shuttering | 2011-04-24 → 2011-04-17 (-7d) | 2011-04-26 → 2011-04-20 (-6d) |  | 9d → 10d |  | baseline start none → 2011-04-24; baseline finish none → 2011-04-26 |
| 346 | **Stair - 1** | 2011-04-02 → 2011-03-03 (-30d) | 2011-04-04 → 2011-03-06 (-29d) |  | 31d → 55d |  | baseline start none → 2011-04-02; baseline finish none → 2011-04-04 |
| 347 | **2nd Flight** | 2011-04-02 → 2011-03-03 (-30d) | 2011-04-04 → 2011-03-06 (-29d) |  | 31d → 55d |  | baseline start none → 2011-04-02; baseline finish none → 2011-04-04 |
| 348 | Brick Work | 2011-04-02 → 2011-03-03 (-30d) | 2011-04-02 → 2011-03-04 (-29d) |  | 31d → 55d |  | baseline start none → 2011-04-02; baseline finish none → 2011-04-02 |
| 349 | Form Work | 2011-04-03 → 2011-03-04 (-30d) | 2011-04-03 → 2011-03-05 (-29d) |  | 31d → 55d |  | baseline start none → 2011-04-03; baseline finish none → 2011-04-03 |
| 350 | Re-bar Work | 2011-04-04 → 2011-03-05 (-30d) | 2011-04-04 → 2011-03-06 (-29d) |  | 31d → 55d |  | baseline start none → 2011-04-04; baseline finish none → 2011-04-04 |
| 351 | **Ramp** | 2011-04-23 → 2011-04-16 (-7d) | 2011-04-25 → 2011-04-19 (-6d) |  | 481d → 493d |  | baseline start none → 2011-04-23; baseline finish none → 2011-04-25 |
| 352 | Form Work | 2011-04-23 → 2011-04-16 (-7d) | 2011-04-23 → 2011-04-17 (-6d) |  | 481d → 493d |  | baseline start none → 2011-04-23; baseline finish none → 2011-04-23 |
| 353 | Re-Bar | 2011-04-24 → 2011-04-17 (-7d) | 2011-04-24 → 2011-04-18 (-6d) |  | 481d → 493d |  | baseline start none → 2011-04-24; baseline finish none → 2011-04-24 |
| 354 | Concrete | 2011-04-25 → 2011-04-17 (-8d) | 2011-04-25 → 2011-04-19 (-6d) | 1d → 2d | 481d → 493d |  | baseline start none → 2011-04-25; baseline finish none → 2011-04-25 |
| 355 | **Roof Slab** | 2011-05-06 → 2011-04-30 (-6d) | 2011-05-12 → 2011-05-18 (+6d) | 7d → 18d |  |  | baseline start none → 2011-05-06; baseline finish none → 2011-05-12 |
| 356 | Form Work | 2011-05-06 → 2011-04-30 (-6d) |  | 2d → 7d |  |  | baseline start none → 2011-05-06; baseline finish none → 2011-05-07 |
| 357 | Re-bar | 2011-05-08 → 2011-05-06 (-2d) | 2011-05-09 → 2011-05-14 (+5d) | 2d → 8d |  | 356FF+2d → 356FF+7d | baseline start none → 2011-05-08; baseline finish none → 2011-05-09 |
| 358 | MEP Work | 2011-05-10 → 2011-05-14 (+4d) | 2011-05-10 → 2011-05-15 (+5d) |  |  |  | baseline start none → 2011-05-10; baseline finish none → 2011-05-10 |
| 359 | Inspection | 2011-05-11 → 2011-05-15 (+4d) | 2011-05-11 → 2011-05-16 (+5d) |  |  |  | baseline start none → 2011-05-11; baseline finish none → 2011-05-11 |
| 360 | Concrete | 2011-05-12 → 2011-05-16 (+4d) | 2011-05-12 → 2011-05-18 (+6d) | 1d → 2d |  |  | resources none → Structural Work-GF Slab [4032 sft]; Filling Sand [1390 cft]; Readymix Concrete-3500 psi [2708.99 cft]; baseline start none → 2011-05-12; baseline finish none → 2011-05-12 |
| 361 | **SUPER STRUCTURE** | 2011-05-13 → 2011-05-18 (+5d) | 2012-06-01 → 2012-06-07 (+6d) |  |  |  | baseline start none → 2011-05-13; baseline finish none → 2012-06-02 |
| 362 | **GROUND FLOOR** | 2011-05-13 → 2011-05-18 (+5d) | 2011-06-06 → 2011-06-12 (+6d) |  |  |  | baseline start none → 2011-05-13; baseline finish none → 2011-06-07 |
| 363 | **Column** | 2011-05-13 → 2011-05-18 (+5d) | 2011-05-24 → 2011-05-30 (+6d) |  |  |  | baseline start none → 2011-05-13; baseline finish none → 2011-05-25 |
| 364 | **1ST Lift** | 2011-05-13 → 2011-05-18 (+5d) | 2011-05-18 → 2011-05-24 (+6d) |  |  |  | baseline start none → 2011-05-13; baseline finish none → 2011-05-19 |
| 365 | Re-Bar Work | 2011-05-13 → 2011-05-18 (+5d) | 2011-05-13 → 2011-05-19 (+6d) |  |  |  | baseline start none → 2011-05-13; baseline finish none → 2011-05-14 |
| 366 | Form Work | 2011-05-14 → 2011-05-19 (+5d) | 2011-05-14 → 2011-05-20 (+6d) |  |  |  | baseline start none → 2011-05-14; baseline finish none → 2011-05-15 |
| 367 | Concrete | 2011-05-15 → 2011-05-20 (+5d) | 2011-05-15 → 2011-05-21 (+6d) |  |  |  | baseline start none → 2011-05-15; baseline finish none → 2011-05-16 |
| 368 | De-shuttering | 2011-05-18 → 2011-05-23 (+5d) | 2011-05-18 → 2011-05-24 (+6d) |  |  |  | baseline start none → 2011-05-18; baseline finish none → 2011-05-19 |
| 369 | **2nd Lift** | 2011-05-19 → 2011-05-24 (+5d) | 2011-05-24 → 2011-05-30 (+6d) |  |  |  | baseline start none → 2011-05-19; baseline finish none → 2011-05-25 |
| 370 | Re-Bar Work | 2011-05-19 → 2011-05-24 (+5d) | 2011-05-19 → 2011-05-25 (+6d) |  |  |  | baseline start none → 2011-05-19; baseline finish none → 2011-05-20 |
| 371 | Form Work | 2011-05-20 → 2011-05-25 (+5d) | 2011-05-20 → 2011-05-26 (+6d) |  |  |  | baseline start none → 2011-05-20; baseline finish none → 2011-05-21 |
| 372 | Concrete | 2011-05-21 → 2011-05-26 (+5d) | 2011-05-21 → 2011-05-27 (+6d) |  |  |  | baseline start none → 2011-05-21; baseline finish none → 2011-05-22 |
| 373 | De-shuttering | 2011-05-24 → 2011-05-29 (+5d) | 2011-05-24 → 2011-05-30 (+6d) |  |  |  | baseline start none → 2011-05-24; baseline finish none → 2011-05-25 |
| 374 | **Shear Wall** | 2011-05-13 → 2011-05-18 (+5d) | 2011-05-24 → 2011-05-30 (+6d) |  |  |  | baseline start none → 2011-05-13; baseline finish none → 2011-05-25 |
| 375 | **1st Lift** | 2011-05-13 → 2011-05-18 (+5d) | 2011-05-18 → 2011-05-24 (+6d) |  |  |  | baseline start none → 2011-05-13; baseline finish none → 2011-05-19 |
| 376 | Re-Bar Work | 2011-05-13 → 2011-05-18 (+5d) | 2011-05-13 → 2011-05-19 (+6d) |  |  |  | baseline start none → 2011-05-13; baseline finish none → 2011-05-14 |
| 377 | Form Work | 2011-05-14 → 2011-05-19 (+5d) | 2011-05-14 → 2011-05-20 (+6d) |  |  |  | baseline start none → 2011-05-14; baseline finish none → 2011-05-15 |
| 378 | Concrete | 2011-05-15 → 2011-05-20 (+5d) | 2011-05-15 → 2011-05-21 (+6d) |  |  |  | baseline start none → 2011-05-15; baseline finish none → 2011-05-16 |
| 379 | De-shuttering | 2011-05-18 → 2011-05-23 (+5d) | 2011-05-18 → 2011-05-24 (+6d) |  |  |  | baseline start none → 2011-05-18; baseline finish none → 2011-05-19 |
| 380 | **2nd Lift** | 2011-05-19 → 2011-05-24 (+5d) | 2011-05-24 → 2011-05-30 (+6d) |  |  |  | baseline start none → 2011-05-19; baseline finish none → 2011-05-25 |
| 381 | Re-Bar Work | 2011-05-19 → 2011-05-24 (+5d) | 2011-05-19 → 2011-05-25 (+6d) |  |  |  | baseline start none → 2011-05-19; baseline finish none → 2011-05-20 |
| 382 | Form Work | 2011-05-20 → 2011-05-25 (+5d) | 2011-05-20 → 2011-05-26 (+6d) |  |  |  | baseline start none → 2011-05-20; baseline finish none → 2011-05-21 |
| 383 | Concrete | 2011-05-21 → 2011-05-26 (+5d) | 2011-05-21 → 2011-05-27 (+6d) |  |  |  | baseline start none → 2011-05-21; baseline finish none → 2011-05-22 |
| 384 | De-shuttering | 2011-05-24 → 2011-05-29 (+5d) | 2011-05-24 → 2011-05-30 (+6d) |  |  |  | baseline start none → 2011-05-24; baseline finish none → 2011-05-25 |

| ID | Task | Start | Finish | Other |
| --- | --- | --- | --- | --- |
| 385 | **Stair - 1 & 2** | 2011-05-13 → 2011-05-18 (+5d) | 2011-05-19 → 2011-05-25 (+6d) | baseline start none → 2011-05-13; baseline finish none → 2011-05-20 |
| 386 | **1st Flight** | 2011-05-13 → 2011-05-18 (+5d) | 2011-05-16 → 2011-05-22 (+6d) | baseline start none → 2011-05-13; baseline finish none → 2011-05-17 |
| 387 | Brick Work | 2011-05-13 → 2011-05-18 (+5d) | 2011-05-13 → 2011-05-19 (+6d) | baseline start none → 2011-05-13; baseline finish none → 2011-05-14 |
| 388 | Form Work | 2011-05-14 → 2011-05-19 (+5d) | 2011-05-14 → 2011-05-20 (+6d) | baseline start none → 2011-05-14; baseline finish none → 2011-05-15 |
| 389 | Re-bar Work | 2011-05-15 → 2011-05-20 (+5d) | 2011-05-15 → 2011-05-21 (+6d) | baseline start none → 2011-05-15; baseline finish none → 2011-05-16 |
| 390 | Concrete | 2011-05-16 → 2011-05-21 (+5d) | 2011-05-16 → 2011-05-22 (+6d) | baseline start none → 2011-05-16; baseline finish none → 2011-05-17 |
| 391 | **2nd Flight** | 2011-05-17 → 2011-05-22 (+5d) | 2011-05-19 → 2011-05-25 (+6d) | baseline start none → 2011-05-17; baseline finish none → 2011-05-20 |
| 392 | Form Work | 2011-05-17 → 2011-05-22 (+5d) | 2011-05-17 → 2011-05-23 (+6d) | baseline start none → 2011-05-17; baseline finish none → 2011-05-18 |
| 393 | Re-bar | 2011-05-18 → 2011-05-23 (+5d) | 2011-05-18 → 2011-05-24 (+6d) | baseline start none → 2011-05-18; baseline finish none → 2011-05-19 |
| 394 | Concrete | 2011-05-19 → 2011-05-24 (+5d) | 2011-05-19 → 2011-05-25 (+6d) | baseline start none → 2011-05-19; baseline finish none → 2011-05-20 |
| 395 | **Roof Slab** | 2011-05-25 → 2011-05-30 (+5d) | 2011-06-06 → 2011-06-12 (+6d) | baseline start none → 2011-05-25; baseline finish none → 2011-06-07 |
| 396 | Form Work | 2011-05-25 → 2011-05-30 (+5d) | 2011-05-29 → 2011-06-04 (+6d) | baseline start none → 2011-05-25; baseline finish none → 2011-05-30 |
| 397 | Re-bar | 2011-05-30 → 2011-06-04 (+5d) | 2011-06-02 → 2011-06-08 (+6d) | baseline start none → 2011-05-30; baseline finish none → 2011-06-03 |
| 398 | MEP Work | 2011-06-03 → 2011-06-08 (+5d) | 2011-06-03 → 2011-06-09 (+6d) | baseline start none → 2011-06-03; baseline finish none → 2011-06-04 |
| 399 | Inspection | 2011-06-04 → 2011-06-09 (+5d) | 2011-06-04 → 2011-06-10 (+6d) | baseline start none → 2011-06-04; baseline finish none → 2011-06-05 |
| 400 | Concrete | 2011-06-05 → 2011-06-10 (+5d) | 2011-06-06 → 2011-06-12 (+6d) | baseline start none → 2011-06-05; baseline finish none → 2011-06-07 |
| 401 | **1ST FLOOR** | 2011-06-07 → 2011-06-12 (+5d) | 2011-07-01 → 2011-07-07 (+6d) | baseline start none → 2011-06-07; baseline finish none → 2011-07-02 |
| 402 | **Column** | 2011-06-07 → 2011-06-12 (+5d) | 2011-06-18 → 2011-06-24 (+6d) | baseline start none → 2011-06-07; baseline finish none → 2011-06-19 |
| 403 | **1ST Lift** | 2011-06-07 → 2011-06-12 (+5d) | 2011-06-12 → 2011-06-18 (+6d) | baseline start none → 2011-06-07; baseline finish none → 2011-06-13 |
| 404 | Re-Bar Work | 2011-06-07 → 2011-06-12 (+5d) | 2011-06-07 → 2011-06-13 (+6d) | baseline start none → 2011-06-07; baseline finish none → 2011-06-08 |
| 405 | Form Work | 2011-06-08 → 2011-06-13 (+5d) | 2011-06-08 → 2011-06-14 (+6d) | baseline start none → 2011-06-08; baseline finish none → 2011-06-09 |
| 406 | Concrete | 2011-06-09 → 2011-06-14 (+5d) | 2011-06-09 → 2011-06-15 (+6d) | baseline start none → 2011-06-09; baseline finish none → 2011-06-10 |
| 407 | De-shuttering | 2011-06-12 → 2011-06-17 (+5d) | 2011-06-12 → 2011-06-18 (+6d) | baseline start none → 2011-06-12; baseline finish none → 2011-06-13 |
| 408 | **2nd Lift** | 2011-06-13 → 2011-06-18 (+5d) | 2011-06-18 → 2011-06-24 (+6d) | baseline start none → 2011-06-13; baseline finish none → 2011-06-19 |
| 409 | Re-Bar Work | 2011-06-13 → 2011-06-18 (+5d) | 2011-06-13 → 2011-06-19 (+6d) | baseline start none → 2011-06-13; baseline finish none → 2011-06-14 |
| 410 | Form Work | 2011-06-14 → 2011-06-19 (+5d) | 2011-06-14 → 2011-06-20 (+6d) | baseline start none → 2011-06-14; baseline finish none → 2011-06-15 |
| 411 | Concrete | 2011-06-15 → 2011-06-20 (+5d) | 2011-06-15 → 2011-06-21 (+6d) | baseline start none → 2011-06-15; baseline finish none → 2011-06-16 |
| 412 | De-shuttering | 2011-06-18 → 2011-06-23 (+5d) | 2011-06-18 → 2011-06-24 (+6d) | baseline start none → 2011-06-18; baseline finish none → 2011-06-19 |
| 413 | **Shear Wall** | 2011-06-07 → 2011-06-12 (+5d) | 2011-06-18 → 2011-06-24 (+6d) | baseline start none → 2011-06-07; baseline finish none → 2011-06-19 |
| 414 | **1st Lift** | 2011-06-07 → 2011-06-12 (+5d) | 2011-06-12 → 2011-06-18 (+6d) | baseline start none → 2011-06-07; baseline finish none → 2011-06-13 |
| 415 | Re-Bar Work | 2011-06-07 → 2011-06-12 (+5d) | 2011-06-07 → 2011-06-13 (+6d) | baseline start none → 2011-06-07; baseline finish none → 2011-06-08 |
| 416 | Form Work | 2011-06-08 → 2011-06-13 (+5d) | 2011-06-08 → 2011-06-14 (+6d) | baseline start none → 2011-06-08; baseline finish none → 2011-06-09 |
| 417 | Concrete | 2011-06-09 → 2011-06-14 (+5d) | 2011-06-09 → 2011-06-15 (+6d) | baseline start none → 2011-06-09; baseline finish none → 2011-06-10 |
| 418 | De-shuttering | 2011-06-12 → 2011-06-17 (+5d) | 2011-06-12 → 2011-06-18 (+6d) | baseline start none → 2011-06-12; baseline finish none → 2011-06-13 |
| 419 | **2nd Lift** | 2011-06-13 → 2011-06-18 (+5d) | 2011-06-18 → 2011-06-24 (+6d) | baseline start none → 2011-06-13; baseline finish none → 2011-06-19 |
| 420 | Re-Bar Work | 2011-06-13 → 2011-06-18 (+5d) | 2011-06-13 → 2011-06-19 (+6d) | baseline start none → 2011-06-13; baseline finish none → 2011-06-14 |
| 421 | Form Work | 2011-06-14 → 2011-06-19 (+5d) | 2011-06-14 → 2011-06-20 (+6d) | baseline start none → 2011-06-14; baseline finish none → 2011-06-15 |
| 422 | Concrete | 2011-06-15 → 2011-06-20 (+5d) | 2011-06-15 → 2011-06-21 (+6d) | baseline start none → 2011-06-15; baseline finish none → 2011-06-16 |
| 423 | De-shuttering | 2011-06-18 → 2011-06-23 (+5d) | 2011-06-18 → 2011-06-24 (+6d) | baseline start none → 2011-06-18; baseline finish none → 2011-06-19 |
| 424 | **Stair - 1 & 2** | 2011-06-07 → 2011-06-12 (+5d) | 2011-06-13 → 2011-06-19 (+6d) | baseline start none → 2011-06-07; baseline finish none → 2011-06-14 |
| 425 | **1st Flight** | 2011-06-07 → 2011-06-12 (+5d) | 2011-06-10 → 2011-06-16 (+6d) | baseline start none → 2011-06-07; baseline finish none → 2011-06-11 |
| 426 | Brick Work | 2011-06-07 → 2011-06-12 (+5d) | 2011-06-07 → 2011-06-13 (+6d) | baseline start none → 2011-06-07; baseline finish none → 2011-06-08 |
| 427 | Form Work | 2011-06-08 → 2011-06-13 (+5d) | 2011-06-08 → 2011-06-14 (+6d) | baseline start none → 2011-06-08; baseline finish none → 2011-06-09 |
| 428 | Re-bar Work | 2011-06-09 → 2011-06-14 (+5d) | 2011-06-09 → 2011-06-15 (+6d) | baseline start none → 2011-06-09; baseline finish none → 2011-06-10 |
| 429 | Concrete | 2011-06-10 → 2011-06-15 (+5d) | 2011-06-10 → 2011-06-16 (+6d) | baseline start none → 2011-06-10; baseline finish none → 2011-06-11 |
| 430 | **2nd Flight** | 2011-06-11 → 2011-06-16 (+5d) | 2011-06-13 → 2011-06-19 (+6d) | baseline start none → 2011-06-11; baseline finish none → 2011-06-14 |
| 431 | Form Work | 2011-06-11 → 2011-06-16 (+5d) | 2011-06-11 → 2011-06-17 (+6d) | baseline start none → 2011-06-11; baseline finish none → 2011-06-12 |
| 432 | Re-bar | 2011-06-12 → 2011-06-17 (+5d) | 2011-06-12 → 2011-06-18 (+6d) | baseline start none → 2011-06-12; baseline finish none → 2011-06-13 |
| 433 | Concrete | 2011-06-13 → 2011-06-18 (+5d) | 2011-06-13 → 2011-06-19 (+6d) | baseline start none → 2011-06-13; baseline finish none → 2011-06-14 |
| 434 | **Roof Slab** | 2011-06-19 → 2011-06-24 (+5d) | 2011-07-01 → 2011-07-07 (+6d) | baseline start none → 2011-06-19; baseline finish none → 2011-07-02 |
| 435 | Form Work | 2011-06-19 → 2011-06-24 (+5d) | 2011-06-23 → 2011-06-29 (+6d) | baseline start none → 2011-06-19; baseline finish none → 2011-06-24 |
| 436 | Re-bar | 2011-06-24 → 2011-06-29 (+5d) | 2011-06-27 → 2011-07-03 (+6d) | baseline start none → 2011-06-24; baseline finish none → 2011-06-28 |
| 437 | MEP Work | 2011-06-28 → 2011-07-03 (+5d) | 2011-06-28 → 2011-07-04 (+6d) | baseline start none → 2011-06-28; baseline finish none → 2011-06-29 |
| 438 | Inspection | 2011-06-29 → 2011-07-04 (+5d) | 2011-06-29 → 2011-07-05 (+6d) | baseline start none → 2011-06-29; baseline finish none → 2011-06-30 |
| 439 | Concrete | 2011-06-30 → 2011-07-05 (+5d) | 2011-07-01 → 2011-07-07 (+6d) | baseline start none → 2011-06-30; baseline finish none → 2011-07-02 |
| 440 | **2ND FLOOR** | 2011-07-02 → 2011-07-07 (+5d) | 2011-07-26 → 2011-08-01 (+6d) | baseline start none → 2011-07-02; baseline finish none → 2011-07-27 |
| 441 | **Column** | 2011-07-02 → 2011-07-07 (+5d) | 2011-07-13 → 2011-07-19 (+6d) | baseline start none → 2011-07-02; baseline finish none → 2011-07-14 |
| 442 | **1ST Lift** | 2011-07-02 → 2011-07-07 (+5d) | 2011-07-07 → 2011-07-13 (+6d) | baseline start none → 2011-07-02; baseline finish none → 2011-07-08 |
| 443 | Re-Bar Work | 2011-07-02 → 2011-07-07 (+5d) | 2011-07-02 → 2011-07-08 (+6d) | baseline start none → 2011-07-02; baseline finish none → 2011-07-03 |
| 444 | Form Work | 2011-07-03 → 2011-07-08 (+5d) | 2011-07-03 → 2011-07-09 (+6d) | baseline start none → 2011-07-03; baseline finish none → 2011-07-04 |
| 445 | Concrete | 2011-07-04 → 2011-07-09 (+5d) | 2011-07-04 → 2011-07-10 (+6d) | baseline start none → 2011-07-04; baseline finish none → 2011-07-05 |
| 446 | De-shuttering | 2011-07-07 → 2011-07-12 (+5d) | 2011-07-07 → 2011-07-13 (+6d) | baseline start none → 2011-07-07; baseline finish none → 2011-07-08 |
| 447 | **2nd Lift** | 2011-07-08 → 2011-07-13 (+5d) | 2011-07-13 → 2011-07-19 (+6d) | baseline start none → 2011-07-08; baseline finish none → 2011-07-14 |
| 448 | Re-Bar Work | 2011-07-08 → 2011-07-13 (+5d) | 2011-07-08 → 2011-07-14 (+6d) | baseline start none → 2011-07-08; baseline finish none → 2011-07-09 |
| 449 | Form Work | 2011-07-09 → 2011-07-14 (+5d) | 2011-07-09 → 2011-07-15 (+6d) | baseline start none → 2011-07-09; baseline finish none → 2011-07-10 |
| 450 | Concrete | 2011-07-10 → 2011-07-15 (+5d) | 2011-07-10 → 2011-07-16 (+6d) | baseline start none → 2011-07-10; baseline finish none → 2011-07-11 |
| 451 | De-shuttering | 2011-07-13 → 2011-07-18 (+5d) | 2011-07-13 → 2011-07-19 (+6d) | baseline start none → 2011-07-13; baseline finish none → 2011-07-14 |
| 452 | **Shear Wall** | 2011-07-02 → 2011-07-07 (+5d) | 2011-07-13 → 2011-07-19 (+6d) | baseline start none → 2011-07-02; baseline finish none → 2011-07-14 |
| 453 | **1st Lift** | 2011-07-02 → 2011-07-07 (+5d) | 2011-07-07 → 2011-07-13 (+6d) | baseline start none → 2011-07-02; baseline finish none → 2011-07-08 |
| 454 | Re-Bar Work | 2011-07-02 → 2011-07-07 (+5d) | 2011-07-02 → 2011-07-08 (+6d) | baseline start none → 2011-07-02; baseline finish none → 2011-07-03 |

| ID | Task | Start | Finish | Other |
| --- | --- | --- | --- | --- |
| 455 | Form Work | 2011-07-03 → 2011-07-08 (+5d) | 2011-07-03 → 2011-07-09 (+6d) | baseline start none → 2011-07-03; baseline finish none → 2011-07-04 |
| 456 | Concrete | 2011-07-04 → 2011-07-09 (+5d) | 2011-07-04 → 2011-07-10 (+6d) | baseline start none → 2011-07-04; baseline finish none → 2011-07-05 |
| 457 | De-shuttering | 2011-07-07 → 2011-07-12 (+5d) | 2011-07-07 → 2011-07-13 (+6d) | baseline start none → 2011-07-07; baseline finish none → 2011-07-08 |
| 458 | **2nd Lift** | 2011-07-08 → 2011-07-13 (+5d) | 2011-07-13 → 2011-07-19 (+6d) | baseline start none → 2011-07-08; baseline finish none → 2011-07-14 |
| 459 | Re-Bar Work | 2011-07-08 → 2011-07-13 (+5d) | 2011-07-08 → 2011-07-14 (+6d) | baseline start none → 2011-07-08; baseline finish none → 2011-07-09 |
| 460 | Form Work | 2011-07-09 → 2011-07-14 (+5d) | 2011-07-09 → 2011-07-15 (+6d) | baseline start none → 2011-07-09; baseline finish none → 2011-07-10 |
| 461 | Concrete | 2011-07-10 → 2011-07-15 (+5d) | 2011-07-10 → 2011-07-16 (+6d) | baseline start none → 2011-07-10; baseline finish none → 2011-07-11 |
| 462 | De-shuttering | 2011-07-13 → 2011-07-18 (+5d) | 2011-07-13 → 2011-07-19 (+6d) | baseline start none → 2011-07-13; baseline finish none → 2011-07-14 |
| 463 | **Stair - 1 & 2** | 2011-07-02 → 2011-07-07 (+5d) | 2011-07-08 → 2011-07-14 (+6d) | baseline start none → 2011-07-02; baseline finish none → 2011-07-09 |
| 464 | **1st Flight** | 2011-07-02 → 2011-07-07 (+5d) | 2011-07-05 → 2011-07-11 (+6d) | baseline start none → 2011-07-02; baseline finish none → 2011-07-06 |
| 465 | Brick Work | 2011-07-02 → 2011-07-07 (+5d) | 2011-07-02 → 2011-07-08 (+6d) | baseline start none → 2011-07-02; baseline finish none → 2011-07-03 |
| 466 | Form Work | 2011-07-03 → 2011-07-08 (+5d) | 2011-07-03 → 2011-07-09 (+6d) | baseline start none → 2011-07-03; baseline finish none → 2011-07-04 |
| 467 | Re-bar Work | 2011-07-04 → 2011-07-09 (+5d) | 2011-07-04 → 2011-07-10 (+6d) | baseline start none → 2011-07-04; baseline finish none → 2011-07-05 |
| 468 | Concrete | 2011-07-05 → 2011-07-10 (+5d) | 2011-07-05 → 2011-07-11 (+6d) | baseline start none → 2011-07-05; baseline finish none → 2011-07-06 |
| 469 | **2nd Flight** | 2011-07-06 → 2011-07-11 (+5d) | 2011-07-08 → 2011-07-14 (+6d) | baseline start none → 2011-07-06; baseline finish none → 2011-07-09 |
| 470 | Form Work | 2011-07-06 → 2011-07-11 (+5d) | 2011-07-06 → 2011-07-12 (+6d) | baseline start none → 2011-07-06; baseline finish none → 2011-07-07 |
| 471 | Re-bar | 2011-07-07 → 2011-07-12 (+5d) | 2011-07-07 → 2011-07-13 (+6d) | baseline start none → 2011-07-07; baseline finish none → 2011-07-08 |
| 472 | Concrete | 2011-07-08 → 2011-07-13 (+5d) | 2011-07-08 → 2011-07-14 (+6d) | baseline start none → 2011-07-08; baseline finish none → 2011-07-09 |
| 473 | **Roof Slab** | 2011-07-14 → 2011-07-19 (+5d) | 2011-07-26 → 2011-08-01 (+6d) | baseline start none → 2011-07-14; baseline finish none → 2011-07-27 |
| 474 | Form Work | 2011-07-14 → 2011-07-19 (+5d) | 2011-07-18 → 2011-07-24 (+6d) | baseline start none → 2011-07-14; baseline finish none → 2011-07-19 |
| 475 | Re-bar | 2011-07-19 → 2011-07-24 (+5d) | 2011-07-22 → 2011-07-28 (+6d) | baseline start none → 2011-07-19; baseline finish none → 2011-07-23 |
| 476 | MEP Work | 2011-07-23 → 2011-07-28 (+5d) | 2011-07-23 → 2011-07-29 (+6d) | baseline start none → 2011-07-23; baseline finish none → 2011-07-24 |
| 477 | Inspection | 2011-07-24 → 2011-07-29 (+5d) | 2011-07-24 → 2011-07-30 (+6d) | baseline start none → 2011-07-24; baseline finish none → 2011-07-25 |
| 478 | Concrete | 2011-07-25 → 2011-07-30 (+5d) | 2011-07-26 → 2011-08-01 (+6d) | baseline start none → 2011-07-25; baseline finish none → 2011-07-27 |
| 479 | **3RD FLOOR** | 2011-07-27 → 2011-08-01 (+5d) | 2011-08-20 → 2011-09-03 (+14d) | baseline start none → 2011-07-27; baseline finish none → 2011-08-21 |
| 480 | **Column** | 2011-07-27 → 2011-08-01 (+5d) | 2011-08-07 → 2011-08-13 (+6d) | baseline start none → 2011-07-27; baseline finish none → 2011-08-08 |
| 481 | **1ST Lift** | 2011-07-27 → 2011-08-01 (+5d) | 2011-08-01 → 2011-08-07 (+6d) | baseline start none → 2011-07-27; baseline finish none → 2011-08-02 |
| 482 | Re-Bar Work | 2011-07-27 → 2011-08-01 (+5d) | 2011-07-27 → 2011-08-02 (+6d) | baseline start none → 2011-07-27; baseline finish none → 2011-07-28 |
| 483 | Form Work | 2011-07-28 → 2011-08-02 (+5d) | 2011-07-28 → 2011-08-03 (+6d) | baseline start none → 2011-07-28; baseline finish none → 2011-07-29 |
| 484 | Concrete | 2011-07-29 → 2011-08-03 (+5d) | 2011-07-29 → 2011-08-04 (+6d) | baseline start none → 2011-07-29; baseline finish none → 2011-07-30 |
| 485 | De-shuttering | 2011-08-01 → 2011-08-06 (+5d) | 2011-08-01 → 2011-08-07 (+6d) | baseline start none → 2011-08-01; baseline finish none → 2011-08-02 |
| 486 | **2nd Lift** | 2011-08-02 → 2011-08-07 (+5d) | 2011-08-07 → 2011-08-13 (+6d) | baseline start none → 2011-08-02; baseline finish none → 2011-08-08 |
| 487 | Re-Bar Work | 2011-08-02 → 2011-08-07 (+5d) | 2011-08-02 → 2011-08-08 (+6d) | baseline start none → 2011-08-02; baseline finish none → 2011-08-03 |
| 488 | Form Work | 2011-08-03 → 2011-08-08 (+5d) | 2011-08-03 → 2011-08-09 (+6d) | baseline start none → 2011-08-03; baseline finish none → 2011-08-04 |
| 489 | Concrete | 2011-08-04 → 2011-08-09 (+5d) | 2011-08-04 → 2011-08-10 (+6d) | baseline start none → 2011-08-04; baseline finish none → 2011-08-05 |
| 490 | De-shuttering | 2011-08-07 → 2011-08-12 (+5d) | 2011-08-07 → 2011-08-13 (+6d) | baseline start none → 2011-08-07; baseline finish none → 2011-08-08 |
| 491 | **Shear Wall** | 2011-07-27 → 2011-08-01 (+5d) | 2011-08-07 → 2011-08-13 (+6d) | baseline start none → 2011-07-27; baseline finish none → 2011-08-08 |
| 492 | **1st Lift** | 2011-07-27 → 2011-08-01 (+5d) | 2011-08-01 → 2011-08-07 (+6d) | baseline start none → 2011-07-27; baseline finish none → 2011-08-02 |
| 493 | Re-Bar Work | 2011-07-27 → 2011-08-01 (+5d) | 2011-07-27 → 2011-08-02 (+6d) | baseline start none → 2011-07-27; baseline finish none → 2011-07-28 |
| 494 | Form Work | 2011-07-28 → 2011-08-02 (+5d) | 2011-07-28 → 2011-08-03 (+6d) | baseline start none → 2011-07-28; baseline finish none → 2011-07-29 |
| 495 | Concrete | 2011-07-29 → 2011-08-03 (+5d) | 2011-07-29 → 2011-08-04 (+6d) | baseline start none → 2011-07-29; baseline finish none → 2011-07-30 |
| 496 | De-shuttering | 2011-08-01 → 2011-08-06 (+5d) | 2011-08-01 → 2011-08-07 (+6d) | baseline start none → 2011-08-01; baseline finish none → 2011-08-02 |
| 497 | **2nd Lift** | 2011-08-02 → 2011-08-07 (+5d) | 2011-08-07 → 2011-08-13 (+6d) | baseline start none → 2011-08-02; baseline finish none → 2011-08-08 |
| 498 | Re-Bar Work | 2011-08-02 → 2011-08-07 (+5d) | 2011-08-02 → 2011-08-08 (+6d) | baseline start none → 2011-08-02; baseline finish none → 2011-08-03 |
| 499 | Form Work | 2011-08-03 → 2011-08-08 (+5d) | 2011-08-03 → 2011-08-09 (+6d) | baseline start none → 2011-08-03; baseline finish none → 2011-08-04 |
| 500 | Concrete | 2011-08-04 → 2011-08-09 (+5d) | 2011-08-04 → 2011-08-10 (+6d) | baseline start none → 2011-08-04; baseline finish none → 2011-08-05 |
| 501 | De-shuttering | 2011-08-07 → 2011-08-12 (+5d) | 2011-08-07 → 2011-08-13 (+6d) | baseline start none → 2011-08-07; baseline finish none → 2011-08-08 |
| 502 | **Stair - 1 & 2** | 2011-07-27 → 2011-08-01 (+5d) | 2011-08-02 → 2011-08-08 (+6d) | baseline start none → 2011-07-27; baseline finish none → 2011-08-03 |
| 503 | **1st Flight** | 2011-07-27 → 2011-08-01 (+5d) | 2011-07-30 → 2011-08-05 (+6d) | baseline start none → 2011-07-27; baseline finish none → 2011-07-31 |
| 504 | Brick Work | 2011-07-27 → 2011-08-01 (+5d) | 2011-07-27 → 2011-08-02 (+6d) | baseline start none → 2011-07-27; baseline finish none → 2011-07-28 |
| 505 | Form Work | 2011-07-28 → 2011-08-02 (+5d) | 2011-07-28 → 2011-08-03 (+6d) | baseline start none → 2011-07-28; baseline finish none → 2011-07-29 |
| 506 | Re-bar Work | 2011-07-29 → 2011-08-03 (+5d) | 2011-07-29 → 2011-08-04 (+6d) | baseline start none → 2011-07-29; baseline finish none → 2011-07-30 |
| 507 | Concrete | 2011-07-30 → 2011-08-04 (+5d) | 2011-07-30 → 2011-08-05 (+6d) | baseline start none → 2011-07-30; baseline finish none → 2011-07-31 |
| 508 | **2nd Flight** | 2011-07-31 → 2011-08-05 (+5d) | 2011-08-02 → 2011-08-08 (+6d) | baseline start none → 2011-07-31; baseline finish none → 2011-08-03 |
| 509 | Form Work | 2011-07-31 → 2011-08-05 (+5d) | 2011-07-31 → 2011-08-06 (+6d) | baseline start none → 2011-07-31; baseline finish none → 2011-08-01 |
| 510 | Re-bar | 2011-08-01 → 2011-08-06 (+5d) | 2011-08-01 → 2011-08-07 (+6d) | baseline start none → 2011-08-01; baseline finish none → 2011-08-02 |
| 511 | Concrete | 2011-08-02 → 2011-08-07 (+5d) | 2011-08-02 → 2011-08-08 (+6d) | baseline start none → 2011-08-02; baseline finish none → 2011-08-03 |
| 512 | **Roof Slab** | 2011-08-08 → 2011-08-13 (+5d) | 2011-08-20 → 2011-09-03 (+14d) | baseline start none → 2011-08-08; baseline finish none → 2011-08-21 |
| 513 | Form Work | 2011-08-08 → 2011-08-13 (+5d) | 2011-08-12 → 2011-08-18 (+6d) | baseline start none → 2011-08-08; baseline finish none → 2011-08-13 |
| 514 | Re-bar | 2011-08-13 → 2011-08-18 (+5d) | 2011-08-16 → 2011-08-22 (+6d) | baseline start none → 2011-08-13; baseline finish none → 2011-08-17 |
| 515 | MEP Work | 2011-08-17 → 2011-08-22 (+5d) | 2011-08-17 → 2011-08-23 (+6d) | baseline start none → 2011-08-17; baseline finish none → 2011-08-18 |
| 516 | Inspection | 2011-08-18 → 2011-08-23 (+5d) | 2011-08-18 → 2011-08-24 (+6d) | baseline start none → 2011-08-18; baseline finish none → 2011-08-19 |
| 517 | Concrete | 2011-08-19 → 2011-08-24 (+5d) | 2011-08-20 → 2011-09-03 (+14d) | baseline start none → 2011-08-19; baseline finish none → 2011-08-21 |
| 518 | **4TH FLOOR** | 2011-08-21 → 2011-09-03 (+13d) | 2011-09-22 → 2011-09-28 (+6d) | baseline start none → 2011-08-21; baseline finish none → 2011-09-23 |
| 519 | **Column** | 2011-08-21 → 2011-09-03 (+13d) | 2011-09-09 → 2011-09-15 (+6d) | baseline start none → 2011-08-21; baseline finish none → 2011-09-10 |
| 520 | **1ST Lift** | 2011-08-21 → 2011-09-03 (+13d) | 2011-09-03 → 2011-09-09 (+6d) | baseline start none → 2011-08-21; baseline finish none → 2011-09-04 |
| 521 | Re-Bar Work | 2011-08-21 → 2011-09-03 (+13d) | 2011-08-21 → 2011-09-04 (+14d) | baseline start none → 2011-08-21; baseline finish none → 2011-08-22 |
| 522 | Form Work | 2011-08-22 → 2011-09-04 (+13d) | 2011-08-22 → 2011-09-05 (+14d) | baseline start none → 2011-08-22; baseline finish none → 2011-08-23 |
| 523 | Concrete | 2011-08-23 → 2011-09-05 (+13d) | 2011-08-23 → 2011-09-06 (+14d) | baseline start none → 2011-08-23; baseline finish none → 2011-08-24 |
| 524 | De-shuttering | 2011-09-03 → 2011-09-08 (+5d) | 2011-09-03 → 2011-09-09 (+6d) | baseline start none → 2011-09-03; baseline finish none → 2011-09-04 |

| ID | Task | Start | Finish | Other |
| --- | --- | --- | --- | --- |
| 525 | **2nd Lift** | 2011-09-04 → 2011-09-09 (+5d) | 2011-09-09 → 2011-09-15 (+6d) | baseline start none → 2011-09-04; baseline finish none → 2011-09-10 |
| 526 | Re-Bar Work | 2011-09-04 → 2011-09-09 (+5d) | 2011-09-04 → 2011-09-10 (+6d) | baseline start none → 2011-09-04; baseline finish none → 2011-09-05 |
| 527 | Form Work | 2011-09-05 → 2011-09-10 (+5d) | 2011-09-05 → 2011-09-11 (+6d) | baseline start none → 2011-09-05; baseline finish none → 2011-09-06 |
| 528 | Concrete | 2011-09-06 → 2011-09-11 (+5d) | 2011-09-06 → 2011-09-12 (+6d) | baseline start none → 2011-09-06; baseline finish none → 2011-09-07 |
| 529 | De-shuttering | 2011-09-09 → 2011-09-14 (+5d) | 2011-09-09 → 2011-09-15 (+6d) | baseline start none → 2011-09-09; baseline finish none → 2011-09-10 |
| 530 | **Shear Wall** | 2011-08-21 → 2011-09-03 (+13d) | 2011-09-09 → 2011-09-15 (+6d) | baseline start none → 2011-08-21; baseline finish none → 2011-09-10 |
| 531 | **1st Lift** | 2011-08-21 → 2011-09-03 (+13d) | 2011-09-03 → 2011-09-09 (+6d) | baseline start none → 2011-08-21; baseline finish none → 2011-09-04 |
| 532 | Re-Bar Work | 2011-08-21 → 2011-09-03 (+13d) | 2011-08-21 → 2011-09-04 (+14d) | baseline start none → 2011-08-21; baseline finish none → 2011-08-22 |
| 533 | Form Work | 2011-08-22 → 2011-09-04 (+13d) | 2011-08-22 → 2011-09-05 (+14d) | baseline start none → 2011-08-22; baseline finish none → 2011-08-23 |
| 534 | Concrete | 2011-08-23 → 2011-09-05 (+13d) | 2011-08-23 → 2011-09-06 (+14d) | baseline start none → 2011-08-23; baseline finish none → 2011-08-24 |
| 535 | De-shuttering | 2011-09-03 → 2011-09-08 (+5d) | 2011-09-03 → 2011-09-09 (+6d) | baseline start none → 2011-09-03; baseline finish none → 2011-09-04 |
| 536 | **2nd Lift** | 2011-09-04 → 2011-09-09 (+5d) | 2011-09-09 → 2011-09-15 (+6d) | baseline start none → 2011-09-04; baseline finish none → 2011-09-10 |
| 537 | Re-Bar Work | 2011-09-04 → 2011-09-09 (+5d) | 2011-09-04 → 2011-09-10 (+6d) | baseline start none → 2011-09-04; baseline finish none → 2011-09-05 |
| 538 | Form Work | 2011-09-05 → 2011-09-10 (+5d) | 2011-09-05 → 2011-09-11 (+6d) | baseline start none → 2011-09-05; baseline finish none → 2011-09-06 |
| 539 | Concrete | 2011-09-06 → 2011-09-11 (+5d) | 2011-09-06 → 2011-09-12 (+6d) | baseline start none → 2011-09-06; baseline finish none → 2011-09-07 |
| 540 | De-shuttering | 2011-09-09 → 2011-09-14 (+5d) | 2011-09-09 → 2011-09-15 (+6d) | baseline start none → 2011-09-09; baseline finish none → 2011-09-10 |
| 541 | **Stair - 1 & 2** | 2011-08-21 → 2011-09-03 (+13d) | 2011-09-04 → 2011-09-10 (+6d) | baseline start none → 2011-08-21; baseline finish none → 2011-09-05 |
| 542 | **1st Flight** | 2011-08-21 → 2011-09-03 (+13d) | 2011-08-24 → 2011-09-07 (+14d) | baseline start none → 2011-08-21; baseline finish none → 2011-08-25 |
| 543 | Brick Work | 2011-08-21 → 2011-09-03 (+13d) | 2011-08-21 → 2011-09-04 (+14d) | baseline start none → 2011-08-21; baseline finish none → 2011-08-22 |
| 544 | Form Work | 2011-08-22 → 2011-09-04 (+13d) | 2011-08-22 → 2011-09-05 (+14d) | baseline start none → 2011-08-22; baseline finish none → 2011-08-23 |
| 545 | Re-bar Work | 2011-08-23 → 2011-09-05 (+13d) | 2011-08-23 → 2011-09-06 (+14d) | baseline start none → 2011-08-23; baseline finish none → 2011-08-24 |
| 546 | Concrete | 2011-08-24 → 2011-09-06 (+13d) | 2011-08-24 → 2011-09-07 (+14d) | baseline start none → 2011-08-24; baseline finish none → 2011-08-25 |
| 547 | **2nd Flight** | 2011-08-25 → 2011-09-07 (+13d) | 2011-09-04 → 2011-09-10 (+6d) | baseline start none → 2011-08-25; baseline finish none → 2011-09-05 |
| 548 | Form Work | 2011-08-25 → 2011-09-07 (+13d) | 2011-08-25 → 2011-09-08 (+14d) | baseline start none → 2011-08-25; baseline finish none → 2011-09-03 |
| 549 | Re-bar | 2011-09-03 → 2011-09-08 (+5d) | 2011-09-03 → 2011-09-09 (+6d) | baseline start none → 2011-09-03; baseline finish none → 2011-09-04 |
| 550 | Concrete | 2011-09-04 → 2011-09-09 (+5d) | 2011-09-04 → 2011-09-10 (+6d) | baseline start none → 2011-09-04; baseline finish none → 2011-09-05 |
| 551 | **Roof Slab** | 2011-09-10 → 2011-09-15 (+5d) | 2011-09-22 → 2011-09-28 (+6d) | baseline start none → 2011-09-10; baseline finish none → 2011-09-23 |
| 552 | Form Work | 2011-09-10 → 2011-09-15 (+5d) | 2011-09-14 → 2011-09-20 (+6d) | baseline start none → 2011-09-10; baseline finish none → 2011-09-15 |
| 553 | Re-bar | 2011-09-15 → 2011-09-20 (+5d) | 2011-09-18 → 2011-09-24 (+6d) | baseline start none → 2011-09-15; baseline finish none → 2011-09-19 |
| 554 | MEP Work | 2011-09-19 → 2011-09-24 (+5d) | 2011-09-19 → 2011-09-25 (+6d) | baseline start none → 2011-09-19; baseline finish none → 2011-09-20 |
| 555 | Inspection | 2011-09-20 → 2011-09-25 (+5d) | 2011-09-20 → 2011-09-26 (+6d) | baseline start none → 2011-09-20; baseline finish none → 2011-09-21 |
| 556 | Concrete | 2011-09-21 → 2011-09-26 (+5d) | 2011-09-22 → 2011-09-28 (+6d) | baseline start none → 2011-09-21; baseline finish none → 2011-09-23 |
| 557 | **5TH FLOOR** | 2011-09-23 → 2011-09-28 (+5d) | 2011-10-17 → 2011-10-23 (+6d) | baseline start none → 2011-09-23; baseline finish none → 2011-10-18 |
| 558 | **Column** | 2011-09-23 → 2011-09-28 (+5d) | 2011-10-04 → 2011-10-10 (+6d) | baseline start none → 2011-09-23; baseline finish none → 2011-10-05 |
| 559 | **1ST Lift** | 2011-09-23 → 2011-09-28 (+5d) | 2011-09-28 → 2011-10-04 (+6d) | baseline start none → 2011-09-23; baseline finish none → 2011-09-29 |
| 560 | Re-Bar Work | 2011-09-23 → 2011-09-28 (+5d) | 2011-09-23 → 2011-09-29 (+6d) | baseline start none → 2011-09-23; baseline finish none → 2011-09-24 |
| 561 | Form Work | 2011-09-24 → 2011-09-29 (+5d) | 2011-09-24 → 2011-09-30 (+6d) | baseline start none → 2011-09-24; baseline finish none → 2011-09-25 |
| 562 | Concrete | 2011-09-25 → 2011-09-30 (+5d) | 2011-09-25 → 2011-10-01 (+6d) | baseline start none → 2011-09-25; baseline finish none → 2011-09-26 |
| 563 | De-shuttering | 2011-09-28 → 2011-10-03 (+5d) | 2011-09-28 → 2011-10-04 (+6d) | baseline start none → 2011-09-28; baseline finish none → 2011-09-29 |
| 564 | **2nd Lift** | 2011-09-29 → 2011-10-04 (+5d) | 2011-10-04 → 2011-10-10 (+6d) | baseline start none → 2011-09-29; baseline finish none → 2011-10-05 |
| 565 | Re-Bar Work | 2011-09-29 → 2011-10-04 (+5d) | 2011-09-29 → 2011-10-05 (+6d) | baseline start none → 2011-09-29; baseline finish none → 2011-09-30 |
| 566 | Form Work | 2011-09-30 → 2011-10-05 (+5d) | 2011-09-30 → 2011-10-06 (+6d) | baseline start none → 2011-09-30; baseline finish none → 2011-10-01 |
| 567 | Concrete | 2011-10-01 → 2011-10-06 (+5d) | 2011-10-01 → 2011-10-07 (+6d) | baseline start none → 2011-10-01; baseline finish none → 2011-10-02 |
| 568 | De-shuttering | 2011-10-04 → 2011-10-09 (+5d) | 2011-10-04 → 2011-10-10 (+6d) | baseline start none → 2011-10-04; baseline finish none → 2011-10-05 |
| 569 | **Shear Wall** | 2011-09-23 → 2011-09-28 (+5d) | 2011-10-04 → 2011-10-10 (+6d) | baseline start none → 2011-09-23; baseline finish none → 2011-10-05 |
| 570 | **1st Lift** | 2011-09-23 → 2011-09-28 (+5d) | 2011-09-28 → 2011-10-04 (+6d) | baseline start none → 2011-09-23; baseline finish none → 2011-09-29 |
| 571 | Re-Bar Work | 2011-09-23 → 2011-09-28 (+5d) | 2011-09-23 → 2011-09-29 (+6d) | baseline start none → 2011-09-23; baseline finish none → 2011-09-24 |
| 572 | Form Work | 2011-09-24 → 2011-09-29 (+5d) | 2011-09-24 → 2011-09-30 (+6d) | baseline start none → 2011-09-24; baseline finish none → 2011-09-25 |
| 573 | Concrete | 2011-09-25 → 2011-09-30 (+5d) | 2011-09-25 → 2011-10-01 (+6d) | baseline start none → 2011-09-25; baseline finish none → 2011-09-26 |
| 574 | De-shuttering | 2011-09-28 → 2011-10-03 (+5d) | 2011-09-28 → 2011-10-04 (+6d) | baseline start none → 2011-09-28; baseline finish none → 2011-09-29 |
| 575 | **2nd Lift** | 2011-09-29 → 2011-10-04 (+5d) | 2011-10-04 → 2011-10-10 (+6d) | baseline start none → 2011-09-29; baseline finish none → 2011-10-05 |
| 576 | Re-Bar Work | 2011-09-29 → 2011-10-04 (+5d) | 2011-09-29 → 2011-10-05 (+6d) | baseline start none → 2011-09-29; baseline finish none → 2011-09-30 |
| 577 | Form Work | 2011-09-30 → 2011-10-05 (+5d) | 2011-09-30 → 2011-10-06 (+6d) | baseline start none → 2011-09-30; baseline finish none → 2011-10-01 |
| 578 | Concrete | 2011-10-01 → 2011-10-06 (+5d) | 2011-10-01 → 2011-10-07 (+6d) | baseline start none → 2011-10-01; baseline finish none → 2011-10-02 |
| 579 | De-shuttering | 2011-10-04 → 2011-10-09 (+5d) | 2011-10-04 → 2011-10-10 (+6d) | baseline start none → 2011-10-04; baseline finish none → 2011-10-05 |
| 580 | **Stair - 1 & 2** | 2011-09-23 → 2011-09-28 (+5d) | 2011-09-29 → 2011-10-05 (+6d) | baseline start none → 2011-09-23; baseline finish none → 2011-09-30 |
| 581 | **1st Flight** | 2011-09-23 → 2011-09-28 (+5d) | 2011-09-26 → 2011-10-02 (+6d) | baseline start none → 2011-09-23; baseline finish none → 2011-09-27 |
| 582 | Brick Work | 2011-09-23 → 2011-09-28 (+5d) | 2011-09-23 → 2011-09-29 (+6d) | baseline start none → 2011-09-23; baseline finish none → 2011-09-24 |
| 583 | Form Work | 2011-09-24 → 2011-09-29 (+5d) | 2011-09-24 → 2011-09-30 (+6d) | baseline start none → 2011-09-24; baseline finish none → 2011-09-25 |
| 584 | Re-bar Work | 2011-09-25 → 2011-09-30 (+5d) | 2011-09-25 → 2011-10-01 (+6d) | baseline start none → 2011-09-25; baseline finish none → 2011-09-26 |
| 585 | Concrete | 2011-09-26 → 2011-10-01 (+5d) | 2011-09-26 → 2011-10-02 (+6d) | baseline start none → 2011-09-26; baseline finish none → 2011-09-27 |
| 586 | **2nd Flight** | 2011-09-27 → 2011-10-02 (+5d) | 2011-09-29 → 2011-10-05 (+6d) | baseline start none → 2011-09-27; baseline finish none → 2011-09-30 |
| 587 | Form Work | 2011-09-27 → 2011-10-02 (+5d) | 2011-09-27 → 2011-10-03 (+6d) | baseline start none → 2011-09-27; baseline finish none → 2011-09-28 |
| 588 | Re-bar | 2011-09-28 → 2011-10-03 (+5d) | 2011-09-28 → 2011-10-04 (+6d) | baseline start none → 2011-09-28; baseline finish none → 2011-09-29 |
| 589 | Concrete | 2011-09-29 → 2011-10-04 (+5d) | 2011-09-29 → 2011-10-05 (+6d) | baseline start none → 2011-09-29; baseline finish none → 2011-09-30 |
| 590 | **Roof Slab** | 2011-10-05 → 2011-10-10 (+5d) | 2011-10-17 → 2011-10-23 (+6d) | baseline start none → 2011-10-05; baseline finish none → 2011-10-18 |
| 591 | Form Work | 2011-10-05 → 2011-10-10 (+5d) | 2011-10-09 → 2011-10-15 (+6d) | baseline start none → 2011-10-05; baseline finish none → 2011-10-10 |
| 592 | Re-bar | 2011-10-10 → 2011-10-15 (+5d) | 2011-10-13 → 2011-10-19 (+6d) | baseline start none → 2011-10-10; baseline finish none → 2011-10-14 |
| 593 | MEP Work | 2011-10-14 → 2011-10-19 (+5d) | 2011-10-14 → 2011-10-20 (+6d) | baseline start none → 2011-10-14; baseline finish none → 2011-10-15 |
| 594 | Inspection | 2011-10-15 → 2011-10-20 (+5d) | 2011-10-15 → 2011-10-21 (+6d) | baseline start none → 2011-10-15; baseline finish none → 2011-10-16 |

| ID | Task | Start | Finish | Other |
| --- | --- | --- | --- | --- |
| 595 | Concrete | 2011-10-16 → 2011-10-21 (+5d) | 2011-10-17 → 2011-10-23 (+6d) | baseline start none → 2011-10-16; baseline finish none → 2011-10-18 |
| 596 | **6TH FLOOR** | 2011-10-18 → 2011-10-23 (+5d) | 2011-11-19 → 2011-11-25 (+6d) | baseline start none → 2011-10-18; baseline finish none → 2011-11-20 |
| 597 | **Column** | 2011-10-18 → 2011-10-23 (+5d) | 2011-10-29 → 2011-11-04 (+6d) | baseline start none → 2011-10-18; baseline finish none → 2011-10-30 |
| 598 | **1ST Lift** | 2011-10-18 → 2011-10-23 (+5d) | 2011-10-23 → 2011-10-29 (+6d) | baseline start none → 2011-10-18; baseline finish none → 2011-10-24 |
| 599 | Re-Bar Work | 2011-10-18 → 2011-10-23 (+5d) | 2011-10-18 → 2011-10-24 (+6d) | baseline start none → 2011-10-18; baseline finish none → 2011-10-19 |
| 600 | Form Work | 2011-10-19 → 2011-10-24 (+5d) | 2011-10-19 → 2011-10-25 (+6d) | baseline start none → 2011-10-19; baseline finish none → 2011-10-20 |
| 601 | Concrete | 2011-10-20 → 2011-10-25 (+5d) | 2011-10-20 → 2011-10-26 (+6d) | baseline start none → 2011-10-20; baseline finish none → 2011-10-21 |
| 602 | De-shuttering | 2011-10-23 → 2011-10-28 (+5d) | 2011-10-23 → 2011-10-29 (+6d) | baseline start none → 2011-10-23; baseline finish none → 2011-10-24 |
| 603 | **2nd Lift** | 2011-10-24 → 2011-10-29 (+5d) | 2011-10-29 → 2011-11-04 (+6d) | baseline start none → 2011-10-24; baseline finish none → 2011-10-30 |
| 604 | Re-Bar Work | 2011-10-24 → 2011-10-29 (+5d) | 2011-10-24 → 2011-10-30 (+6d) | baseline start none → 2011-10-24; baseline finish none → 2011-10-25 |
| 605 | Form Work | 2011-10-25 → 2011-10-30 (+5d) | 2011-10-25 → 2011-10-31 (+6d) | baseline start none → 2011-10-25; baseline finish none → 2011-10-26 |
| 606 | Concrete | 2011-10-26 → 2011-10-31 (+5d) | 2011-10-26 → 2011-11-01 (+6d) | baseline start none → 2011-10-26; baseline finish none → 2011-10-27 |
| 607 | De-shuttering | 2011-10-29 → 2011-11-03 (+5d) | 2011-10-29 → 2011-11-04 (+6d) | baseline start none → 2011-10-29; baseline finish none → 2011-10-30 |
| 608 | **Shear Wall** | 2011-10-18 → 2011-10-23 (+5d) | 2011-10-29 → 2011-11-04 (+6d) | baseline start none → 2011-10-18; baseline finish none → 2011-10-30 |
| 609 | **1st Lift** | 2011-10-18 → 2011-10-23 (+5d) | 2011-10-23 → 2011-10-29 (+6d) | baseline start none → 2011-10-18; baseline finish none → 2011-10-24 |
| 610 | Re-Bar Work | 2011-10-18 → 2011-10-23 (+5d) | 2011-10-18 → 2011-10-24 (+6d) | baseline start none → 2011-10-18; baseline finish none → 2011-10-19 |
| 611 | Form Work | 2011-10-19 → 2011-10-24 (+5d) | 2011-10-19 → 2011-10-25 (+6d) | baseline start none → 2011-10-19; baseline finish none → 2011-10-20 |
| 612 | Concrete | 2011-10-20 → 2011-10-25 (+5d) | 2011-10-20 → 2011-10-26 (+6d) | baseline start none → 2011-10-20; baseline finish none → 2011-10-21 |
| 613 | De-shuttering | 2011-10-23 → 2011-10-28 (+5d) | 2011-10-23 → 2011-10-29 (+6d) | baseline start none → 2011-10-23; baseline finish none → 2011-10-24 |
| 614 | **2nd Lift** | 2011-10-24 → 2011-10-29 (+5d) | 2011-10-29 → 2011-11-04 (+6d) | baseline start none → 2011-10-24; baseline finish none → 2011-10-30 |
| 615 | Re-Bar Work | 2011-10-24 → 2011-10-29 (+5d) | 2011-10-24 → 2011-10-30 (+6d) | baseline start none → 2011-10-24; baseline finish none → 2011-10-25 |
| 616 | Form Work | 2011-10-25 → 2011-10-30 (+5d) | 2011-10-25 → 2011-10-31 (+6d) | baseline start none → 2011-10-25; baseline finish none → 2011-10-26 |
| 617 | Concrete | 2011-10-26 → 2011-10-31 (+5d) | 2011-10-26 → 2011-11-01 (+6d) | baseline start none → 2011-10-26; baseline finish none → 2011-10-27 |
| 618 | De-shuttering | 2011-10-29 → 2011-11-03 (+5d) | 2011-10-29 → 2011-11-04 (+6d) | baseline start none → 2011-10-29; baseline finish none → 2011-10-30 |
| 619 | **Stair - 1 & 2** | 2011-10-18 → 2011-10-23 (+5d) | 2011-10-24 → 2011-10-30 (+6d) | baseline start none → 2011-10-18; baseline finish none → 2011-10-25 |
| 620 | **1st Flight** | 2011-10-18 → 2011-10-23 (+5d) | 2011-10-21 → 2011-10-27 (+6d) | baseline start none → 2011-10-18; baseline finish none → 2011-10-22 |
| 621 | Brick Work | 2011-10-18 → 2011-10-23 (+5d) | 2011-10-18 → 2011-10-24 (+6d) | baseline start none → 2011-10-18; baseline finish none → 2011-10-19 |
| 622 | Form Work | 2011-10-19 → 2011-10-24 (+5d) | 2011-10-19 → 2011-10-25 (+6d) | baseline start none → 2011-10-19; baseline finish none → 2011-10-20 |
| 623 | Re-bar Work | 2011-10-20 → 2011-10-25 (+5d) | 2011-10-20 → 2011-10-26 (+6d) | baseline start none → 2011-10-20; baseline finish none → 2011-10-21 |
| 624 | Concrete | 2011-10-21 → 2011-10-26 (+5d) | 2011-10-21 → 2011-10-27 (+6d) | baseline start none → 2011-10-21; baseline finish none → 2011-10-22 |
| 625 | **2nd Flight** | 2011-10-22 → 2011-10-27 (+5d) | 2011-10-24 → 2011-10-30 (+6d) | baseline start none → 2011-10-22; baseline finish none → 2011-10-25 |
| 626 | Form Work | 2011-10-22 → 2011-10-27 (+5d) | 2011-10-22 → 2011-10-28 (+6d) | baseline start none → 2011-10-22; baseline finish none → 2011-10-23 |
| 627 | Re-bar | 2011-10-23 → 2011-10-28 (+5d) | 2011-10-23 → 2011-10-29 (+6d) | baseline start none → 2011-10-23; baseline finish none → 2011-10-24 |
| 628 | Concrete | 2011-10-24 → 2011-10-29 (+5d) | 2011-10-24 → 2011-10-30 (+6d) | baseline start none → 2011-10-24; baseline finish none → 2011-10-25 |
| 629 | **Roof Slab** | 2011-10-30 → 2011-11-04 (+5d) | 2011-11-19 → 2011-11-25 (+6d) | baseline start none → 2011-10-30; baseline finish none → 2011-11-20 |
| 630 | Form Work | 2011-10-30 → 2011-11-04 (+5d) | 2011-11-03 → 2011-11-09 (+6d) | baseline start none → 2011-10-30; baseline finish none → 2011-11-04 |
| 631 | Re-bar | 2011-11-04 → 2011-11-09 (+5d) | 2011-11-07 → 2011-11-21 (+14d) | baseline start none → 2011-11-04; baseline finish none → 2011-11-08 |
| 632 | MEP Work | 2011-11-08 → 2011-11-21 (+13d) | 2011-11-08 → 2011-11-22 (+14d) | baseline start none → 2011-11-08; baseline finish none → 2011-11-09 |
| 633 | Inspection | 2011-11-09 → 2011-11-22 (+13d) | 2011-11-09 → 2011-11-23 (+14d) | baseline start none → 2011-11-09; baseline finish none → 2011-11-10 |
| 634 | Concrete | 2011-11-10 → 2011-11-23 (+13d) | 2011-11-19 → 2011-11-25 (+6d) | baseline start none → 2011-11-10; baseline finish none → 2011-11-20 |
| 635 | **7TH FLOOR** | 2011-11-20 → 2011-11-25 (+5d) | 2011-12-14 → 2011-12-20 (+6d) | baseline start none → 2011-11-20; baseline finish none → 2011-12-15 |
| 636 | **Column** | 2011-11-20 → 2011-11-25 (+5d) | 2011-12-01 → 2011-12-07 (+6d) | baseline start none → 2011-11-20; baseline finish none → 2011-12-02 |
| 637 | **1ST Lift** | 2011-11-20 → 2011-11-25 (+5d) | 2011-11-25 → 2011-12-01 (+6d) | baseline start none → 2011-11-20; baseline finish none → 2011-11-26 |
| 638 | Re-Bar Work | 2011-11-20 → 2011-11-25 (+5d) | 2011-11-20 → 2011-11-26 (+6d) | baseline start none → 2011-11-20; baseline finish none → 2011-11-21 |
| 639 | Form Work | 2011-11-21 → 2011-11-26 (+5d) | 2011-11-21 → 2011-11-27 (+6d) | baseline start none → 2011-11-21; baseline finish none → 2011-11-22 |
| 640 | Concrete | 2011-11-22 → 2011-11-27 (+5d) | 2011-11-22 → 2011-11-28 (+6d) | baseline start none → 2011-11-22; baseline finish none → 2011-11-23 |
| 641 | De-shuttering | 2011-11-25 → 2011-11-30 (+5d) | 2011-11-25 → 2011-12-01 (+6d) | baseline start none → 2011-11-25; baseline finish none → 2011-11-26 |
| 642 | **2nd Lift** | 2011-11-26 → 2011-12-01 (+5d) | 2011-12-01 → 2011-12-07 (+6d) | baseline start none → 2011-11-26; baseline finish none → 2011-12-02 |
| 643 | Re-Bar Work | 2011-11-26 → 2011-12-01 (+5d) | 2011-11-26 → 2011-12-02 (+6d) | baseline start none → 2011-11-26; baseline finish none → 2011-11-27 |
| 644 | Form Work | 2011-11-27 → 2011-12-02 (+5d) | 2011-11-27 → 2011-12-03 (+6d) | baseline start none → 2011-11-27; baseline finish none → 2011-11-28 |
| 645 | Concrete | 2011-11-28 → 2011-12-03 (+5d) | 2011-11-28 → 2011-12-04 (+6d) | baseline start none → 2011-11-28; baseline finish none → 2011-11-29 |
| 646 | De-shuttering | 2011-12-01 → 2011-12-06 (+5d) | 2011-12-01 → 2011-12-07 (+6d) | baseline start none → 2011-12-01; baseline finish none → 2011-12-02 |
| 647 | **Shear Wall** | 2011-11-20 → 2011-11-25 (+5d) | 2011-12-01 → 2011-12-07 (+6d) | baseline start none → 2011-11-20; baseline finish none → 2011-12-02 |
| 648 | **1st Lift** | 2011-11-20 → 2011-11-25 (+5d) | 2011-11-25 → 2011-12-01 (+6d) | baseline start none → 2011-11-20; baseline finish none → 2011-11-26 |
| 649 | Re-Bar Work | 2011-11-20 → 2011-11-25 (+5d) | 2011-11-20 → 2011-11-26 (+6d) | baseline start none → 2011-11-20; baseline finish none → 2011-11-21 |
| 650 | Form Work | 2011-11-21 → 2011-11-26 (+5d) | 2011-11-21 → 2011-11-27 (+6d) | baseline start none → 2011-11-21; baseline finish none → 2011-11-22 |
| 651 | Concrete | 2011-11-22 → 2011-11-27 (+5d) | 2011-11-22 → 2011-11-28 (+6d) | baseline start none → 2011-11-22; baseline finish none → 2011-11-23 |
| 652 | De-shuttering | 2011-11-25 → 2011-11-30 (+5d) | 2011-11-25 → 2011-12-01 (+6d) | baseline start none → 2011-11-25; baseline finish none → 2011-11-26 |
| 653 | **2nd Lift** | 2011-11-26 → 2011-12-01 (+5d) | 2011-12-01 → 2011-12-07 (+6d) | baseline start none → 2011-11-26; baseline finish none → 2011-12-02 |
| 654 | Re-Bar Work | 2011-11-26 → 2011-12-01 (+5d) | 2011-11-26 → 2011-12-02 (+6d) | baseline start none → 2011-11-26; baseline finish none → 2011-11-27 |
| 655 | Form Work | 2011-11-27 → 2011-12-02 (+5d) | 2011-11-27 → 2011-12-03 (+6d) | baseline start none → 2011-11-27; baseline finish none → 2011-11-28 |
| 656 | Concrete | 2011-11-28 → 2011-12-03 (+5d) | 2011-11-28 → 2011-12-04 (+6d) | baseline start none → 2011-11-28; baseline finish none → 2011-11-29 |
| 657 | De-shuttering | 2011-12-01 → 2011-12-06 (+5d) | 2011-12-01 → 2011-12-07 (+6d) | baseline start none → 2011-12-01; baseline finish none → 2011-12-02 |
| 658 | **Stair - 1 & 2** | 2011-11-20 → 2011-11-25 (+5d) | 2011-11-26 → 2011-12-02 (+6d) | baseline start none → 2011-11-20; baseline finish none → 2011-11-27 |
| 659 | **1st Flight** | 2011-11-20 → 2011-11-25 (+5d) | 2011-11-23 → 2011-11-29 (+6d) | baseline start none → 2011-11-20; baseline finish none → 2011-11-24 |
| 660 | Brick Work | 2011-11-20 → 2011-11-25 (+5d) | 2011-11-20 → 2011-11-26 (+6d) | baseline start none → 2011-11-20; baseline finish none → 2011-11-21 |
| 661 | Form Work | 2011-11-21 → 2011-11-26 (+5d) | 2011-11-21 → 2011-11-27 (+6d) | baseline start none → 2011-11-21; baseline finish none → 2011-11-22 |
| 662 | Re-bar Work | 2011-11-22 → 2011-11-27 (+5d) | 2011-11-22 → 2011-11-28 (+6d) | baseline start none → 2011-11-22; baseline finish none → 2011-11-23 |
| 663 | Concrete | 2011-11-23 → 2011-11-28 (+5d) | 2011-11-23 → 2011-11-29 (+6d) | baseline start none → 2011-11-23; baseline finish none → 2011-11-24 |
| 664 | **2nd Flight** | 2011-11-24 → 2011-11-29 (+5d) | 2011-11-26 → 2011-12-02 (+6d) | baseline start none → 2011-11-24; baseline finish none → 2011-11-27 |

| ID | Task | Start | Finish | Other |
| --- | --- | --- | --- | --- |
| 665 | Form Work | 2011-11-24 → 2011-11-29 (+5d) | 2011-11-24 → 2011-11-30 (+6d) | baseline start none → 2011-11-24; baseline finish none → 2011-11-25 |
| 666 | Re-bar | 2011-11-25 → 2011-11-30 (+5d) | 2011-11-25 → 2011-12-01 (+6d) | baseline start none → 2011-11-25; baseline finish none → 2011-11-26 |
| 667 | Concrete | 2011-11-26 → 2011-12-01 (+5d) | 2011-11-26 → 2011-12-02 (+6d) | baseline start none → 2011-11-26; baseline finish none → 2011-11-27 |
| 668 | **Roof Slab** | 2011-12-02 → 2011-12-07 (+5d) | 2011-12-14 → 2011-12-20 (+6d) | baseline start none → 2011-12-02; baseline finish none → 2011-12-15 |
| 669 | Form Work | 2011-12-02 → 2011-12-07 (+5d) | 2011-12-06 → 2011-12-12 (+6d) | baseline start none → 2011-12-02; baseline finish none → 2011-12-07 |
| 670 | Re-bar | 2011-12-07 → 2011-12-12 (+5d) | 2011-12-10 → 2011-12-16 (+6d) | baseline start none → 2011-12-07; baseline finish none → 2011-12-11 |
| 671 | MEP Work | 2011-12-11 → 2011-12-16 (+5d) | 2011-12-11 → 2011-12-17 (+6d) | baseline start none → 2011-12-11; baseline finish none → 2011-12-12 |
| 672 | Inspection | 2011-12-12 → 2011-12-17 (+5d) | 2011-12-12 → 2011-12-18 (+6d) | baseline start none → 2011-12-12; baseline finish none → 2011-12-13 |
| 673 | Concrete | 2011-12-13 → 2011-12-18 (+5d) | 2011-12-14 → 2011-12-20 (+6d) | baseline start none → 2011-12-13; baseline finish none → 2011-12-15 |
| 674 | **8TH FLOOR** | 2011-12-15 → 2011-12-20 (+5d) | 2012-01-08 → 2012-01-14 (+6d) | baseline start none → 2011-12-15; baseline finish none → 2012-01-09 |
| 675 | **Column** | 2011-12-15 → 2011-12-20 (+5d) | 2011-12-26 → 2012-01-01 (+6d) | baseline start none → 2011-12-15; baseline finish none → 2011-12-27 |
| 676 | **1ST Lift** | 2011-12-15 → 2011-12-20 (+5d) | 2011-12-20 → 2011-12-26 (+6d) | baseline start none → 2011-12-15; baseline finish none → 2011-12-21 |
| 677 | Re-Bar Work | 2011-12-15 → 2011-12-20 (+5d) | 2011-12-15 → 2011-12-21 (+6d) | baseline start none → 2011-12-15; baseline finish none → 2011-12-16 |
| 678 | Form Work | 2011-12-16 → 2011-12-21 (+5d) | 2011-12-16 → 2011-12-22 (+6d) | baseline start none → 2011-12-16; baseline finish none → 2011-12-17 |
| 679 | Concrete | 2011-12-17 → 2011-12-22 (+5d) | 2011-12-17 → 2011-12-23 (+6d) | baseline start none → 2011-12-17; baseline finish none → 2011-12-18 |
| 680 | De-shuttering | 2011-12-20 → 2011-12-25 (+5d) | 2011-12-20 → 2011-12-26 (+6d) | baseline start none → 2011-12-20; baseline finish none → 2011-12-21 |
| 681 | **2nd Lift** | 2011-12-21 → 2011-12-26 (+5d) | 2011-12-26 → 2012-01-01 (+6d) | baseline start none → 2011-12-21; baseline finish none → 2011-12-27 |
| 682 | Re-Bar Work | 2011-12-21 → 2011-12-26 (+5d) | 2011-12-21 → 2011-12-27 (+6d) | baseline start none → 2011-12-21; baseline finish none → 2011-12-22 |
| 683 | Form Work | 2011-12-22 → 2011-12-27 (+5d) | 2011-12-22 → 2011-12-28 (+6d) | baseline start none → 2011-12-22; baseline finish none → 2011-12-23 |
| 684 | Concrete | 2011-12-23 → 2011-12-28 (+5d) | 2011-12-23 → 2011-12-29 (+6d) | baseline start none → 2011-12-23; baseline finish none → 2011-12-24 |
| 685 | De-shuttering | 2011-12-26 → 2011-12-31 (+5d) | 2011-12-26 → 2012-01-01 (+6d) | baseline start none → 2011-12-26; baseline finish none → 2011-12-27 |
| 686 | **Shear Wall** | 2011-12-15 → 2011-12-20 (+5d) | 2011-12-26 → 2012-01-01 (+6d) | baseline start none → 2011-12-15; baseline finish none → 2011-12-27 |
| 687 | **1st Lift** | 2011-12-15 → 2011-12-20 (+5d) | 2011-12-20 → 2011-12-26 (+6d) | baseline start none → 2011-12-15; baseline finish none → 2011-12-21 |
| 688 | Re-Bar Work | 2011-12-15 → 2011-12-20 (+5d) | 2011-12-15 → 2011-12-21 (+6d) | baseline start none → 2011-12-15; baseline finish none → 2011-12-16 |
| 689 | Form Work | 2011-12-16 → 2011-12-21 (+5d) | 2011-12-16 → 2011-12-22 (+6d) | baseline start none → 2011-12-16; baseline finish none → 2011-12-17 |
| 690 | Concrete | 2011-12-17 → 2011-12-22 (+5d) | 2011-12-17 → 2011-12-23 (+6d) | baseline start none → 2011-12-17; baseline finish none → 2011-12-18 |
| 691 | De-shuttering | 2011-12-20 → 2011-12-25 (+5d) | 2011-12-20 → 2011-12-26 (+6d) | baseline start none → 2011-12-20; baseline finish none → 2011-12-21 |
| 692 | **2nd Lift** | 2011-12-21 → 2011-12-26 (+5d) | 2011-12-26 → 2012-01-01 (+6d) | baseline start none → 2011-12-21; baseline finish none → 2011-12-27 |
| 693 | Re-Bar Work | 2011-12-21 → 2011-12-26 (+5d) | 2011-12-21 → 2011-12-27 (+6d) | baseline start none → 2011-12-21; baseline finish none → 2011-12-22 |
| 694 | Form Work | 2011-12-22 → 2011-12-27 (+5d) | 2011-12-22 → 2011-12-28 (+6d) | baseline start none → 2011-12-22; baseline finish none → 2011-12-23 |
| 695 | Concrete | 2011-12-23 → 2011-12-28 (+5d) | 2011-12-23 → 2011-12-29 (+6d) | baseline start none → 2011-12-23; baseline finish none → 2011-12-24 |
| 696 | De-shuttering | 2011-12-26 → 2011-12-31 (+5d) | 2011-12-26 → 2012-01-01 (+6d) | baseline start none → 2011-12-26; baseline finish none → 2011-12-27 |
| 697 | **Stair - 1 & 2** | 2011-12-15 → 2011-12-20 (+5d) | 2011-12-21 → 2011-12-27 (+6d) | baseline start none → 2011-12-15; baseline finish none → 2011-12-22 |
| 698 | **1st Flight** | 2011-12-15 → 2011-12-20 (+5d) | 2011-12-18 → 2011-12-24 (+6d) | baseline start none → 2011-12-15; baseline finish none → 2011-12-19 |
| 699 | Brick Work | 2011-12-15 → 2011-12-20 (+5d) | 2011-12-15 → 2011-12-21 (+6d) | baseline start none → 2011-12-15; baseline finish none → 2011-12-16 |
| 700 | Form Work | 2011-12-16 → 2011-12-21 (+5d) | 2011-12-16 → 2011-12-22 (+6d) | baseline start none → 2011-12-16; baseline finish none → 2011-12-17 |
| 701 | Re-bar Work | 2011-12-17 → 2011-12-22 (+5d) | 2011-12-17 → 2011-12-23 (+6d) | baseline start none → 2011-12-17; baseline finish none → 2011-12-18 |
| 702 | Concrete | 2011-12-18 → 2011-12-23 (+5d) | 2011-12-18 → 2011-12-24 (+6d) | baseline start none → 2011-12-18; baseline finish none → 2011-12-19 |
| 703 | **2nd Flight** | 2011-12-19 → 2011-12-24 (+5d) | 2011-12-21 → 2011-12-27 (+6d) | baseline start none → 2011-12-19; baseline finish none → 2011-12-22 |
| 704 | Form Work | 2011-12-19 → 2011-12-24 (+5d) | 2011-12-19 → 2011-12-25 (+6d) | baseline start none → 2011-12-19; baseline finish none → 2011-12-20 |
| 705 | Re-bar | 2011-12-20 → 2011-12-25 (+5d) | 2011-12-20 → 2011-12-26 (+6d) | baseline start none → 2011-12-20; baseline finish none → 2011-12-21 |
| 706 | Concrete | 2011-12-21 → 2011-12-26 (+5d) | 2011-12-21 → 2011-12-27 (+6d) | baseline start none → 2011-12-21; baseline finish none → 2011-12-22 |
| 707 | **Roof Slab** | 2011-12-27 → 2012-01-01 (+5d) | 2012-01-08 → 2012-01-14 (+6d) | baseline start none → 2011-12-27; baseline finish none → 2012-01-09 |
| 708 | Form Work | 2011-12-27 → 2012-01-01 (+5d) | 2011-12-31 → 2012-01-06 (+6d) | baseline start none → 2011-12-27; baseline finish none → 2012-01-01 |
| 709 | Re-bar | 2012-01-01 → 2012-01-06 (+5d) | 2012-01-04 → 2012-01-10 (+6d) | baseline start none → 2012-01-01; baseline finish none → 2012-01-05 |
| 710 | MEP Work | 2012-01-05 → 2012-01-10 (+5d) | 2012-01-05 → 2012-01-11 (+6d) | baseline start none → 2012-01-05; baseline finish none → 2012-01-06 |
| 711 | Inspection | 2012-01-06 → 2012-01-11 (+5d) | 2012-01-06 → 2012-01-12 (+6d) | baseline start none → 2012-01-06; baseline finish none → 2012-01-07 |
| 712 | Concrete | 2012-01-07 → 2012-01-12 (+5d) | 2012-01-08 → 2012-01-14 (+6d) | baseline start none → 2012-01-07; baseline finish none → 2012-01-09 |
| 713 | **9TH FLOOR** | 2012-01-09 → 2012-01-14 (+5d) | 2012-02-02 → 2012-02-08 (+6d) | baseline start none → 2012-01-09; baseline finish none → 2012-02-03 |
| 714 | **Column** | 2012-01-09 → 2012-01-14 (+5d) | 2012-01-20 → 2012-01-26 (+6d) | baseline start none → 2012-01-09; baseline finish none → 2012-01-21 |
| 715 | **1ST Lift** | 2012-01-09 → 2012-01-14 (+5d) | 2012-01-14 → 2012-01-20 (+6d) | baseline start none → 2012-01-09; baseline finish none → 2012-01-15 |
| 716 | Re-Bar Work | 2012-01-09 → 2012-01-14 (+5d) | 2012-01-09 → 2012-01-15 (+6d) | baseline start none → 2012-01-09; baseline finish none → 2012-01-10 |
| 717 | Form Work | 2012-01-10 → 2012-01-15 (+5d) | 2012-01-10 → 2012-01-16 (+6d) | baseline start none → 2012-01-10; baseline finish none → 2012-01-11 |
| 718 | Concrete | 2012-01-11 → 2012-01-16 (+5d) | 2012-01-11 → 2012-01-17 (+6d) | baseline start none → 2012-01-11; baseline finish none → 2012-01-12 |
| 719 | De-shuttering | 2012-01-14 → 2012-01-19 (+5d) | 2012-01-14 → 2012-01-20 (+6d) | baseline start none → 2012-01-14; baseline finish none → 2012-01-15 |
| 720 | **2nd Lift** | 2012-01-15 → 2012-01-20 (+5d) | 2012-01-20 → 2012-01-26 (+6d) | baseline start none → 2012-01-15; baseline finish none → 2012-01-21 |
| 721 | Re-Bar Work | 2012-01-15 → 2012-01-20 (+5d) | 2012-01-15 → 2012-01-21 (+6d) | baseline start none → 2012-01-15; baseline finish none → 2012-01-16 |
| 722 | Form Work | 2012-01-16 → 2012-01-21 (+5d) | 2012-01-16 → 2012-01-22 (+6d) | baseline start none → 2012-01-16; baseline finish none → 2012-01-17 |
| 723 | Concrete | 2012-01-17 → 2012-01-22 (+5d) | 2012-01-17 → 2012-01-23 (+6d) | baseline start none → 2012-01-17; baseline finish none → 2012-01-18 |
| 724 | De-shuttering | 2012-01-20 → 2012-01-25 (+5d) | 2012-01-20 → 2012-01-26 (+6d) | baseline start none → 2012-01-20; baseline finish none → 2012-01-21 |
| 725 | **Shear Wall** | 2012-01-09 → 2012-01-14 (+5d) | 2012-01-20 → 2012-01-26 (+6d) | baseline start none → 2012-01-09; baseline finish none → 2012-01-21 |
| 726 | **1st Lift** | 2012-01-09 → 2012-01-14 (+5d) | 2012-01-14 → 2012-01-20 (+6d) | baseline start none → 2012-01-09; baseline finish none → 2012-01-15 |
| 727 | Re-Bar Work | 2012-01-09 → 2012-01-14 (+5d) | 2012-01-09 → 2012-01-15 (+6d) | baseline start none → 2012-01-09; baseline finish none → 2012-01-10 |
| 728 | Form Work | 2012-01-10 → 2012-01-15 (+5d) | 2012-01-10 → 2012-01-16 (+6d) | baseline start none → 2012-01-10; baseline finish none → 2012-01-11 |
| 729 | Concrete | 2012-01-11 → 2012-01-16 (+5d) | 2012-01-11 → 2012-01-17 (+6d) | baseline start none → 2012-01-11; baseline finish none → 2012-01-12 |
| 730 | De-shuttering | 2012-01-14 → 2012-01-19 (+5d) | 2012-01-14 → 2012-01-20 (+6d) | baseline start none → 2012-01-14; baseline finish none → 2012-01-15 |
| 731 | **2nd Lift** | 2012-01-15 → 2012-01-20 (+5d) | 2012-01-20 → 2012-01-26 (+6d) | baseline start none → 2012-01-15; baseline finish none → 2012-01-21 |
| 732 | Re-Bar Work | 2012-01-15 → 2012-01-20 (+5d) | 2012-01-15 → 2012-01-21 (+6d) | baseline start none → 2012-01-15; baseline finish none → 2012-01-16 |
| 733 | Form Work | 2012-01-16 → 2012-01-21 (+5d) | 2012-01-16 → 2012-01-22 (+6d) | baseline start none → 2012-01-16; baseline finish none → 2012-01-17 |
| 734 | Concrete | 2012-01-17 → 2012-01-22 (+5d) | 2012-01-17 → 2012-01-23 (+6d) | baseline start none → 2012-01-17; baseline finish none → 2012-01-18 |

| ID | Task | Start | Finish | Other |
| --- | --- | --- | --- | --- |
| 735 | De-shuttering | 2012-01-20 → 2012-01-25 (+5d) | 2012-01-20 → 2012-01-26 (+6d) | baseline start none → 2012-01-20; baseline finish none → 2012-01-21 |
| 736 | **Stair - 1 & 2** | 2012-01-09 → 2012-01-14 (+5d) | 2012-01-15 → 2012-01-21 (+6d) | baseline start none → 2012-01-09; baseline finish none → 2012-01-16 |
| 737 | **1st Flight** | 2012-01-09 → 2012-01-14 (+5d) | 2012-01-12 → 2012-01-18 (+6d) | baseline start none → 2012-01-09; baseline finish none → 2012-01-13 |
| 738 | Brick Work | 2012-01-09 → 2012-01-14 (+5d) | 2012-01-09 → 2012-01-15 (+6d) | baseline start none → 2012-01-09; baseline finish none → 2012-01-10 |
| 739 | Form Work | 2012-01-10 → 2012-01-15 (+5d) | 2012-01-10 → 2012-01-16 (+6d) | baseline start none → 2012-01-10; baseline finish none → 2012-01-11 |
| 740 | Re-bar Work | 2012-01-11 → 2012-01-16 (+5d) | 2012-01-11 → 2012-01-17 (+6d) | baseline start none → 2012-01-11; baseline finish none → 2012-01-12 |
| 741 | Concrete | 2012-01-12 → 2012-01-17 (+5d) | 2012-01-12 → 2012-01-18 (+6d) | baseline start none → 2012-01-12; baseline finish none → 2012-01-13 |
| 742 | **2nd Flight** | 2012-01-13 → 2012-01-18 (+5d) | 2012-01-15 → 2012-01-21 (+6d) | baseline start none → 2012-01-13; baseline finish none → 2012-01-16 |
| 743 | Form Work | 2012-01-13 → 2012-01-18 (+5d) | 2012-01-13 → 2012-01-19 (+6d) | baseline start none → 2012-01-13; baseline finish none → 2012-01-14 |
| 744 | Re-bar | 2012-01-14 → 2012-01-19 (+5d) | 2012-01-14 → 2012-01-20 (+6d) | baseline start none → 2012-01-14; baseline finish none → 2012-01-15 |
| 745 | Concrete | 2012-01-15 → 2012-01-20 (+5d) | 2012-01-15 → 2012-01-21 (+6d) | baseline start none → 2012-01-15; baseline finish none → 2012-01-16 |
| 746 | **Roof Slab** | 2012-01-21 → 2012-01-26 (+5d) | 2012-02-02 → 2012-02-08 (+6d) | baseline start none → 2012-01-21; baseline finish none → 2012-02-03 |
| 747 | Form Work | 2012-01-21 → 2012-01-26 (+5d) | 2012-01-25 → 2012-01-31 (+6d) | baseline start none → 2012-01-21; baseline finish none → 2012-01-26 |
| 748 | Re-bar | 2012-01-26 → 2012-01-31 (+5d) | 2012-01-29 → 2012-02-04 (+6d) | baseline start none → 2012-01-26; baseline finish none → 2012-01-30 |
| 749 | MEP Work | 2012-01-30 → 2012-02-04 (+5d) | 2012-01-30 → 2012-02-05 (+6d) | baseline start none → 2012-01-30; baseline finish none → 2012-01-31 |
| 750 | Inspection | 2012-01-31 → 2012-02-05 (+5d) | 2012-01-31 → 2012-02-06 (+6d) | baseline start none → 2012-01-31; baseline finish none → 2012-02-01 |
| 751 | Concrete | 2012-02-01 → 2012-02-06 (+5d) | 2012-02-02 → 2012-02-08 (+6d) | baseline start none → 2012-02-01; baseline finish none → 2012-02-03 |
| 752 | **10TH FLOOR** | 2012-02-03 → 2012-02-08 (+5d) | 2012-02-27 → 2012-03-04 (+6d) | baseline start none → 2012-02-03; baseline finish none → 2012-02-28 |
| 753 | **Column** | 2012-02-03 → 2012-02-08 (+5d) | 2012-02-14 → 2012-02-20 (+6d) | baseline start none → 2012-02-03; baseline finish none → 2012-02-15 |
| 754 | **1ST Lift** | 2012-02-03 → 2012-02-08 (+5d) | 2012-02-08 → 2012-02-14 (+6d) | baseline start none → 2012-02-03; baseline finish none → 2012-02-09 |
| 755 | Re-Bar Work | 2012-02-03 → 2012-02-08 (+5d) | 2012-02-03 → 2012-02-09 (+6d) | baseline start none → 2012-02-03; baseline finish none → 2012-02-04 |
| 756 | Form Work | 2012-02-04 → 2012-02-09 (+5d) | 2012-02-04 → 2012-02-10 (+6d) | baseline start none → 2012-02-04; baseline finish none → 2012-02-05 |
| 757 | Concrete | 2012-02-05 → 2012-02-10 (+5d) | 2012-02-05 → 2012-02-11 (+6d) | baseline start none → 2012-02-05; baseline finish none → 2012-02-06 |
| 758 | De-shuttering | 2012-02-08 → 2012-02-13 (+5d) | 2012-02-08 → 2012-02-14 (+6d) | baseline start none → 2012-02-08; baseline finish none → 2012-02-09 |
| 759 | **2nd Lift** | 2012-02-09 → 2012-02-14 (+5d) | 2012-02-14 → 2012-02-20 (+6d) | baseline start none → 2012-02-09; baseline finish none → 2012-02-15 |
| 760 | Re-Bar Work | 2012-02-09 → 2012-02-14 (+5d) | 2012-02-09 → 2012-02-15 (+6d) | baseline start none → 2012-02-09; baseline finish none → 2012-02-10 |
| 761 | Form Work | 2012-02-10 → 2012-02-15 (+5d) | 2012-02-10 → 2012-02-16 (+6d) | baseline start none → 2012-02-10; baseline finish none → 2012-02-11 |
| 762 | Concrete | 2012-02-11 → 2012-02-16 (+5d) | 2012-02-11 → 2012-02-17 (+6d) | baseline start none → 2012-02-11; baseline finish none → 2012-02-12 |
| 763 | De-shuttering | 2012-02-14 → 2012-02-19 (+5d) | 2012-02-14 → 2012-02-20 (+6d) | baseline start none → 2012-02-14; baseline finish none → 2012-02-15 |
| 764 | **Shear Wall** | 2012-02-03 → 2012-02-08 (+5d) | 2012-02-14 → 2012-02-20 (+6d) | baseline start none → 2012-02-03; baseline finish none → 2012-02-15 |
| 765 | **1st Lift** | 2012-02-03 → 2012-02-08 (+5d) | 2012-02-08 → 2012-02-14 (+6d) | baseline start none → 2012-02-03; baseline finish none → 2012-02-09 |
| 766 | Re-Bar Work | 2012-02-03 → 2012-02-08 (+5d) | 2012-02-03 → 2012-02-09 (+6d) | baseline start none → 2012-02-03; baseline finish none → 2012-02-04 |
| 767 | Form Work | 2012-02-04 → 2012-02-09 (+5d) | 2012-02-04 → 2012-02-10 (+6d) | baseline start none → 2012-02-04; baseline finish none → 2012-02-05 |
| 768 | Concrete | 2012-02-05 → 2012-02-10 (+5d) | 2012-02-05 → 2012-02-11 (+6d) | baseline start none → 2012-02-05; baseline finish none → 2012-02-06 |
| 769 | De-shuttering | 2012-02-08 → 2012-02-13 (+5d) | 2012-02-08 → 2012-02-14 (+6d) | baseline start none → 2012-02-08; baseline finish none → 2012-02-09 |
| 770 | **2nd Lift** | 2012-02-09 → 2012-02-14 (+5d) | 2012-02-14 → 2012-02-20 (+6d) | baseline start none → 2012-02-09; baseline finish none → 2012-02-15 |
| 771 | Re-Bar Work | 2012-02-09 → 2012-02-14 (+5d) | 2012-02-09 → 2012-02-15 (+6d) | baseline start none → 2012-02-09; baseline finish none → 2012-02-10 |
| 772 | Form Work | 2012-02-10 → 2012-02-15 (+5d) | 2012-02-10 → 2012-02-16 (+6d) | baseline start none → 2012-02-10; baseline finish none → 2012-02-11 |
| 773 | Concrete | 2012-02-11 → 2012-02-16 (+5d) | 2012-02-11 → 2012-02-17 (+6d) | baseline start none → 2012-02-11; baseline finish none → 2012-02-12 |
| 774 | De-shuttering | 2012-02-14 → 2012-02-19 (+5d) | 2012-02-14 → 2012-02-20 (+6d) | baseline start none → 2012-02-14; baseline finish none → 2012-02-15 |
| 775 | **Stair - 1 & 2** | 2012-02-03 → 2012-02-08 (+5d) | 2012-02-09 → 2012-02-15 (+6d) | baseline start none → 2012-02-03; baseline finish none → 2012-02-10 |
| 776 | **1st Flight** | 2012-02-03 → 2012-02-08 (+5d) | 2012-02-06 → 2012-02-12 (+6d) | baseline start none → 2012-02-03; baseline finish none → 2012-02-07 |
| 777 | Brick Work | 2012-02-03 → 2012-02-08 (+5d) | 2012-02-03 → 2012-02-09 (+6d) | baseline start none → 2012-02-03; baseline finish none → 2012-02-04 |
| 778 | Form Work | 2012-02-04 → 2012-02-09 (+5d) | 2012-02-04 → 2012-02-10 (+6d) | baseline start none → 2012-02-04; baseline finish none → 2012-02-05 |
| 779 | Re-bar Work | 2012-02-05 → 2012-02-10 (+5d) | 2012-02-05 → 2012-02-11 (+6d) | baseline start none → 2012-02-05; baseline finish none → 2012-02-06 |
| 780 | Concrete | 2012-02-06 → 2012-02-11 (+5d) | 2012-02-06 → 2012-02-12 (+6d) | baseline start none → 2012-02-06; baseline finish none → 2012-02-07 |
| 781 | **2nd Flight** | 2012-02-07 → 2012-02-12 (+5d) | 2012-02-09 → 2012-02-15 (+6d) | baseline start none → 2012-02-07; baseline finish none → 2012-02-10 |
| 782 | Form Work | 2012-02-07 → 2012-02-12 (+5d) | 2012-02-07 → 2012-02-13 (+6d) | baseline start none → 2012-02-07; baseline finish none → 2012-02-08 |
| 783 | Re-bar | 2012-02-08 → 2012-02-13 (+5d) | 2012-02-08 → 2012-02-14 (+6d) | baseline start none → 2012-02-08; baseline finish none → 2012-02-09 |
| 784 | Concrete | 2012-02-09 → 2012-02-14 (+5d) | 2012-02-09 → 2012-02-15 (+6d) | baseline start none → 2012-02-09; baseline finish none → 2012-02-10 |
| 785 | **Roof Slab** | 2012-02-15 → 2012-02-20 (+5d) | 2012-02-27 → 2012-03-04 (+6d) | baseline start none → 2012-02-15; baseline finish none → 2012-02-28 |
| 786 | Form Work | 2012-02-15 → 2012-02-20 (+5d) | 2012-02-19 → 2012-02-25 (+6d) | baseline start none → 2012-02-15; baseline finish none → 2012-02-20 |
| 787 | Re-bar | 2012-02-20 → 2012-02-25 (+5d) | 2012-02-23 → 2012-02-29 (+6d) | baseline start none → 2012-02-20; baseline finish none → 2012-02-24 |
| 788 | MEP Work | 2012-02-24 → 2012-02-29 (+5d) | 2012-02-24 → 2012-03-01 (+6d) | baseline start none → 2012-02-24; baseline finish none → 2012-02-25 |
| 789 | Inspection | 2012-02-25 → 2012-03-01 (+5d) | 2012-02-25 → 2012-03-02 (+6d) | baseline start none → 2012-02-25; baseline finish none → 2012-02-26 |
| 790 | Concrete | 2012-02-26 → 2012-03-02 (+5d) | 2012-02-27 → 2012-03-04 (+6d) | baseline start none → 2012-02-26; baseline finish none → 2012-02-28 |
| 791 | **11TH FLOOR** | 2012-02-28 → 2012-03-04 (+5d) | 2012-03-23 → 2012-03-29 (+6d) | baseline start none → 2012-02-28; baseline finish none → 2012-03-24 |
| 792 | **Column** | 2012-02-28 → 2012-03-04 (+5d) | 2012-03-10 → 2012-03-16 (+6d) | baseline start none → 2012-02-28; baseline finish none → 2012-03-11 |
| 793 | **1ST Lift** | 2012-02-28 → 2012-03-04 (+5d) | 2012-03-04 → 2012-03-10 (+6d) | baseline start none → 2012-02-28; baseline finish none → 2012-03-05 |
| 794 | Re-Bar Work | 2012-02-28 → 2012-03-04 (+5d) | 2012-02-28 → 2012-03-05 (+6d) | baseline start none → 2012-02-28; baseline finish none → 2012-02-29 |
| 795 | Form Work | 2012-02-29 → 2012-03-05 (+5d) | 2012-02-29 → 2012-03-06 (+6d) | baseline start none → 2012-02-29; baseline finish none → 2012-03-01 |
| 796 | Concrete | 2012-03-01 → 2012-03-06 (+5d) | 2012-03-01 → 2012-03-07 (+6d) | baseline start none → 2012-03-01; baseline finish none → 2012-03-02 |
| 797 | De-shuttering | 2012-03-04 → 2012-03-09 (+5d) | 2012-03-04 → 2012-03-10 (+6d) | baseline start none → 2012-03-04; baseline finish none → 2012-03-05 |
| 798 | **2nd Lift** | 2012-03-05 → 2012-03-10 (+5d) | 2012-03-10 → 2012-03-16 (+6d) | baseline start none → 2012-03-05; baseline finish none → 2012-03-11 |
| 799 | Re-Bar Work | 2012-03-05 → 2012-03-10 (+5d) | 2012-03-05 → 2012-03-11 (+6d) | baseline start none → 2012-03-05; baseline finish none → 2012-03-06 |
| 800 | Form Work | 2012-03-06 → 2012-03-11 (+5d) | 2012-03-06 → 2012-03-12 (+6d) | baseline start none → 2012-03-06; baseline finish none → 2012-03-07 |
| 801 | Concrete | 2012-03-07 → 2012-03-12 (+5d) | 2012-03-07 → 2012-03-13 (+6d) | baseline start none → 2012-03-07; baseline finish none → 2012-03-08 |
| 802 | De-shuttering | 2012-03-10 → 2012-03-15 (+5d) | 2012-03-10 → 2012-03-16 (+6d) | baseline start none → 2012-03-10; baseline finish none → 2012-03-11 |
| 803 | **Shear Wall** | 2012-02-28 → 2012-03-04 (+5d) | 2012-03-10 → 2012-03-16 (+6d) | baseline start none → 2012-02-28; baseline finish none → 2012-03-11 |
| 804 | **1st Lift** | 2012-02-28 → 2012-03-04 (+5d) | 2012-03-04 → 2012-03-10 (+6d) | baseline start none → 2012-02-28; baseline finish none → 2012-03-05 |

| ID | Task | Start | Finish | Other |
| --- | --- | --- | --- | --- |
| 805 | Re-Bar Work | 2012-02-28 → 2012-03-04 (+5d) | 2012-02-28 → 2012-03-05 (+6d) | baseline start none → 2012-02-28; baseline finish none → 2012-02-29 |
| 806 | Form Work | 2012-02-29 → 2012-03-05 (+5d) | 2012-02-29 → 2012-03-06 (+6d) | baseline start none → 2012-02-29; baseline finish none → 2012-03-01 |
| 807 | Concrete | 2012-03-01 → 2012-03-06 (+5d) | 2012-03-01 → 2012-03-07 (+6d) | baseline start none → 2012-03-01; baseline finish none → 2012-03-02 |
| 808 | De-shuttering | 2012-03-04 → 2012-03-09 (+5d) | 2012-03-04 → 2012-03-10 (+6d) | baseline start none → 2012-03-04; baseline finish none → 2012-03-05 |
| 809 | **2nd Lift** | 2012-03-05 → 2012-03-10 (+5d) | 2012-03-10 → 2012-03-16 (+6d) | baseline start none → 2012-03-05; baseline finish none → 2012-03-11 |
| 810 | Re-Bar Work | 2012-03-05 → 2012-03-10 (+5d) | 2012-03-05 → 2012-03-11 (+6d) | baseline start none → 2012-03-05; baseline finish none → 2012-03-06 |
| 811 | Form Work | 2012-03-06 → 2012-03-11 (+5d) | 2012-03-06 → 2012-03-12 (+6d) | baseline start none → 2012-03-06; baseline finish none → 2012-03-07 |
| 812 | Concrete | 2012-03-07 → 2012-03-12 (+5d) | 2012-03-07 → 2012-03-13 (+6d) | baseline start none → 2012-03-07; baseline finish none → 2012-03-08 |
| 813 | De-shuttering | 2012-03-10 → 2012-03-15 (+5d) | 2012-03-10 → 2012-03-16 (+6d) | baseline start none → 2012-03-10; baseline finish none → 2012-03-11 |
| 814 | **Stair - 1 & 2** | 2012-02-28 → 2012-03-04 (+5d) | 2012-03-05 → 2012-03-11 (+6d) | baseline start none → 2012-02-28; baseline finish none → 2012-03-06 |
| 815 | **1st Flight** | 2012-02-28 → 2012-03-04 (+5d) | 2012-03-02 → 2012-03-08 (+6d) | baseline start none → 2012-02-28; baseline finish none → 2012-03-03 |
| 816 | Brick Work | 2012-02-28 → 2012-03-04 (+5d) | 2012-02-28 → 2012-03-05 (+6d) | baseline start none → 2012-02-28; baseline finish none → 2012-02-29 |
| 817 | Form Work | 2012-02-29 → 2012-03-05 (+5d) | 2012-02-29 → 2012-03-06 (+6d) | baseline start none → 2012-02-29; baseline finish none → 2012-03-01 |
| 818 | Re-bar Work | 2012-03-01 → 2012-03-06 (+5d) | 2012-03-01 → 2012-03-07 (+6d) | baseline start none → 2012-03-01; baseline finish none → 2012-03-02 |
| 819 | Concrete | 2012-03-02 → 2012-03-07 (+5d) | 2012-03-02 → 2012-03-08 (+6d) | baseline start none → 2012-03-02; baseline finish none → 2012-03-03 |
| 820 | **2nd Flight** | 2012-03-03 → 2012-03-08 (+5d) | 2012-03-05 → 2012-03-11 (+6d) | baseline start none → 2012-03-03; baseline finish none → 2012-03-06 |
| 821 | Form Work | 2012-03-03 → 2012-03-08 (+5d) | 2012-03-03 → 2012-03-09 (+6d) | baseline start none → 2012-03-03; baseline finish none → 2012-03-04 |
| 822 | Re-bar | 2012-03-04 → 2012-03-09 (+5d) | 2012-03-04 → 2012-03-10 (+6d) | baseline start none → 2012-03-04; baseline finish none → 2012-03-05 |
| 823 | Concrete | 2012-03-05 → 2012-03-10 (+5d) | 2012-03-05 → 2012-03-11 (+6d) | baseline start none → 2012-03-05; baseline finish none → 2012-03-06 |
| 824 | **Roof Slab** | 2012-03-11 → 2012-03-16 (+5d) | 2012-03-23 → 2012-03-29 (+6d) | baseline start none → 2012-03-11; baseline finish none → 2012-03-24 |
| 825 | Form Work | 2012-03-11 → 2012-03-16 (+5d) | 2012-03-15 → 2012-03-21 (+6d) | baseline start none → 2012-03-11; baseline finish none → 2012-03-16 |
| 826 | Re-bar | 2012-03-16 → 2012-03-21 (+5d) | 2012-03-19 → 2012-03-25 (+6d) | baseline start none → 2012-03-16; baseline finish none → 2012-03-20 |
| 827 | MEP Work | 2012-03-20 → 2012-03-25 (+5d) | 2012-03-20 → 2012-03-26 (+6d) | baseline start none → 2012-03-20; baseline finish none → 2012-03-21 |
| 828 | Inspection | 2012-03-21 → 2012-03-26 (+5d) | 2012-03-21 → 2012-03-27 (+6d) | baseline start none → 2012-03-21; baseline finish none → 2012-03-22 |
| 829 | Concrete | 2012-03-22 → 2012-03-27 (+5d) | 2012-03-23 → 2012-03-29 (+6d) | baseline start none → 2012-03-22; baseline finish none → 2012-03-24 |
| 830 | **12TH FLOOR** | 2012-03-24 → 2012-03-29 (+5d) | 2012-04-17 → 2012-04-23 (+6d) | baseline start none → 2012-03-24; baseline finish none → 2012-04-18 |
| 831 | **Column** | 2012-03-24 → 2012-03-29 (+5d) | 2012-04-04 → 2012-04-10 (+6d) | baseline start none → 2012-03-24; baseline finish none → 2012-04-05 |
| 832 | **1ST Lift** | 2012-03-24 → 2012-03-29 (+5d) | 2012-03-29 → 2012-04-04 (+6d) | baseline start none → 2012-03-24; baseline finish none → 2012-03-30 |
| 833 | Re-Bar Work | 2012-03-24 → 2012-03-29 (+5d) | 2012-03-24 → 2012-03-30 (+6d) | baseline start none → 2012-03-24; baseline finish none → 2012-03-25 |
| 834 | Form Work | 2012-03-25 → 2012-03-30 (+5d) | 2012-03-25 → 2012-03-31 (+6d) | baseline start none → 2012-03-25; baseline finish none → 2012-03-26 |
| 835 | Concrete | 2012-03-26 → 2012-03-31 (+5d) | 2012-03-26 → 2012-04-01 (+6d) | baseline start none → 2012-03-26; baseline finish none → 2012-03-27 |
| 836 | De-shuttering | 2012-03-29 → 2012-04-03 (+5d) | 2012-03-29 → 2012-04-04 (+6d) | baseline start none → 2012-03-29; baseline finish none → 2012-03-30 |
| 837 | **2nd Lift** | 2012-03-30 → 2012-04-04 (+5d) | 2012-04-04 → 2012-04-10 (+6d) | baseline start none → 2012-03-30; baseline finish none → 2012-04-05 |
| 838 | Re-Bar Work | 2012-03-30 → 2012-04-04 (+5d) | 2012-03-30 → 2012-04-05 (+6d) | baseline start none → 2012-03-30; baseline finish none → 2012-03-31 |
| 839 | Form Work | 2012-03-31 → 2012-04-05 (+5d) | 2012-03-31 → 2012-04-06 (+6d) | baseline start none → 2012-03-31; baseline finish none → 2012-04-01 |
| 840 | Concrete | 2012-04-01 → 2012-04-06 (+5d) | 2012-04-01 → 2012-04-07 (+6d) | baseline start none → 2012-04-01; baseline finish none → 2012-04-02 |
| 841 | De-shuttering | 2012-04-04 → 2012-04-09 (+5d) | 2012-04-04 → 2012-04-10 (+6d) | baseline start none → 2012-04-04; baseline finish none → 2012-04-05 |
| 842 | **Shear Wall** | 2012-03-24 → 2012-03-29 (+5d) | 2012-04-04 → 2012-04-10 (+6d) | baseline start none → 2012-03-24; baseline finish none → 2012-04-05 |
| 843 | **1st Lift** | 2012-03-24 → 2012-03-29 (+5d) | 2012-03-29 → 2012-04-04 (+6d) | baseline start none → 2012-03-24; baseline finish none → 2012-03-30 |
| 844 | Re-Bar Work | 2012-03-24 → 2012-03-29 (+5d) | 2012-03-24 → 2012-03-30 (+6d) | baseline start none → 2012-03-24; baseline finish none → 2012-03-25 |
| 845 | Form Work | 2012-03-25 → 2012-03-30 (+5d) | 2012-03-25 → 2012-03-31 (+6d) | baseline start none → 2012-03-25; baseline finish none → 2012-03-26 |
| 846 | Concrete | 2012-03-26 → 2012-03-31 (+5d) | 2012-03-26 → 2012-04-01 (+6d) | baseline start none → 2012-03-26; baseline finish none → 2012-03-27 |
| 847 | De-shuttering | 2012-03-29 → 2012-04-03 (+5d) | 2012-03-29 → 2012-04-04 (+6d) | baseline start none → 2012-03-29; baseline finish none → 2012-03-30 |
| 848 | **2nd Lift** | 2012-03-30 → 2012-04-04 (+5d) | 2012-04-04 → 2012-04-10 (+6d) | baseline start none → 2012-03-30; baseline finish none → 2012-04-05 |
| 849 | Re-Bar Work | 2012-03-30 → 2012-04-04 (+5d) | 2012-03-30 → 2012-04-05 (+6d) | baseline start none → 2012-03-30; baseline finish none → 2012-03-31 |
| 850 | Form Work | 2012-03-31 → 2012-04-05 (+5d) | 2012-03-31 → 2012-04-06 (+6d) | baseline start none → 2012-03-31; baseline finish none → 2012-04-01 |
| 851 | Concrete | 2012-04-01 → 2012-04-06 (+5d) | 2012-04-01 → 2012-04-07 (+6d) | baseline start none → 2012-04-01; baseline finish none → 2012-04-02 |
| 852 | De-shuttering | 2012-04-04 → 2012-04-09 (+5d) | 2012-04-04 → 2012-04-10 (+6d) | baseline start none → 2012-04-04; baseline finish none → 2012-04-05 |
| 853 | **Stair - 1 & 2** | 2012-03-24 → 2012-03-29 (+5d) | 2012-03-30 → 2012-04-05 (+6d) | baseline start none → 2012-03-24; baseline finish none → 2012-03-31 |
| 854 | **1st Flight** | 2012-03-24 → 2012-03-29 (+5d) | 2012-03-27 → 2012-04-02 (+6d) | baseline start none → 2012-03-24; baseline finish none → 2012-03-28 |
| 855 | Brick Work | 2012-03-24 → 2012-03-29 (+5d) | 2012-03-24 → 2012-03-30 (+6d) | baseline start none → 2012-03-24; baseline finish none → 2012-03-25 |
| 856 | Form Work | 2012-03-25 → 2012-03-30 (+5d) | 2012-03-25 → 2012-03-31 (+6d) | baseline start none → 2012-03-25; baseline finish none → 2012-03-26 |
| 857 | Re-bar Work | 2012-03-26 → 2012-03-31 (+5d) | 2012-03-26 → 2012-04-01 (+6d) | baseline start none → 2012-03-26; baseline finish none → 2012-03-27 |
| 858 | Concrete | 2012-03-27 → 2012-04-01 (+5d) | 2012-03-27 → 2012-04-02 (+6d) | baseline start none → 2012-03-27; baseline finish none → 2012-03-28 |
| 859 | **2nd Flight** | 2012-03-28 → 2012-04-02 (+5d) | 2012-03-30 → 2012-04-05 (+6d) | baseline start none → 2012-03-28; baseline finish none → 2012-03-31 |
| 860 | Form Work | 2012-03-28 → 2012-04-02 (+5d) | 2012-03-28 → 2012-04-03 (+6d) | baseline start none → 2012-03-28; baseline finish none → 2012-03-29 |
| 861 | Re-bar | 2012-03-29 → 2012-04-03 (+5d) | 2012-03-29 → 2012-04-04 (+6d) | baseline start none → 2012-03-29; baseline finish none → 2012-03-30 |
| 862 | Concrete | 2012-03-30 → 2012-04-04 (+5d) | 2012-03-30 → 2012-04-05 (+6d) | baseline start none → 2012-03-30; baseline finish none → 2012-03-31 |
| 863 | **Roof Slab** | 2012-04-05 → 2012-04-10 (+5d) | 2012-04-17 → 2012-04-23 (+6d) | baseline start none → 2012-04-05; baseline finish none → 2012-04-18 |
| 864 | Form Work | 2012-04-05 → 2012-04-10 (+5d) | 2012-04-09 → 2012-04-15 (+6d) | baseline start none → 2012-04-05; baseline finish none → 2012-04-10 |
| 865 | Re-bar | 2012-04-10 → 2012-04-15 (+5d) | 2012-04-13 → 2012-04-19 (+6d) | baseline start none → 2012-04-10; baseline finish none → 2012-04-14 |
| 866 | MEP Work | 2012-04-14 → 2012-04-19 (+5d) | 2012-04-14 → 2012-04-20 (+6d) | baseline start none → 2012-04-14; baseline finish none → 2012-04-15 |
| 867 | Inspection | 2012-04-15 → 2012-04-20 (+5d) | 2012-04-15 → 2012-04-21 (+6d) | baseline start none → 2012-04-15; baseline finish none → 2012-04-16 |
| 868 | Concrete | 2012-04-16 → 2012-04-21 (+5d) | 2012-04-17 → 2012-04-23 (+6d) | baseline start none → 2012-04-16; baseline finish none → 2012-04-18 |
| 869 | **13TH FLOOR** | 2012-04-18 → 2012-04-23 (+5d) | 2012-05-12 → 2012-05-18 (+6d) | baseline start none → 2012-04-18; baseline finish none → 2012-05-13 |
| 870 | **Column** | 2012-04-18 → 2012-04-23 (+5d) | 2012-04-29 → 2012-05-05 (+6d) | baseline start none → 2012-04-18; baseline finish none → 2012-04-30 |
| 871 | **1ST Lift** | 2012-04-18 → 2012-04-23 (+5d) | 2012-04-23 → 2012-04-29 (+6d) | baseline start none → 2012-04-18; baseline finish none → 2012-04-24 |
| 872 | Re-Bar Work | 2012-04-18 → 2012-04-23 (+5d) | 2012-04-18 → 2012-04-24 (+6d) | baseline start none → 2012-04-18; baseline finish none → 2012-04-19 |
| 873 | Form Work | 2012-04-19 → 2012-04-24 (+5d) | 2012-04-19 → 2012-04-25 (+6d) | baseline start none → 2012-04-19; baseline finish none → 2012-04-20 |
| 874 | Concrete | 2012-04-20 → 2012-04-25 (+5d) | 2012-04-20 → 2012-04-26 (+6d) | baseline start none → 2012-04-20; baseline finish none → 2012-04-21 |

| ID | Task | Start | Finish | Duration | Total float | Other |
| --- | --- | --- | --- | --- | --- | --- |
| 875 | De-shuttering | 2012-04-23 → 2012-04-28 (+5d) | 2012-04-23 → 2012-04-29 (+6d) |  |  | baseline start none → 2012-04-23; baseline finish none → 2012-04-24 |
| 876 | **2nd Lift** | 2012-04-24 → 2012-04-29 (+5d) | 2012-04-29 → 2012-05-05 (+6d) |  |  | baseline start none → 2012-04-24; baseline finish none → 2012-04-30 |
| 877 | Re-Bar Work | 2012-04-24 → 2012-04-29 (+5d) | 2012-04-24 → 2012-04-30 (+6d) |  |  | baseline start none → 2012-04-24; baseline finish none → 2012-04-25 |
| 878 | Form Work | 2012-04-25 → 2012-04-30 (+5d) | 2012-04-25 → 2012-05-01 (+6d) |  |  | baseline start none → 2012-04-25; baseline finish none → 2012-04-26 |
| 879 | Concrete | 2012-04-26 → 2012-05-01 (+5d) | 2012-04-26 → 2012-05-02 (+6d) |  |  | baseline start none → 2012-04-26; baseline finish none → 2012-04-27 |
| 880 | De-shuttering | 2012-04-29 → 2012-05-04 (+5d) | 2012-04-29 → 2012-05-05 (+6d) |  |  | baseline start none → 2012-04-29; baseline finish none → 2012-04-30 |
| 881 | **Shear Wall** | 2012-04-18 → 2012-04-23 (+5d) | 2012-04-29 → 2012-05-05 (+6d) |  |  | baseline start none → 2012-04-18; baseline finish none → 2012-04-30 |
| 882 | **1st Lift** | 2012-04-18 → 2012-04-23 (+5d) | 2012-04-23 → 2012-04-29 (+6d) |  |  | baseline start none → 2012-04-18; baseline finish none → 2012-04-24 |
| 883 | Re-Bar Work | 2012-04-18 → 2012-04-23 (+5d) | 2012-04-18 → 2012-04-24 (+6d) |  |  | baseline start none → 2012-04-18; baseline finish none → 2012-04-19 |
| 884 | Form Work | 2012-04-19 → 2012-04-24 (+5d) | 2012-04-19 → 2012-04-25 (+6d) |  |  | baseline start none → 2012-04-19; baseline finish none → 2012-04-20 |
| 885 | Concrete | 2012-04-20 → 2012-04-25 (+5d) | 2012-04-20 → 2012-04-26 (+6d) |  |  | baseline start none → 2012-04-20; baseline finish none → 2012-04-21 |
| 886 | De-shuttering | 2012-04-23 → 2012-04-28 (+5d) | 2012-04-23 → 2012-04-29 (+6d) |  |  | baseline start none → 2012-04-23; baseline finish none → 2012-04-24 |
| 887 | **2nd Lift** | 2012-04-24 → 2012-04-29 (+5d) | 2012-04-29 → 2012-05-05 (+6d) |  |  | baseline start none → 2012-04-24; baseline finish none → 2012-04-30 |
| 888 | Re-Bar Work | 2012-04-24 → 2012-04-29 (+5d) | 2012-04-24 → 2012-04-30 (+6d) |  |  | baseline start none → 2012-04-24; baseline finish none → 2012-04-25 |
| 889 | Form Work | 2012-04-25 → 2012-04-30 (+5d) | 2012-04-25 → 2012-05-01 (+6d) |  |  | baseline start none → 2012-04-25; baseline finish none → 2012-04-26 |
| 890 | Concrete | 2012-04-26 → 2012-05-01 (+5d) | 2012-04-26 → 2012-05-02 (+6d) |  |  | baseline start none → 2012-04-26; baseline finish none → 2012-04-27 |
| 891 | De-shuttering | 2012-04-29 → 2012-05-04 (+5d) | 2012-04-29 → 2012-05-05 (+6d) |  |  | baseline start none → 2012-04-29; baseline finish none → 2012-04-30 |
| 892 | **Stair - 1 & 2** | 2012-04-18 → 2012-04-23 (+5d) | 2012-04-24 → 2012-04-30 (+6d) |  |  | baseline start none → 2012-04-18; baseline finish none → 2012-04-25 |
| 893 | **1st Flight** | 2012-04-18 → 2012-04-23 (+5d) | 2012-04-21 → 2012-04-27 (+6d) |  |  | baseline start none → 2012-04-18; baseline finish none → 2012-04-22 |
| 894 | Brick Work | 2012-04-18 → 2012-04-23 (+5d) | 2012-04-18 → 2012-04-24 (+6d) |  |  | baseline start none → 2012-04-18; baseline finish none → 2012-04-19 |
| 895 | Form Work | 2012-04-19 → 2012-04-24 (+5d) | 2012-04-19 → 2012-04-25 (+6d) |  |  | baseline start none → 2012-04-19; baseline finish none → 2012-04-20 |
| 896 | Re-bar Work | 2012-04-20 → 2012-04-25 (+5d) | 2012-04-20 → 2012-04-26 (+6d) |  |  | baseline start none → 2012-04-20; baseline finish none → 2012-04-21 |
| 897 | Concrete | 2012-04-21 → 2012-04-26 (+5d) | 2012-04-21 → 2012-04-27 (+6d) |  |  | baseline start none → 2012-04-21; baseline finish none → 2012-04-22 |
| 898 | **2nd Flight** | 2012-04-22 → 2012-04-27 (+5d) | 2012-04-24 → 2012-04-30 (+6d) |  |  | baseline start none → 2012-04-22; baseline finish none → 2012-04-25 |
| 899 | Form Work | 2012-04-22 → 2012-04-27 (+5d) | 2012-04-22 → 2012-04-28 (+6d) |  |  | baseline start none → 2012-04-22; baseline finish none → 2012-04-23 |
| 900 | Re-bar | 2012-04-23 → 2012-04-28 (+5d) | 2012-04-23 → 2012-04-29 (+6d) |  |  | baseline start none → 2012-04-23; baseline finish none → 2012-04-24 |
| 901 | Concrete | 2012-04-24 → 2012-04-29 (+5d) | 2012-04-24 → 2012-04-30 (+6d) |  |  | baseline start none → 2012-04-24; baseline finish none → 2012-04-25 |
| 902 | **Roof Slab** | 2012-04-30 → 2012-05-05 (+5d) | 2012-05-12 → 2012-05-18 (+6d) |  |  | baseline start none → 2012-04-30; baseline finish none → 2012-05-13 |
| 903 | Form Work | 2012-04-30 → 2012-05-05 (+5d) | 2012-05-04 → 2012-05-10 (+6d) |  |  | baseline start none → 2012-04-30; baseline finish none → 2012-05-05 |
| 904 | Re-bar | 2012-05-05 → 2012-05-10 (+5d) | 2012-05-08 → 2012-05-14 (+6d) |  |  | baseline start none → 2012-05-05; baseline finish none → 2012-05-09 |
| 905 | MEP Work | 2012-05-09 → 2012-05-14 (+5d) | 2012-05-09 → 2012-05-15 (+6d) |  |  | baseline start none → 2012-05-09; baseline finish none → 2012-05-10 |
| 906 | Inspection | 2012-05-10 → 2012-05-15 (+5d) | 2012-05-10 → 2012-05-16 (+6d) |  |  | baseline start none → 2012-05-10; baseline finish none → 2012-05-11 |
| 907 | Concrete | 2012-05-11 → 2012-05-16 (+5d) | 2012-05-12 → 2012-05-18 (+6d) |  |  | baseline start none → 2012-05-11; baseline finish none → 2012-05-13 |
| 908 | **MACHINE FLOOR** | 2012-05-13 → 2012-05-18 (+5d) | 2012-06-01 → 2012-06-07 (+6d) |  |  | baseline start none → 2012-05-13; baseline finish none → 2012-06-02 |
| 909 | **Column** | 2012-05-13 → 2012-05-18 (+5d) | 2012-05-24 → 2012-05-30 (+6d) |  |  | baseline start none → 2012-05-13; baseline finish none → 2012-05-25 |
| 910 | **1st Lift** | 2012-05-13 → 2012-05-18 (+5d) | 2012-05-18 → 2012-05-24 (+6d) |  |  | baseline start none → 2012-05-13; baseline finish none → 2012-05-19 |
| 911 | Re-Bar Work | 2012-05-13 → 2012-05-18 (+5d) | 2012-05-13 → 2012-05-19 (+6d) |  |  | baseline start none → 2012-05-13; baseline finish none → 2012-05-14 |
| 912 | Form Work | 2012-05-14 → 2012-05-19 (+5d) | 2012-05-14 → 2012-05-20 (+6d) |  |  | baseline start none → 2012-05-14; baseline finish none → 2012-05-15 |
| 913 | Concrete | 2012-05-15 → 2012-05-20 (+5d) | 2012-05-15 → 2012-05-21 (+6d) |  |  | baseline start none → 2012-05-15; baseline finish none → 2012-05-16 |
| 914 | De-shuttering | 2012-05-18 → 2012-05-23 (+5d) | 2012-05-18 → 2012-05-24 (+6d) |  |  | baseline start none → 2012-05-18; baseline finish none → 2012-05-19 |
| 915 | **2nd Lift** | 2012-05-19 → 2012-05-24 (+5d) | 2012-05-24 → 2012-05-30 (+6d) |  |  | baseline start none → 2012-05-19; baseline finish none → 2012-05-25 |
| 916 | Re-Bar Work | 2012-05-19 → 2012-05-24 (+5d) | 2012-05-19 → 2012-05-25 (+6d) |  |  | baseline start none → 2012-05-19; baseline finish none → 2012-05-20 |
| 917 | Form Work | 2012-05-20 → 2012-05-25 (+5d) | 2012-05-20 → 2012-05-26 (+6d) |  |  | baseline start none → 2012-05-20; baseline finish none → 2012-05-21 |
| 918 | Concrete | 2012-05-21 → 2012-05-26 (+5d) | 2012-05-21 → 2012-05-27 (+6d) |  |  | baseline start none → 2012-05-21; baseline finish none → 2012-05-22 |
| 919 | De-shuttering | 2012-05-24 → 2012-05-29 (+5d) | 2012-05-24 → 2012-05-30 (+6d) |  |  | baseline start none → 2012-05-24; baseline finish none → 2012-05-25 |
| 920 | Brcik Work upto M/c Room Bot Slab | 2012-05-13 → 2012-05-18 (+5d) | 2012-05-13 → 2012-05-19 (+6d) |  |  | baseline start none → 2012-05-13; baseline finish none → 2012-05-14 |
| 921 | **M/c Room Bottom Slab** | 2012-05-19 → 2012-05-24 (+5d) | 2012-05-21 → 2012-05-27 (+6d) |  |  | baseline start none → 2012-05-19; baseline finish none → 2012-05-22 |
| 922 | Form work | 2012-05-19 → 2012-05-24 (+5d) | 2012-05-19 → 2012-05-25 (+6d) |  |  | baseline start none → 2012-05-19; baseline finish none → 2012-05-20 |
| 923 | Re-bar | 2012-05-20 → 2012-05-25 (+5d) | 2012-05-20 → 2012-05-26 (+6d) |  |  | baseline start none → 2012-05-20; baseline finish none → 2012-05-21 |
| 924 | Concrete | 2012-05-21 → 2012-05-26 (+5d) | 2012-05-21 → 2012-05-27 (+6d) |  |  | baseline start none → 2012-05-21; baseline finish none → 2012-05-22 |
| 925 | Brick Work upto Top Slab | 2012-05-22 → 2012-05-27 (+5d) | 2012-05-22 → 2012-05-28 (+6d) |  |  | baseline start none → 2012-05-22; baseline finish none → 2012-05-23 |
| 926 | **Top slab** | 2012-05-23 → 2012-05-28 (+5d) | 2012-06-01 → 2012-06-07 (+6d) |  |  | baseline start none → 2012-05-23; baseline finish none → 2012-06-02 |
| 927 | Form Work | 2012-05-23 → 2012-05-28 (+5d) | 2012-05-27 → 2012-06-02 (+6d) |  |  | baseline start none → 2012-05-23; baseline finish none → 2012-05-28 |
| 928 | Re-bar Work | 2012-05-28 → 2012-06-02 (+5d) | 2012-05-30 → 2012-06-05 (+6d) |  |  | baseline start none → 2012-05-28; baseline finish none → 2012-05-31 |
| 929 | Inspection | 2012-05-31 → 2012-06-05 (+5d) | 2012-05-31 → 2012-06-06 (+6d) |  |  | baseline start none → 2012-05-31; baseline finish none → 2012-06-01 |
| 930 | Concrete | 2012-06-01 → 2012-06-06 (+5d) | 2012-06-01 → 2012-06-07 (+6d) |  |  | baseline start none → 2012-06-01; baseline finish none → 2012-06-02 |
| 931 | **Swimming Pool** | 2012-05-13 → 2012-05-18 (+5d) | 2012-05-17 → 2012-05-23 (+6d) |  |  | baseline start none → 2012-05-13; baseline finish none → 2012-05-18 |
| 932 | **Vertical Wall** | 2012-05-13 → 2012-05-18 (+5d) | 2012-05-17 → 2012-05-23 (+6d) |  |  | baseline start none → 2012-05-13; baseline finish none → 2012-05-18 |
| 933 | Re-bar | 2012-05-13 → 2012-05-18 (+5d) | 2012-05-14 → 2012-05-20 (+6d) |  |  | baseline start none → 2012-05-13; baseline finish none → 2012-05-15 |
| 934 | Formwork | 2012-05-15 → 2012-05-20 (+5d) | 2012-05-16 → 2012-05-22 (+6d) |  |  | baseline start none → 2012-05-15; baseline finish none → 2012-05-17 |
| 935 | Concrete | 2012-05-17 → 2012-05-22 (+5d) | 2012-05-17 → 2012-05-23 (+6d) |  |  | baseline start none → 2012-05-17; baseline finish none → 2012-05-18 |
| 936 | **Planter Box** | 2012-05-13 → 2012-05-18 (+5d) | 2012-05-18 → 2012-05-24 (+6d) |  |  | baseline start none → 2012-05-13; baseline finish none → 2012-05-19 |
| 937 | **Vertical Wall** | 2012-05-13 → 2012-05-18 (+5d) | 2012-05-18 → 2012-05-24 (+6d) |  |  | baseline start none → 2012-05-13; baseline finish none → 2012-05-19 |
| 938 | Re-bar | 2012-05-13 → 2012-05-18 (+5d) | 2012-05-14 → 2012-05-20 (+6d) |  |  | baseline start none → 2012-05-13; baseline finish none → 2012-05-15 |
| 939 | Formwork | 2012-05-15 → 2012-05-20 (+5d) | 2012-05-16 → 2012-05-22 (+6d) |  |  | baseline start none → 2012-05-15; baseline finish none → 2012-05-17 |
| 940 | Concrete | 2012-05-17 → 2012-05-22 (+5d) | 2012-05-18 → 2012-05-24 (+6d) |  |  | baseline start none → 2012-05-17; baseline finish none → 2012-05-19 |
| 941 | **FINISHING WORK** | 2011-04-15 → 2011-03-01 (-45d) | 2012-08-01 → 2012-08-07 (+6d) | 459d → 509d | 0d → 2d | baseline start none → 2011-04-15; baseline finish none → 2012-08-02 |
| 942 | **BASEMENT-3** | 2011-04-15 → 2011-03-01 (-45d) | 2011-06-30 → 2011-05-17 (-44d) |  | 382d → 432d | baseline start none → 2011-04-15; baseline finish none → 2011-07-01 |
| 943 | De-shuttering Roof Slab | 2011-04-15 → 2011-03-01 (-45d) | 2011-04-17 → 2011-03-04 (-44d) |  | 382d → 432d | baseline start none → 2011-04-15; baseline finish none → 2011-04-18 |
| 944 | Brick Work | 2011-04-18 → 2011-03-04 (-45d) | 2011-05-01 → 2011-03-18 (-44d) |  | 384d → 434d | baseline start none → 2011-04-18; baseline finish none → 2011-05-02 |

| ID | Task | Start | Finish | Total float | Other |
| --- | --- | --- | --- | --- | --- |
| 945 | Plaster | 2011-04-25 → 2011-03-11 (-45d) | 2011-05-08 → 2011-03-25 (-44d) | 384d → 434d | baseline start none → 2011-04-25; baseline finish none → 2011-05-09 |
| 946 | Column Guard/ Car Stopper | 2011-06-02 → 2011-04-18 (-45d) | 2011-06-09 → 2011-04-25 (-45d) | 404d → 456d | baseline start none → 2011-06-02; baseline finish none → 2011-06-10 |
| 947 | Stair/Other Railing | 2011-05-25 → 2011-04-10 (-45d) | 2011-06-09 → 2011-04-25 (-45d) | 404d → 456d | baseline start none → 2011-05-25; baseline finish none → 2011-06-10 |
| 948 | Resin Floor | 2011-06-09 → 2011-04-25 (-45d) | 2011-06-23 → 2011-05-10 (-44d) | 382d → 434d | baseline start none → 2011-06-09; baseline finish none → 2011-06-24 |
| 949 | Painting | 2011-06-01 → 2011-04-17 (-45d) | 2011-06-30 → 2011-05-17 (-44d) | 382d → 432d | baseline start none → 2011-06-01; baseline finish none → 2011-07-01 |
| 950 | **BASEMENT-2** | 2011-05-09 → 2011-04-10 (-29d) | 2011-07-24 → 2011-06-26 (-28d) | 358d → 392d | baseline start none → 2011-05-09; baseline finish none → 2011-07-25 |
| 951 | De-shuttering Roof Slab | 2011-05-09 → 2011-04-10 (-29d) | 2011-05-11 → 2011-04-13 (-28d) | 358d → 392d | baseline start none → 2011-05-09; baseline finish none → 2011-05-12 |
| 952 | Brick Work | 2011-05-12 → 2011-04-13 (-29d) | 2011-05-25 → 2011-04-27 (-28d) | 360d → 394d | baseline start none → 2011-05-12; baseline finish none → 2011-05-26 |
| 953 | Plaster | 2011-05-19 → 2011-04-20 (-29d) | 2011-06-01 → 2011-05-04 (-28d) | 360d → 394d | baseline start none → 2011-05-19; baseline finish none → 2011-06-02 |
| 954 | Column Guard/ Car Stopper | 2011-06-26 → 2011-05-28 (-29d) | 2011-07-03 → 2011-06-04 (-29d) | 380d → 414d | baseline start none → 2011-06-26; baseline finish none → 2011-07-04 |
| 955 | Stair/Other Railing | 2011-06-18 → 2011-05-20 (-29d) | 2011-07-03 → 2011-06-04 (-29d) | 380d → 414d | baseline start none → 2011-06-18; baseline finish none → 2011-07-04 |
| 956 | Resin Floor | 2011-07-03 → 2011-06-04 (-29d) | 2011-07-17 → 2011-06-19 (-28d) | 358d → 392d | baseline start none → 2011-07-03; baseline finish none → 2011-07-18 |
| 957 | Painting | 2011-06-25 → 2011-05-27 (-29d) | 2011-07-24 → 2011-06-26 (-28d) | 358d → 392d | baseline start none → 2011-06-25; baseline finish none → 2011-07-25 |
| 958 | **BASEMENT-1** | 2011-06-03 → 2011-06-08 (+5d) | 2011-08-18 → 2011-08-24 (+6d) |  | baseline start none → 2011-06-03; baseline finish none → 2011-08-19 |
| 959 | De-shuttering Roof Slab | 2011-06-03 → 2011-06-08 (+5d) | 2011-06-05 → 2011-06-11 (+6d) |  | baseline start none → 2011-06-03; baseline finish none → 2011-06-06 |
| 960 | Brick Work | 2011-06-06 → 2011-06-11 (+5d) | 2011-06-19 → 2011-06-25 (+6d) |  | baseline start none → 2011-06-06; baseline finish none → 2011-06-20 |
| 961 | Plaster | 2011-06-13 → 2011-06-18 (+5d) | 2011-06-26 → 2011-07-02 (+6d) |  | baseline start none → 2011-06-13; baseline finish none → 2011-06-27 |
| 962 | Column Guard/ Car Stopper | 2011-07-21 → 2011-07-26 (+5d) | 2011-07-28 → 2011-08-02 (+5d) |  | baseline start none → 2011-07-21; baseline finish none → 2011-07-29 |
| 963 | Stair/Other Railing | 2011-07-13 → 2011-07-18 (+5d) | 2011-07-28 → 2011-08-02 (+5d) |  | baseline start none → 2011-07-13; baseline finish none → 2011-07-29 |
| 964 | Resin Floor | 2011-07-28 → 2011-08-02 (+5d) | 2011-08-11 → 2011-08-17 (+6d) |  | baseline start none → 2011-07-28; baseline finish none → 2011-08-12 |
| 965 | Painting | 2011-07-20 → 2011-07-25 (+5d) | 2011-08-18 → 2011-08-24 (+6d) |  | baseline start none → 2011-07-20; baseline finish none → 2011-08-19 |
| 966 | **GROUND FLOOR** | 2011-06-28 → 2011-07-03 (+5d) | 2011-09-05 → 2011-09-11 (+6d) |  | baseline start none → 2011-06-28; baseline finish none → 2011-09-06 |
| 967 | De-shuttering Roof Slab | 2011-06-28 → 2011-07-03 (+5d) | 2011-06-30 → 2011-07-06 (+6d) |  | baseline start none → 2011-06-28; baseline finish none → 2011-07-01 |
| 968 | Brick Work | 2011-07-01 → 2011-07-06 (+5d) | 2011-07-07 → 2011-07-13 (+6d) |  | baseline start none → 2011-07-01; baseline finish none → 2011-07-08 |
| 969 | Plaster | 2011-07-08 → 2011-07-13 (+5d) | 2011-07-14 → 2011-07-20 (+6d) |  | baseline start none → 2011-07-08; baseline finish none → 2011-07-15 |
| 970 | **Toilet Cubicals** | 2011-07-15 → 2011-07-20 (+5d) | 2011-07-25 → 2011-07-31 (+6d) |  | baseline start none → 2011-07-15; baseline finish none → 2011-07-26 |
| 971 | Water/ Sewarage Pipe Lines | 2011-07-15 → 2011-07-20 (+5d) | 2011-07-17 → 2011-07-23 (+6d) |  | baseline start none → 2011-07-15; baseline finish none → 2011-07-18 |
| 972 | Water Proofing Works | 2011-07-18 → 2011-07-23 (+5d) | 2011-07-18 → 2011-07-24 (+6d) |  | baseline start none → 2011-07-18; baseline finish none → 2011-07-19 |
| 973 | Tile Works/ Marble Top | 2011-07-19 → 2011-07-24 (+5d) | 2011-07-21 → 2011-07-27 (+6d) |  | baseline start none → 2011-07-19; baseline finish none → 2011-07-22 |
| 974 | Cubicals Install | 2011-07-22 → 2011-07-27 (+5d) | 2011-07-24 → 2011-07-30 (+6d) |  | baseline start none → 2011-07-22; baseline finish none → 2011-07-25 |
| 975 | Fitting & Fixtures | 2011-07-25 → 2011-07-30 (+5d) | 2011-07-25 → 2011-07-31 (+6d) |  | baseline start none → 2011-07-25; baseline finish none → 2011-07-26 |
| 976 | False Ceiling Works | 2011-08-14 → 2011-08-19 (+5d) | 2011-09-05 → 2011-09-11 (+6d) |  | baseline start none → 2011-08-14; baseline finish none → 2011-09-06 |
| 977 | Paver Works | 2011-07-15 → 2011-07-20 (+5d) | 2011-07-29 → 2011-08-04 (+6d) |  | baseline start none → 2011-07-15; baseline finish none → 2011-07-30 |
| 978 | Sone/Wood/Glazing in Wall | 2011-07-23 → 2011-07-28 (+5d) | 2011-08-06 → 2011-08-11 (+5d) |  | baseline start none → 2011-07-23; baseline finish none → 2011-08-07 |
| 979 | Stair/Other Railing | 2011-07-22 → 2011-07-27 (+5d) | 2011-08-06 → 2011-08-11 (+5d) |  | baseline start none → 2011-07-22; baseline finish none → 2011-08-07 |
| 980 | Granite Flooring | 2011-08-08 → 2011-08-13 (+5d) | 2011-08-17 → 2011-08-23 (+6d) |  | baseline start none → 2011-08-08; baseline finish none → 2011-08-18 |
| 981 | Resin Floor | 2011-08-06 → 2011-08-11 (+5d) | 2011-08-20 → 2011-09-03 (+14d) |  | baseline start none → 2011-08-06; baseline finish none → 2011-08-21 |
| 982 | Fire Door Installation | 2011-08-17 → 2011-08-22 (+5d) | 2011-08-23 → 2011-09-06 (+14d) |  | baseline start none → 2011-08-17; baseline finish none → 2011-08-24 |
| 983 | Painting | 2011-08-13 → 2011-08-18 (+5d) | 2011-09-04 → 2011-09-10 (+6d) |  | baseline start none → 2011-08-13; baseline finish none → 2011-09-05 |
| 984 | **1ST FLOOR** | 2011-07-23 → 2011-07-28 (+5d) | 2011-09-21 → 2011-09-27 (+6d) |  | baseline start none → 2011-07-23; baseline finish none → 2011-09-22 |
| 985 | De-shuttering Roof Slab | 2011-07-23 → 2011-07-28 (+5d) | 2011-07-25 → 2011-07-31 (+6d) |  | baseline start none → 2011-07-23; baseline finish none → 2011-07-26 |
| 986 | Brick Work | 2011-07-26 → 2011-07-31 (+5d) | 2011-08-01 → 2011-08-07 (+6d) |  | baseline start none → 2011-07-26; baseline finish none → 2011-08-02 |
| 987 | Plaster | 2011-08-02 → 2011-08-07 (+5d) | 2011-08-08 → 2011-08-14 (+6d) |  | baseline start none → 2011-08-02; baseline finish none → 2011-08-09 |
| 988 | **Toilet Cubicals** | 2011-08-09 → 2011-08-14 (+5d) | 2011-08-19 → 2011-08-25 (+6d) |  | baseline start none → 2011-08-09; baseline finish none → 2011-08-20 |
| 989 | Water/ Sewarage Pipe Lines | 2011-08-09 → 2011-08-14 (+5d) | 2011-08-11 → 2011-08-17 (+6d) |  | baseline start none → 2011-08-09; baseline finish none → 2011-08-12 |
| 990 | Water Proofing Works | 2011-08-12 → 2011-08-17 (+5d) | 2011-08-12 → 2011-08-18 (+6d) |  | baseline start none → 2011-08-12; baseline finish none → 2011-08-13 |
| 991 | Tile Works/ Marble Top | 2011-08-13 → 2011-08-18 (+5d) | 2011-08-15 → 2011-08-21 (+6d) |  | baseline start none → 2011-08-13; baseline finish none → 2011-08-16 |
| 992 | Cubicals Install | 2011-08-16 → 2011-08-21 (+5d) | 2011-08-18 → 2011-08-24 (+6d) |  | baseline start none → 2011-08-16; baseline finish none → 2011-08-19 |
| 993 | Fitting & Fixtures | 2011-08-19 → 2011-08-24 (+5d) | 2011-08-19 → 2011-08-25 (+6d) |  | baseline start none → 2011-08-19; baseline finish none → 2011-08-20 |
| 994 | False Ceiling Works | 2011-08-25 → 2011-09-07 (+13d) | 2011-09-16 → 2011-09-22 (+6d) |  | baseline start none → 2011-08-25; baseline finish none → 2011-09-17 |
| 995 | Sone/Wood/Glazing in Wall | 2011-08-03 → 2011-08-08 (+5d) | 2011-08-17 → 2011-08-22 (+5d) |  | baseline start none → 2011-08-03; baseline finish none → 2011-08-18 |
| 996 | Stair/Other Railing | 2011-08-02 → 2011-08-07 (+5d) | 2011-08-17 → 2011-08-22 (+5d) |  | baseline start none → 2011-08-02; baseline finish none → 2011-08-18 |
| 997 | Granite Flooring | 2011-08-19 → 2011-08-24 (+5d) | 2011-09-05 → 2011-09-11 (+6d) |  | baseline start none → 2011-08-19; baseline finish none → 2011-09-06 |
| 998 | Resin Floor | 2011-08-17 → 2011-08-22 (+5d) | 2011-09-08 → 2011-09-14 (+6d) |  | baseline start none → 2011-08-17; baseline finish none → 2011-09-09 |
| 999 | Fire Door Installation | 2011-09-05 → 2011-09-10 (+5d) | 2011-09-11 → 2011-09-17 (+6d) |  | baseline start none → 2011-09-05; baseline finish none → 2011-09-12 |
| 1000 | Painting | 2011-09-07 → 2011-09-12 (+5d) | 2011-09-21 → 2011-09-27 (+6d) |  | baseline start none → 2011-09-07; baseline finish none → 2011-09-22 |
| 1001 | **2ND FLOOR** | 2011-08-17 → 2011-08-22 (+5d) | 2011-10-16 → 2011-10-22 (+6d) |  | baseline start none → 2011-08-17; baseline finish none → 2011-10-17 |
| 1002 | De-shuttering Roof Slab | 2011-08-17 → 2011-08-22 (+5d) | 2011-08-19 → 2011-08-25 (+6d) |  | baseline start none → 2011-08-17; baseline finish none → 2011-08-20 |
| 1003 | Brick Work | 2011-08-20 → 2011-08-25 (+5d) | 2011-09-03 → 2011-09-09 (+6d) |  | baseline start none → 2011-08-20; baseline finish none → 2011-09-04 |
| 1004 | Plaster | 2011-09-04 → 2011-09-09 (+5d) | 2011-09-10 → 2011-09-16 (+6d) |  | baseline start none → 2011-09-04; baseline finish none → 2011-09-11 |
| 1005 | **Toilet Cubicals** | 2011-09-11 → 2011-09-16 (+5d) | 2011-09-21 → 2011-09-27 (+6d) |  | baseline start none → 2011-09-11; baseline finish none → 2011-09-22 |
| 1006 | Water/ Sewarage Pipe Lines | 2011-09-11 → 2011-09-16 (+5d) | 2011-09-13 → 2011-09-19 (+6d) |  | baseline start none → 2011-09-11; baseline finish none → 2011-09-14 |
| 1007 | Water Proofing Works | 2011-09-14 → 2011-09-19 (+5d) | 2011-09-14 → 2011-09-20 (+6d) |  | baseline start none → 2011-09-14; baseline finish none → 2011-09-15 |
| 1008 | Tile Works/ Marble Top | 2011-09-15 → 2011-09-20 (+5d) | 2011-09-17 → 2011-09-23 (+6d) |  | baseline start none → 2011-09-15; baseline finish none → 2011-09-18 |
| 1009 | Cubicals Install | 2011-09-18 → 2011-09-23 (+5d) | 2011-09-20 → 2011-09-26 (+6d) |  | baseline start none → 2011-09-18; baseline finish none → 2011-09-21 |
| 1010 | Fitting & Fixtures | 2011-09-21 → 2011-09-26 (+5d) | 2011-09-21 → 2011-09-27 (+6d) |  | baseline start none → 2011-09-21; baseline finish none → 2011-09-22 |
| 1011 | False Ceiling Works | 2011-09-27 → 2011-10-02 (+5d) | 2011-10-11 → 2011-10-17 (+6d) |  | baseline start none → 2011-09-27; baseline finish none → 2011-10-12 |
| 1012 | Sone/Wood/Glazing in Wall | 2011-09-05 → 2011-09-10 (+5d) | 2011-09-19 → 2011-09-24 (+5d) |  | baseline start none → 2011-09-05; baseline finish none → 2011-09-20 |
| 1013 | Stair/Other Railing | 2011-09-04 → 2011-09-09 (+5d) | 2011-09-19 → 2011-09-24 (+5d) |  | baseline start none → 2011-09-04; baseline finish none → 2011-09-20 |
| 1014 | Granite Flooring | 2011-09-21 → 2011-09-26 (+5d) | 2011-09-30 → 2011-10-06 (+6d) |  | baseline start none → 2011-09-21; baseline finish none → 2011-10-01 |

| ID | Task | Start | Finish | Other |
| --- | --- | --- | --- | --- |
| 1015 | Resin Floor | 2011-09-19 → 2011-09-24 (+5d) | 2011-10-03 → 2011-10-09 (+6d) | baseline start none → 2011-09-19; baseline finish none → 2011-10-04 |
| 1016 | Fire Door Installation | 2011-09-30 → 2011-10-05 (+5d) | 2011-10-06 → 2011-10-12 (+6d) | baseline start none → 2011-09-30; baseline finish none → 2011-10-07 |
| 1017 | Painting | 2011-10-02 → 2011-10-07 (+5d) | 2011-10-16 → 2011-10-22 (+6d) | baseline start none → 2011-10-02; baseline finish none → 2011-10-17 |
| 1018 | **3RD FLOOR** | 2011-09-19 → 2011-09-24 (+5d) | 2011-11-10 → 2011-11-24 (+14d) | baseline start none → 2011-09-19; baseline finish none → 2011-11-19 |
| 1019 | De-shuttering Roof Slab | 2011-09-19 → 2011-09-24 (+5d) | 2011-09-21 → 2011-09-27 (+6d) | baseline start none → 2011-09-19; baseline finish none → 2011-09-22 |
| 1020 | Brick Work | 2011-09-22 → 2011-09-27 (+5d) | 2011-09-28 → 2011-10-04 (+6d) | baseline start none → 2011-09-22; baseline finish none → 2011-09-29 |
| 1021 | Plaster | 2011-09-29 → 2011-10-04 (+5d) | 2011-10-05 → 2011-10-11 (+6d) | baseline start none → 2011-09-29; baseline finish none → 2011-10-06 |
| 1022 | **Toilet Cubicals** | 2011-10-06 → 2011-10-11 (+5d) | 2011-10-16 → 2011-10-22 (+6d) | baseline start none → 2011-10-06; baseline finish none → 2011-10-17 |
| 1023 | Water/ Sewarage Pipe Lines | 2011-10-06 → 2011-10-11 (+5d) | 2011-10-08 → 2011-10-14 (+6d) | baseline start none → 2011-10-06; baseline finish none → 2011-10-09 |
| 1024 | Water Proofing Works | 2011-10-09 → 2011-10-14 (+5d) | 2011-10-09 → 2011-10-15 (+6d) | baseline start none → 2011-10-09; baseline finish none → 2011-10-10 |
| 1025 | Tile Works/ Marble Top | 2011-10-10 → 2011-10-15 (+5d) | 2011-10-12 → 2011-10-18 (+6d) | baseline start none → 2011-10-10; baseline finish none → 2011-10-13 |
| 1026 | Cubicals Install | 2011-10-13 → 2011-10-18 (+5d) | 2011-10-15 → 2011-10-21 (+6d) | baseline start none → 2011-10-13; baseline finish none → 2011-10-16 |
| 1027 | Fitting & Fixtures | 2011-10-16 → 2011-10-21 (+5d) | 2011-10-16 → 2011-10-22 (+6d) | baseline start none → 2011-10-16; baseline finish none → 2011-10-17 |
| 1028 | False Ceiling Works | 2011-10-22 → 2011-10-27 (+5d) | 2011-11-05 → 2011-11-19 (+14d) | baseline start none → 2011-10-22; baseline finish none → 2011-11-06 |
| 1029 | Sone/Wood/Glazing in Wall | 2011-09-30 → 2011-10-05 (+5d) | 2011-10-14 → 2011-10-19 (+5d) | baseline start none → 2011-09-30; baseline finish none → 2011-10-15 |
| 1030 | Stair/Other Railing | 2011-09-29 → 2011-10-04 (+5d) | 2011-10-14 → 2011-10-19 (+5d) | baseline start none → 2011-09-29; baseline finish none → 2011-10-15 |
| 1031 | Granite Flooring | 2011-10-16 → 2011-10-21 (+5d) | 2011-10-25 → 2011-10-31 (+6d) | baseline start none → 2011-10-16; baseline finish none → 2011-10-26 |
| 1032 | Resin Floor | 2011-10-14 → 2011-10-19 (+5d) | 2011-10-28 → 2011-11-03 (+6d) | baseline start none → 2011-10-14; baseline finish none → 2011-10-29 |
| 1033 | Fire Door Installation | 2011-10-25 → 2011-10-30 (+5d) | 2011-10-31 → 2011-11-06 (+6d) | baseline start none → 2011-10-25; baseline finish none → 2011-11-01 |
| 1034 | Painting | 2011-10-27 → 2011-11-01 (+5d) | 2011-11-10 → 2011-11-24 (+14d) | baseline start none → 2011-10-27; baseline finish none → 2011-11-19 |
| 1035 | **4TH FLOOR** | 2011-10-14 → 2011-10-19 (+5d) | 2011-12-13 → 2011-12-19 (+6d) | baseline start none → 2011-10-14; baseline finish none → 2011-12-14 |
| 1036 | De-shuttering Roof Slab | 2011-10-14 → 2011-10-19 (+5d) | 2011-10-16 → 2011-10-22 (+6d) | baseline start none → 2011-10-14; baseline finish none → 2011-10-17 |
| 1037 | Brick Work | 2011-10-17 → 2011-10-22 (+5d) | 2011-10-23 → 2011-10-29 (+6d) | baseline start none → 2011-10-17; baseline finish none → 2011-10-24 |
| 1038 | Plaster | 2011-10-24 → 2011-10-29 (+5d) | 2011-10-30 → 2011-11-05 (+6d) | baseline start none → 2011-10-24; baseline finish none → 2011-10-31 |
| 1039 | **Toilet Cubicals** | 2011-10-31 → 2011-11-05 (+5d) | 2011-11-10 → 2011-11-24 (+14d) | baseline start none → 2011-10-31; baseline finish none → 2011-11-19 |
| 1040 | Water/ Sewarage Pipe Lines | 2011-10-31 → 2011-11-05 (+5d) | 2011-11-02 → 2011-11-08 (+6d) | baseline start none → 2011-10-31; baseline finish none → 2011-11-03 |
| 1041 | Water Proofing Works | 2011-11-03 → 2011-11-08 (+5d) | 2011-11-03 → 2011-11-09 (+6d) | baseline start none → 2011-11-03; baseline finish none → 2011-11-04 |
| 1042 | Tile Works/ Marble Top | 2011-11-04 → 2011-11-09 (+5d) | 2011-11-06 → 2011-11-20 (+14d) | baseline start none → 2011-11-04; baseline finish none → 2011-11-07 |
| 1043 | Cubicals Install | 2011-11-07 → 2011-11-20 (+13d) | 2011-11-09 → 2011-11-23 (+14d) | baseline start none → 2011-11-07; baseline finish none → 2011-11-10 |
| 1044 | Fitting & Fixtures | 2011-11-10 → 2011-11-23 (+13d) | 2011-11-10 → 2011-11-24 (+14d) | baseline start none → 2011-11-10; baseline finish none → 2011-11-19 |
| 1045 | False Ceiling Works | 2011-11-24 → 2011-11-29 (+5d) | 2011-12-08 → 2011-12-14 (+6d) | baseline start none → 2011-11-24; baseline finish none → 2011-12-09 |
| 1046 | Sone/Wood/Glazing in Wall | 2011-10-25 → 2011-10-30 (+5d) | 2011-11-08 → 2011-11-21 (+13d) | baseline start none → 2011-10-25; baseline finish none → 2011-11-09 |
| 1047 | Stair/Other Railing | 2011-10-24 → 2011-10-29 (+5d) | 2011-11-08 → 2011-11-21 (+13d) | baseline start none → 2011-10-24; baseline finish none → 2011-11-09 |
| 1048 | Granite Flooring | 2011-11-10 → 2011-11-23 (+13d) | 2011-11-27 → 2011-12-03 (+6d) | baseline start none → 2011-11-10; baseline finish none → 2011-11-28 |
| 1049 | Resin Floor | 2011-11-08 → 2011-11-21 (+13d) | 2011-11-30 → 2011-12-06 (+6d) | baseline start none → 2011-11-08; baseline finish none → 2011-12-01 |
| 1050 | Fire Door Installation | 2011-11-27 → 2011-12-02 (+5d) | 2011-12-03 → 2011-12-09 (+6d) | baseline start none → 2011-11-27; baseline finish none → 2011-12-04 |
| 1051 | Painting | 2011-11-29 → 2011-12-04 (+5d) | 2011-12-13 → 2011-12-19 (+6d) | baseline start none → 2011-11-29; baseline finish none → 2011-12-14 |
| 1052 | **5TH FLOOR** | 2011-11-08 → 2011-11-21 (+13d) | 2012-01-07 → 2012-01-13 (+6d) | baseline start none → 2011-11-08; baseline finish none → 2012-01-08 |
| 1053 | De-shuttering Roof Slab | 2011-11-08 → 2011-11-21 (+13d) | 2011-11-10 → 2011-11-24 (+14d) | baseline start none → 2011-11-08; baseline finish none → 2011-11-19 |
| 1054 | Brick Work | 2011-11-19 → 2011-11-24 (+5d) | 2011-11-25 → 2011-12-01 (+6d) | baseline start none → 2011-11-19; baseline finish none → 2011-11-26 |
| 1055 | Plaster | 2011-11-26 → 2011-12-01 (+5d) | 2011-12-02 → 2011-12-08 (+6d) | baseline start none → 2011-11-26; baseline finish none → 2011-12-03 |
| 1056 | **Toilet Cubicals** | 2011-12-03 → 2011-12-08 (+5d) | 2011-12-13 → 2011-12-19 (+6d) | baseline start none → 2011-12-03; baseline finish none → 2011-12-14 |
| 1057 | Water/ Sewarage Pipe Lines | 2011-12-03 → 2011-12-08 (+5d) | 2011-12-05 → 2011-12-11 (+6d) | baseline start none → 2011-12-03; baseline finish none → 2011-12-06 |
| 1058 | Water Proofing Works | 2011-12-06 → 2011-12-11 (+5d) | 2011-12-06 → 2011-12-12 (+6d) | baseline start none → 2011-12-06; baseline finish none → 2011-12-07 |
| 1059 | Tile Works/ Marble Top | 2011-12-07 → 2011-12-12 (+5d) | 2011-12-09 → 2011-12-15 (+6d) | baseline start none → 2011-12-07; baseline finish none → 2011-12-10 |
| 1060 | Cubicals Install | 2011-12-10 → 2011-12-15 (+5d) | 2011-12-12 → 2011-12-18 (+6d) | baseline start none → 2011-12-10; baseline finish none → 2011-12-13 |
| 1061 | Fitting & Fixtures | 2011-12-13 → 2011-12-18 (+5d) | 2011-12-13 → 2011-12-19 (+6d) | baseline start none → 2011-12-13; baseline finish none → 2011-12-14 |
| 1062 | False Ceiling Works | 2011-12-19 → 2011-12-24 (+5d) | 2012-01-02 → 2012-01-08 (+6d) | baseline start none → 2011-12-19; baseline finish none → 2012-01-03 |
| 1063 | Sone/Wood/Glazing in Wall | 2011-11-27 → 2011-12-02 (+5d) | 2011-12-11 → 2011-12-16 (+5d) | baseline start none → 2011-11-27; baseline finish none → 2011-12-12 |
| 1064 | Stair/Other Railing | 2011-11-26 → 2011-12-01 (+5d) | 2011-12-11 → 2011-12-16 (+5d) | baseline start none → 2011-11-26; baseline finish none → 2011-12-12 |
| 1065 | Granite Flooring | 2011-12-13 → 2011-12-18 (+5d) | 2011-12-22 → 2011-12-28 (+6d) | baseline start none → 2011-12-13; baseline finish none → 2011-12-23 |
| 1066 | Resin Floor | 2011-12-11 → 2011-12-16 (+5d) | 2011-12-25 → 2011-12-31 (+6d) | baseline start none → 2011-12-11; baseline finish none → 2011-12-26 |
| 1067 | Fire Door Installation | 2011-12-22 → 2011-12-27 (+5d) | 2011-12-28 → 2012-01-03 (+6d) | baseline start none → 2011-12-22; baseline finish none → 2011-12-29 |
| 1068 | Painting | 2011-12-24 → 2011-12-29 (+5d) | 2012-01-07 → 2012-01-13 (+6d) | baseline start none → 2011-12-24; baseline finish none → 2012-01-08 |
| 1069 | **6TH FLOOR** | 2011-12-11 → 2011-12-16 (+5d) | 2012-02-01 → 2012-02-07 (+6d) | baseline start none → 2011-12-11; baseline finish none → 2012-02-02 |
| 1070 | De-shuttering Roof Slab | 2011-12-11 → 2011-12-16 (+5d) | 2011-12-13 → 2011-12-19 (+6d) | baseline start none → 2011-12-11; baseline finish none → 2011-12-14 |
| 1071 | Brick Work | 2011-12-14 → 2011-12-19 (+5d) | 2011-12-20 → 2011-12-26 (+6d) | baseline start none → 2011-12-14; baseline finish none → 2011-12-21 |
| 1072 | Plaster | 2011-12-21 → 2011-12-26 (+5d) | 2011-12-27 → 2012-01-02 (+6d) | baseline start none → 2011-12-21; baseline finish none → 2011-12-28 |
| 1073 | **Toilet Cubicals** | 2011-12-28 → 2012-01-02 (+5d) | 2012-01-07 → 2012-01-13 (+6d) | baseline start none → 2011-12-28; baseline finish none → 2012-01-08 |
| 1074 | Water/ Sewarage Pipe Lines | 2011-12-28 → 2012-01-02 (+5d) | 2011-12-30 → 2012-01-05 (+6d) | baseline start none → 2011-12-28; baseline finish none → 2011-12-31 |
| 1075 | Water Proofing Works | 2011-12-31 → 2012-01-05 (+5d) | 2011-12-31 → 2012-01-06 (+6d) | baseline start none → 2011-12-31; baseline finish none → 2012-01-01 |
| 1076 | Tile Works/ Marble Top | 2012-01-01 → 2012-01-06 (+5d) | 2012-01-03 → 2012-01-09 (+6d) | baseline start none → 2012-01-01; baseline finish none → 2012-01-04 |
| 1077 | Cubicals Install | 2012-01-04 → 2012-01-09 (+5d) | 2012-01-06 → 2012-01-12 (+6d) | baseline start none → 2012-01-04; baseline finish none → 2012-01-07 |
| 1078 | Fitting & Fixtures | 2012-01-07 → 2012-01-12 (+5d) | 2012-01-07 → 2012-01-13 (+6d) | baseline start none → 2012-01-07; baseline finish none → 2012-01-08 |
| 1079 | False Ceiling Works | 2012-01-13 → 2012-01-18 (+5d) | 2012-01-27 → 2012-02-02 (+6d) | baseline start none → 2012-01-13; baseline finish none → 2012-01-28 |
| 1080 | Sone/Wood/Glazing in Wall | 2011-12-22 → 2011-12-27 (+5d) | 2012-01-05 → 2012-01-10 (+5d) | baseline start none → 2011-12-22; baseline finish none → 2012-01-06 |
| 1081 | Stair/Other Railing | 2011-12-21 → 2011-12-26 (+5d) | 2012-01-05 → 2012-01-10 (+5d) | baseline start none → 2011-12-21; baseline finish none → 2012-01-06 |
| 1082 | Granite Flooring | 2012-01-07 → 2012-01-12 (+5d) | 2012-01-16 → 2012-01-22 (+6d) | baseline start none → 2012-01-07; baseline finish none → 2012-01-17 |
| 1083 | Resin Floor | 2012-01-05 → 2012-01-10 (+5d) | 2012-01-19 → 2012-01-25 (+6d) | baseline start none → 2012-01-05; baseline finish none → 2012-01-20 |
| 1084 | Fire Door Installation | 2012-01-16 → 2012-01-21 (+5d) | 2012-01-22 → 2012-01-28 (+6d) | baseline start none → 2012-01-16; baseline finish none → 2012-01-23 |

| ID | Task | Start | Finish | Other |
| --- | --- | --- | --- | --- |
| 1085 | Painting | 2012-01-18 → 2012-01-23 (+5d) | 2012-02-01 → 2012-02-07 (+6d) | baseline start none → 2012-01-18; baseline finish none → 2012-02-02 |
| 1086 | **7TH FLOOR** | 2012-01-05 → 2012-01-10 (+5d) | 2012-02-26 → 2012-03-03 (+6d) | baseline start none → 2012-01-05; baseline finish none → 2012-02-27 |
| 1087 | De-shuttering Roof Slab | 2012-01-05 → 2012-01-10 (+5d) | 2012-01-07 → 2012-01-13 (+6d) | baseline start none → 2012-01-05; baseline finish none → 2012-01-08 |
| 1088 | Brick Work | 2012-01-08 → 2012-01-13 (+5d) | 2012-01-14 → 2012-01-20 (+6d) | baseline start none → 2012-01-08; baseline finish none → 2012-01-15 |
| 1089 | Plaster | 2012-01-15 → 2012-01-20 (+5d) | 2012-01-21 → 2012-01-27 (+6d) | baseline start none → 2012-01-15; baseline finish none → 2012-01-22 |
| 1090 | **Toilet Cubicals** | 2012-01-22 → 2012-01-27 (+5d) | 2012-02-01 → 2012-02-07 (+6d) | baseline start none → 2012-01-22; baseline finish none → 2012-02-02 |
| 1091 | Water/ Sewarage Pipe Lines | 2012-01-22 → 2012-01-27 (+5d) | 2012-01-24 → 2012-01-30 (+6d) | baseline start none → 2012-01-22; baseline finish none → 2012-01-25 |
| 1092 | Water Proofing Works | 2012-01-25 → 2012-01-30 (+5d) | 2012-01-25 → 2012-01-31 (+6d) | baseline start none → 2012-01-25; baseline finish none → 2012-01-26 |
| 1093 | Tile Works/ Marble Top | 2012-01-26 → 2012-01-31 (+5d) | 2012-01-28 → 2012-02-03 (+6d) | baseline start none → 2012-01-26; baseline finish none → 2012-01-29 |
| 1094 | Cubicals Install | 2012-01-29 → 2012-02-03 (+5d) | 2012-01-31 → 2012-02-06 (+6d) | baseline start none → 2012-01-29; baseline finish none → 2012-02-01 |
| 1095 | Fitting & Fixtures | 2012-02-01 → 2012-02-06 (+5d) | 2012-02-01 → 2012-02-07 (+6d) | baseline start none → 2012-02-01; baseline finish none → 2012-02-02 |
| 1096 | False Ceiling Works | 2012-02-07 → 2012-02-12 (+5d) | 2012-02-21 → 2012-02-27 (+6d) | baseline start none → 2012-02-07; baseline finish none → 2012-02-22 |
| 1097 | Sone/Wood/Glazing in Wall | 2012-01-16 → 2012-01-21 (+5d) | 2012-01-30 → 2012-02-04 (+5d) | baseline start none → 2012-01-16; baseline finish none → 2012-01-31 |
| 1098 | Stair/Other Railing | 2012-01-15 → 2012-01-20 (+5d) | 2012-01-30 → 2012-02-04 (+5d) | baseline start none → 2012-01-15; baseline finish none → 2012-01-31 |
| 1099 | Granite Flooring | 2012-02-01 → 2012-02-06 (+5d) | 2012-02-10 → 2012-02-16 (+6d) | baseline start none → 2012-02-01; baseline finish none → 2012-02-11 |
| 1100 | Resin Floor | 2012-01-30 → 2012-02-04 (+5d) | 2012-02-13 → 2012-02-19 (+6d) | baseline start none → 2012-01-30; baseline finish none → 2012-02-14 |
| 1101 | Fire Door Installation | 2012-02-10 → 2012-02-15 (+5d) | 2012-02-16 → 2012-02-22 (+6d) | baseline start none → 2012-02-10; baseline finish none → 2012-02-17 |
| 1102 | Painting | 2012-02-12 → 2012-02-17 (+5d) | 2012-02-26 → 2012-03-03 (+6d) | baseline start none → 2012-02-12; baseline finish none → 2012-02-27 |
| 1103 | **8TH FLOOR** | 2012-02-11 → 2012-02-16 (+5d) | 2012-04-03 → 2012-04-09 (+6d) | baseline start none → 2012-02-11; baseline finish none → 2012-04-04 |
| 1104 | De-shuttering Roof Slab | 2012-02-11 → 2012-02-16 (+5d) | 2012-02-13 → 2012-02-19 (+6d) | baseline start none → 2012-02-11; baseline finish none → 2012-02-14 |
| 1105 | Brick Work | 2012-02-14 → 2012-02-19 (+5d) | 2012-02-20 → 2012-02-26 (+6d) | baseline start none → 2012-02-14; baseline finish none → 2012-02-21 |
| 1106 | Plaster | 2012-02-21 → 2012-02-26 (+5d) | 2012-02-27 → 2012-03-04 (+6d) | baseline start none → 2012-02-21; baseline finish none → 2012-02-28 |
| 1107 | **Toilet Cubicals** | 2012-02-28 → 2012-03-04 (+5d) | 2012-03-09 → 2012-03-15 (+6d) | baseline start none → 2012-02-28; baseline finish none → 2012-03-10 |
| 1108 | Water/ Sewarage Pipe Lines | 2012-02-28 → 2012-03-04 (+5d) | 2012-03-01 → 2012-03-07 (+6d) | baseline start none → 2012-02-28; baseline finish none → 2012-03-02 |
| 1109 | Water Proofing Works | 2012-03-02 → 2012-03-07 (+5d) | 2012-03-02 → 2012-03-08 (+6d) | baseline start none → 2012-03-02; baseline finish none → 2012-03-03 |
| 1110 | Tile Works/ Marble Top | 2012-03-03 → 2012-03-08 (+5d) | 2012-03-05 → 2012-03-11 (+6d) | baseline start none → 2012-03-03; baseline finish none → 2012-03-06 |
| 1111 | Cubicals Install | 2012-03-06 → 2012-03-11 (+5d) | 2012-03-08 → 2012-03-14 (+6d) | baseline start none → 2012-03-06; baseline finish none → 2012-03-09 |
| 1112 | Fitting & Fixtures | 2012-03-09 → 2012-03-14 (+5d) | 2012-03-09 → 2012-03-15 (+6d) | baseline start none → 2012-03-09; baseline finish none → 2012-03-10 |
| 1113 | False Ceiling Works | 2012-03-15 → 2012-03-20 (+5d) | 2012-03-29 → 2012-04-04 (+6d) | baseline start none → 2012-03-15; baseline finish none → 2012-03-30 |
| 1114 | Sone/Wood/Glazing in Wall | 2012-02-22 → 2012-02-27 (+5d) | 2012-03-07 → 2012-03-12 (+5d) | baseline start none → 2012-02-22; baseline finish none → 2012-03-08 |
| 1115 | Stair/Other Railing | 2012-02-21 → 2012-02-26 (+5d) | 2012-03-07 → 2012-03-12 (+5d) | baseline start none → 2012-02-21; baseline finish none → 2012-03-08 |
| 1116 | Granite Flooring | 2012-03-09 → 2012-03-14 (+5d) | 2012-03-18 → 2012-03-24 (+6d) | baseline start none → 2012-03-09; baseline finish none → 2012-03-19 |
| 1117 | Resin Floor | 2012-03-07 → 2012-03-12 (+5d) | 2012-03-21 → 2012-03-27 (+6d) | baseline start none → 2012-03-07; baseline finish none → 2012-03-22 |
| 1118 | Fire Door Installation | 2012-03-18 → 2012-03-23 (+5d) | 2012-03-24 → 2012-03-30 (+6d) | baseline start none → 2012-03-18; baseline finish none → 2012-03-25 |
| 1119 | Painting | 2012-03-20 → 2012-03-25 (+5d) | 2012-04-03 → 2012-04-09 (+6d) | baseline start none → 2012-03-20; baseline finish none → 2012-04-04 |
| 1120 | **9TH FLOOR** | 2012-02-24 → 2012-02-29 (+5d) | 2012-04-16 → 2012-04-22 (+6d) | baseline start none → 2012-02-24; baseline finish none → 2012-04-17 |
| 1121 | De-shuttering Roof Slab | 2012-02-24 → 2012-02-29 (+5d) | 2012-02-26 → 2012-03-03 (+6d) | baseline start none → 2012-02-24; baseline finish none → 2012-02-27 |
| 1122 | Brick Work | 2012-02-27 → 2012-03-03 (+5d) | 2012-03-04 → 2012-03-10 (+6d) | baseline start none → 2012-02-27; baseline finish none → 2012-03-05 |
| 1123 | Plaster | 2012-03-05 → 2012-03-10 (+5d) | 2012-03-11 → 2012-03-17 (+6d) | baseline start none → 2012-03-05; baseline finish none → 2012-03-12 |
| 1124 | **Toilet Cubicals** | 2012-03-12 → 2012-03-17 (+5d) | 2012-03-22 → 2012-03-28 (+6d) | baseline start none → 2012-03-12; baseline finish none → 2012-03-23 |
| 1125 | Water/ Sewarage Pipe Lines | 2012-03-12 → 2012-03-17 (+5d) | 2012-03-14 → 2012-03-20 (+6d) | baseline start none → 2012-03-12; baseline finish none → 2012-03-15 |
| 1126 | Water Proofing Works | 2012-03-15 → 2012-03-20 (+5d) | 2012-03-15 → 2012-03-21 (+6d) | baseline start none → 2012-03-15; baseline finish none → 2012-03-16 |
| 1127 | Tile Works/ Marble Top | 2012-03-16 → 2012-03-21 (+5d) | 2012-03-18 → 2012-03-24 (+6d) | baseline start none → 2012-03-16; baseline finish none → 2012-03-19 |
| 1128 | Cubicals Install | 2012-03-19 → 2012-03-24 (+5d) | 2012-03-21 → 2012-03-27 (+6d) | baseline start none → 2012-03-19; baseline finish none → 2012-03-22 |
| 1129 | Fitting & Fixtures | 2012-03-22 → 2012-03-27 (+5d) | 2012-03-22 → 2012-03-28 (+6d) | baseline start none → 2012-03-22; baseline finish none → 2012-03-23 |
| 1130 | False Ceiling Works | 2012-03-28 → 2012-04-02 (+5d) | 2012-04-11 → 2012-04-17 (+6d) | baseline start none → 2012-03-28; baseline finish none → 2012-04-12 |
| 1131 | Sone/Wood/Glazing in Wall | 2012-03-06 → 2012-03-11 (+5d) | 2012-03-20 → 2012-03-25 (+5d) | baseline start none → 2012-03-06; baseline finish none → 2012-03-21 |
| 1132 | Stair/Other Railing | 2012-03-05 → 2012-03-10 (+5d) | 2012-03-20 → 2012-03-25 (+5d) | baseline start none → 2012-03-05; baseline finish none → 2012-03-21 |
| 1133 | Granite Flooring | 2012-03-22 → 2012-03-27 (+5d) | 2012-03-31 → 2012-04-06 (+6d) | baseline start none → 2012-03-22; baseline finish none → 2012-04-01 |
| 1134 | Resin Floor | 2012-03-20 → 2012-03-25 (+5d) | 2012-04-03 → 2012-04-09 (+6d) | baseline start none → 2012-03-20; baseline finish none → 2012-04-04 |
| 1135 | Fire Door Installation | 2012-03-31 → 2012-04-05 (+5d) | 2012-04-06 → 2012-04-12 (+6d) | baseline start none → 2012-03-31; baseline finish none → 2012-04-07 |
| 1136 | Painting | 2012-04-02 → 2012-04-07 (+5d) | 2012-04-16 → 2012-04-22 (+6d) | baseline start none → 2012-04-02; baseline finish none → 2012-04-17 |
| 1137 | **10TH FLOOR** | 2012-03-20 → 2012-03-25 (+5d) | 2012-05-11 → 2012-05-17 (+6d) | baseline start none → 2012-03-20; baseline finish none → 2012-05-12 |
| 1138 | De-shuttering Roof Slab | 2012-03-20 → 2012-03-25 (+5d) | 2012-03-22 → 2012-03-28 (+6d) | baseline start none → 2012-03-20; baseline finish none → 2012-03-23 |
| 1139 | Brick Work | 2012-03-23 → 2012-03-28 (+5d) | 2012-03-29 → 2012-04-04 (+6d) | baseline start none → 2012-03-23; baseline finish none → 2012-03-30 |
| 1140 | Plaster | 2012-03-30 → 2012-04-04 (+5d) | 2012-04-05 → 2012-04-11 (+6d) | baseline start none → 2012-03-30; baseline finish none → 2012-04-06 |
| 1141 | **Toilet Cubicals** | 2012-04-06 → 2012-04-11 (+5d) | 2012-04-16 → 2012-04-22 (+6d) | baseline start none → 2012-04-06; baseline finish none → 2012-04-17 |
| 1142 | Water/ Sewarage Pipe Lines | 2012-04-06 → 2012-04-11 (+5d) | 2012-04-08 → 2012-04-14 (+6d) | baseline start none → 2012-04-06; baseline finish none → 2012-04-09 |
| 1143 | Water Proofing Works | 2012-04-09 → 2012-04-14 (+5d) | 2012-04-09 → 2012-04-15 (+6d) | baseline start none → 2012-04-09; baseline finish none → 2012-04-10 |
| 1144 | Tile Works/ Marble Top | 2012-04-10 → 2012-04-15 (+5d) | 2012-04-12 → 2012-04-18 (+6d) | baseline start none → 2012-04-10; baseline finish none → 2012-04-13 |
| 1145 | Cubicals Install | 2012-04-13 → 2012-04-18 (+5d) | 2012-04-15 → 2012-04-21 (+6d) | baseline start none → 2012-04-13; baseline finish none → 2012-04-16 |
| 1146 | Fitting & Fixtures | 2012-04-16 → 2012-04-21 (+5d) | 2012-04-16 → 2012-04-22 (+6d) | baseline start none → 2012-04-16; baseline finish none → 2012-04-17 |
| 1147 | False Ceiling Works | 2012-04-22 → 2012-04-27 (+5d) | 2012-05-06 → 2012-05-12 (+6d) | baseline start none → 2012-04-22; baseline finish none → 2012-05-07 |
| 1148 | Sone/Wood/Glazing in Wall | 2012-03-31 → 2012-04-05 (+5d) | 2012-04-14 → 2012-04-19 (+5d) | baseline start none → 2012-03-31; baseline finish none → 2012-04-15 |
| 1149 | Stair/Other Railing | 2012-03-30 → 2012-04-04 (+5d) | 2012-04-14 → 2012-04-19 (+5d) | baseline start none → 2012-03-30; baseline finish none → 2012-04-15 |
| 1150 | Granite Flooring | 2012-04-16 → 2012-04-21 (+5d) | 2012-04-25 → 2012-05-01 (+6d) | baseline start none → 2012-04-16; baseline finish none → 2012-04-26 |
| 1151 | Resin Floor | 2012-04-14 → 2012-04-19 (+5d) | 2012-04-28 → 2012-05-04 (+6d) | baseline start none → 2012-04-14; baseline finish none → 2012-04-29 |
| 1152 | Fire Door Installation | 2012-04-25 → 2012-04-30 (+5d) | 2012-05-01 → 2012-05-07 (+6d) | baseline start none → 2012-04-25; baseline finish none → 2012-05-02 |
| 1153 | Painting | 2012-04-27 → 2012-05-02 (+5d) | 2012-05-11 → 2012-05-17 (+6d) | baseline start none → 2012-04-27; baseline finish none → 2012-05-12 |
| 1154 | **11TH FLOOR** | 2012-04-14 → 2012-04-19 (+5d) | 2012-06-05 → 2012-06-11 (+6d) | baseline start none → 2012-04-14; baseline finish none → 2012-06-06 |

| ID | Task | Start | Finish | Other |
| --- | --- | --- | --- | --- |
| 1155 | De-shuttering Roof Slab | 2012-04-14 → 2012-04-19 (+5d) | 2012-04-16 → 2012-04-22 (+6d) | baseline start none → 2012-04-14; baseline finish none → 2012-04-17 |
| 1156 | Brick Work | 2012-04-17 → 2012-04-22 (+5d) | 2012-04-23 → 2012-04-29 (+6d) | baseline start none → 2012-04-17; baseline finish none → 2012-04-24 |
| 1157 | Plaster | 2012-04-24 → 2012-04-29 (+5d) | 2012-04-30 → 2012-05-06 (+6d) | baseline start none → 2012-04-24; baseline finish none → 2012-05-01 |
| 1158 | **Toilet Cubicals** | 2012-05-01 → 2012-05-06 (+5d) | 2012-05-11 → 2012-05-17 (+6d) | baseline start none → 2012-05-01; baseline finish none → 2012-05-12 |
| 1159 | Water/ Sewarage Pipe Lines | 2012-05-01 → 2012-05-06 (+5d) | 2012-05-03 → 2012-05-09 (+6d) | baseline start none → 2012-05-01; baseline finish none → 2012-05-04 |
| 1160 | Water Proofing Works | 2012-05-04 → 2012-05-09 (+5d) | 2012-05-04 → 2012-05-10 (+6d) | baseline start none → 2012-05-04; baseline finish none → 2012-05-05 |
| 1161 | Tile Works/ Marble Top | 2012-05-05 → 2012-05-10 (+5d) | 2012-05-07 → 2012-05-13 (+6d) | baseline start none → 2012-05-05; baseline finish none → 2012-05-08 |
| 1162 | Cubicals Install | 2012-05-08 → 2012-05-13 (+5d) | 2012-05-10 → 2012-05-16 (+6d) | baseline start none → 2012-05-08; baseline finish none → 2012-05-11 |
| 1163 | Fitting & Fixtures | 2012-05-11 → 2012-05-16 (+5d) | 2012-05-11 → 2012-05-17 (+6d) | baseline start none → 2012-05-11; baseline finish none → 2012-05-12 |
| 1164 | False Ceiling Works | 2012-05-17 → 2012-05-22 (+5d) | 2012-05-31 → 2012-06-06 (+6d) | baseline start none → 2012-05-17; baseline finish none → 2012-06-01 |
| 1165 | Sone/Wood/Glazing in Wall | 2012-04-25 → 2012-04-30 (+5d) | 2012-05-09 → 2012-05-14 (+5d) | baseline start none → 2012-04-25; baseline finish none → 2012-05-10 |
| 1166 | Stair/Other Railing | 2012-04-24 → 2012-04-29 (+5d) | 2012-05-09 → 2012-05-14 (+5d) | baseline start none → 2012-04-24; baseline finish none → 2012-05-10 |
| 1167 | Granite Flooring | 2012-05-11 → 2012-05-16 (+5d) | 2012-05-20 → 2012-05-26 (+6d) | baseline start none → 2012-05-11; baseline finish none → 2012-05-21 |
| 1168 | Resin Floor | 2012-05-09 → 2012-05-14 (+5d) | 2012-05-23 → 2012-05-29 (+6d) | baseline start none → 2012-05-09; baseline finish none → 2012-05-24 |
| 1169 | Fire Door Installation | 2012-05-20 → 2012-05-25 (+5d) | 2012-05-26 → 2012-06-01 (+6d) | baseline start none → 2012-05-20; baseline finish none → 2012-05-27 |
| 1170 | Painting | 2012-05-22 → 2012-05-27 (+5d) | 2012-06-05 → 2012-06-11 (+6d) | baseline start none → 2012-05-22; baseline finish none → 2012-06-06 |
| 1171 | **12TH FLOOR** | 2012-05-09 → 2012-05-14 (+5d) | 2012-06-30 → 2012-07-06 (+6d) | baseline start none → 2012-05-09; baseline finish none → 2012-07-01 |
| 1172 | De-shuttering Roof Slab | 2012-05-09 → 2012-05-14 (+5d) | 2012-05-11 → 2012-05-17 (+6d) | baseline start none → 2012-05-09; baseline finish none → 2012-05-12 |
| 1173 | Brick Work | 2012-05-12 → 2012-05-17 (+5d) | 2012-05-18 → 2012-05-24 (+6d) | baseline start none → 2012-05-12; baseline finish none → 2012-05-19 |
| 1174 | Plaster | 2012-05-19 → 2012-05-24 (+5d) | 2012-05-25 → 2012-05-31 (+6d) | baseline start none → 2012-05-19; baseline finish none → 2012-05-26 |
| 1175 | **Toilet Cubicals** | 2012-05-26 → 2012-05-31 (+5d) | 2012-06-05 → 2012-06-11 (+6d) | baseline start none → 2012-05-26; baseline finish none → 2012-06-06 |
| 1176 | Water/ Sewarage Pipe Lines | 2012-05-26 → 2012-05-31 (+5d) | 2012-05-28 → 2012-06-03 (+6d) | baseline start none → 2012-05-26; baseline finish none → 2012-05-29 |
| 1177 | Water Proofing Works | 2012-05-29 → 2012-06-03 (+5d) | 2012-05-29 → 2012-06-04 (+6d) | baseline start none → 2012-05-29; baseline finish none → 2012-05-30 |
| 1178 | Tile Works/ Marble Top | 2012-05-30 → 2012-06-04 (+5d) | 2012-06-01 → 2012-06-07 (+6d) | baseline start none → 2012-05-30; baseline finish none → 2012-06-02 |
| 1179 | Cubicals Install | 2012-06-02 → 2012-06-07 (+5d) | 2012-06-04 → 2012-06-10 (+6d) | baseline start none → 2012-06-02; baseline finish none → 2012-06-05 |
| 1180 | Fitting & Fixtures | 2012-06-05 → 2012-06-10 (+5d) | 2012-06-05 → 2012-06-11 (+6d) | baseline start none → 2012-06-05; baseline finish none → 2012-06-06 |
| 1181 | False Ceiling Works | 2012-06-11 → 2012-06-16 (+5d) | 2012-06-25 → 2012-07-01 (+6d) | baseline start none → 2012-06-11; baseline finish none → 2012-06-26 |
| 1182 | Sone/Wood/Glazing in Wall | 2012-05-20 → 2012-05-25 (+5d) | 2012-06-03 → 2012-06-08 (+5d) | baseline start none → 2012-05-20; baseline finish none → 2012-06-04 |
| 1183 | Stair/Other Railing | 2012-05-19 → 2012-05-24 (+5d) | 2012-06-03 → 2012-06-08 (+5d) | baseline start none → 2012-05-19; baseline finish none → 2012-06-04 |
| 1184 | Granite Flooring | 2012-06-05 → 2012-06-10 (+5d) | 2012-06-14 → 2012-06-20 (+6d) | baseline start none → 2012-06-05; baseline finish none → 2012-06-15 |
| 1185 | Resin Floor | 2012-06-03 → 2012-06-08 (+5d) | 2012-06-17 → 2012-06-23 (+6d) | baseline start none → 2012-06-03; baseline finish none → 2012-06-18 |
| 1186 | Fire Door Installation | 2012-06-14 → 2012-06-19 (+5d) | 2012-06-20 → 2012-06-26 (+6d) | baseline start none → 2012-06-14; baseline finish none → 2012-06-21 |
| 1187 | Painting | 2012-06-16 → 2012-06-21 (+5d) | 2012-06-30 → 2012-07-06 (+6d) | baseline start none → 2012-06-16; baseline finish none → 2012-07-01 |
| 1188 | **13TH FLOOR** | 2012-06-03 → 2012-06-08 (+5d) | 2012-07-20 → 2012-07-26 (+6d) | baseline start none → 2012-06-03; baseline finish none → 2012-07-21 |
| 1189 | De-shuttering Roof Slab | 2012-06-03 → 2012-06-08 (+5d) | 2012-06-05 → 2012-06-11 (+6d) | baseline start none → 2012-06-03; baseline finish none → 2012-06-06 |
| 1190 | Brick Work | 2012-06-06 → 2012-06-11 (+5d) | 2012-06-12 → 2012-06-18 (+6d) | baseline start none → 2012-06-06; baseline finish none → 2012-06-13 |
| 1191 | Plaster | 2012-06-13 → 2012-06-18 (+5d) | 2012-06-19 → 2012-06-25 (+6d) | baseline start none → 2012-06-13; baseline finish none → 2012-06-20 |
| 1192 | **Toilet Cubicals** | 2012-06-20 → 2012-06-25 (+5d) | 2012-06-30 → 2012-07-06 (+6d) | baseline start none → 2012-06-20; baseline finish none → 2012-07-01 |
| 1193 | Water/ Sewarage Pipe Lines | 2012-06-20 → 2012-06-25 (+5d) | 2012-06-22 → 2012-06-28 (+6d) | baseline start none → 2012-06-20; baseline finish none → 2012-06-23 |
| 1194 | Water Proofing Works | 2012-06-23 → 2012-06-28 (+5d) | 2012-06-23 → 2012-06-29 (+6d) | baseline start none → 2012-06-23; baseline finish none → 2012-06-24 |
| 1195 | Tile Works/ Marble Top | 2012-06-24 → 2012-06-29 (+5d) | 2012-06-26 → 2012-07-02 (+6d) | baseline start none → 2012-06-24; baseline finish none → 2012-06-27 |
| 1196 | Cubicals Install | 2012-06-27 → 2012-07-02 (+5d) | 2012-06-29 → 2012-07-05 (+6d) | baseline start none → 2012-06-27; baseline finish none → 2012-06-30 |
| 1197 | Fitting & Fixtures | 2012-06-30 → 2012-07-05 (+5d) | 2012-06-30 → 2012-07-06 (+6d) | baseline start none → 2012-06-30; baseline finish none → 2012-07-01 |
| 1198 | False Ceiling Works | 2012-07-06 → 2012-07-11 (+5d) | 2012-07-20 → 2012-07-26 (+6d) | baseline start none → 2012-07-06; baseline finish none → 2012-07-21 |
| 1199 | Sone/Wood/Glazing in Wall | 2012-06-14 → 2012-06-19 (+5d) | 2012-06-28 → 2012-07-03 (+5d) | baseline start none → 2012-06-14; baseline finish none → 2012-06-29 |
| 1200 | Stair/Other Railing | 2012-06-13 → 2012-06-18 (+5d) | 2012-06-28 → 2012-07-03 (+5d) | baseline start none → 2012-06-13; baseline finish none → 2012-06-29 |
| 1201 | Granite Flooring | 2012-06-30 → 2012-07-05 (+5d) | 2012-07-09 → 2012-07-15 (+6d) | baseline start none → 2012-06-30; baseline finish none → 2012-07-10 |
| 1202 | Resin Floor | 2012-06-28 → 2012-07-03 (+5d) | 2012-07-12 → 2012-07-18 (+6d) | baseline start none → 2012-06-28; baseline finish none → 2012-07-13 |
| 1203 | Fire Door Installation | 2012-07-09 → 2012-07-14 (+5d) | 2012-07-15 → 2012-07-21 (+6d) | baseline start none → 2012-07-09; baseline finish none → 2012-07-16 |
| 1204 | Painting | 2012-07-05 → 2012-07-10 (+5d) | 2012-07-19 → 2012-07-25 (+6d) | baseline start none → 2012-07-05; baseline finish none → 2012-07-20 |
| 1205 | **MACHINE FLOOR** | 2012-06-23 → 2012-06-28 (+5d) | 2012-08-01 → 2012-08-07 (+6d) | baseline start none → 2012-06-23; baseline finish none → 2012-08-02 |
| 1206 | Brick Work | 2012-06-23 → 2012-06-28 (+5d) | 2012-06-29 → 2012-07-05 (+6d) | baseline start none → 2012-06-23; baseline finish none → 2012-06-30 |
| 1207 | Plaster | 2012-06-30 → 2012-07-05 (+5d) | 2012-07-04 → 2012-07-10 (+6d) | baseline start none → 2012-06-30; baseline finish none → 2012-07-05 |
| 1208 | Painting | 2012-07-26 → 2012-07-31 (+5d) | 2012-08-01 → 2012-08-07 (+6d) | baseline start none → 2012-07-26; baseline finish none → 2012-08-02 |
| 1209 | **Sweeming Pool** | 2012-06-23 → 2012-06-28 (+5d) | 2012-07-23 → 2012-07-29 (+6d) | baseline start none → 2012-06-23; baseline finish none → 2012-07-24 |
| 1210 | Deshuttering | 2012-06-23 → 2012-06-28 (+5d) | 2012-06-23 → 2012-06-29 (+6d) | baseline start none → 2012-06-23; baseline finish none → 2012-06-24 |
| 1211 | Making Steps | 2012-06-24 → 2012-06-29 (+5d) | 2012-06-26 → 2012-07-02 (+6d) | baseline start none → 2012-06-24; baseline finish none → 2012-06-27 |
| 1212 | Water Proofing | 2012-06-27 → 2012-07-02 (+5d) | 2012-07-06 → 2012-07-12 (+6d) | baseline start none → 2012-06-27; baseline finish none → 2012-07-07 |
| 1213 | Lean Concrete | 2012-07-07 → 2012-07-12 (+5d) | 2012-07-07 → 2012-07-13 (+6d) | baseline start none → 2012-07-07; baseline finish none → 2012-07-08 |
| 1214 | Granaite Plaster | 2012-07-08 → 2012-07-13 (+5d) | 2012-07-10 → 2012-07-16 (+6d) | baseline start none → 2012-07-08; baseline finish none → 2012-07-11 |
| 1215 | Tile Work | 2012-07-11 → 2012-07-16 (+5d) | 2012-07-20 → 2012-07-26 (+6d) | baseline start none → 2012-07-11; baseline finish none → 2012-07-21 |
| 1216 | MEP Fittings | 2012-07-21 → 2012-07-26 (+5d) | 2012-07-23 → 2012-07-29 (+6d) | baseline start none → 2012-07-21; baseline finish none → 2012-07-24 |
| 1217 | **Planter Box** | 2012-07-05 → 2012-07-10 (+5d) | 2012-07-28 → 2012-08-03 (+6d) | baseline start none → 2012-07-05; baseline finish none → 2012-07-29 |
| 1218 | Water Proofing | 2012-07-05 → 2012-07-10 (+5d) | 2012-07-14 → 2012-07-20 (+6d) | baseline start none → 2012-07-05; baseline finish none → 2012-07-15 |
| 1219 | Making Bed For Plantation | 2012-07-15 → 2012-07-20 (+5d) | 2012-07-21 → 2012-07-27 (+6d) | baseline start none → 2012-07-15; baseline finish none → 2012-07-22 |
| 1220 | Plantation | 2012-07-22 → 2012-07-27 (+5d) | 2012-07-28 → 2012-08-03 (+6d) | baseline start none → 2012-07-22; baseline finish none → 2012-07-29 |
| 1221 | **Open Terrace** | 2012-07-05 → 2012-07-10 (+5d) | 2012-07-24 → 2012-07-30 (+6d) | baseline start none → 2012-07-05; baseline finish none → 2012-07-25 |
| 1222 | Water Proofing | 2012-07-05 → 2012-07-10 (+5d) | 2012-07-14 → 2012-07-20 (+6d) | baseline start none → 2012-07-05; baseline finish none → 2012-07-15 |
| 1223 | Paver Fixing | 2012-07-15 → 2012-07-20 (+5d) | 2012-07-24 → 2012-07-30 (+6d) | baseline start none → 2012-07-15; baseline finish none → 2012-07-25 |
| 1224 | **TOP ROOF SLAB** | 2012-07-05 → 2012-07-10 (+5d) | 2012-07-24 → 2012-07-30 (+6d) | baseline start none → 2012-07-05; baseline finish none → 2012-07-25 |

| ID | Task | Start | Finish | Duration | Total float | Other |
| --- | --- | --- | --- | --- | --- | --- |
| 1225 | Water proofing | 2012-07-05 → 2012-07-10 (+5d) | 2012-07-14 → 2012-07-20 (+6d) |  |  | baseline start none → 2012-07-05; baseline finish none → 2012-07-15 |
| 1226 | Paver Fixing | 2012-07-15 → 2012-07-20 (+5d) | 2012-07-24 → 2012-07-30 (+6d) |  |  | baseline start none → 2012-07-15; baseline finish none → 2012-07-25 |
| 1227 | **MEP WORKS** | 2011-04-18 → 2011-03-04 (-45d) | 2012-07-19 → 2012-07-25 (+6d) | 443d → 493d |  | baseline start none → 2011-04-18; baseline finish none → 2012-07-20 |
| 1228 | BASEMENT-3 | 2011-04-18 → 2011-03-04 (-45d) | 2011-06-16 → 2011-05-03 (-44d) |  | 382d → 432d | baseline start none → 2011-04-18; baseline finish none → 2011-06-17 |
| 1229 | BASEMENT-2 | 2011-05-12 → 2011-04-13 (-29d) | 2011-07-10 → 2011-06-12 (-28d) |  | 358d → 392d | baseline start none → 2011-05-12; baseline finish none → 2011-07-11 |
| 1230 | BASEMENT-1 | 2011-06-06 → 2011-06-11 (+5d) | 2011-08-04 → 2011-08-10 (+6d) |  |  | baseline start none → 2011-06-06; baseline finish none → 2011-08-05 |
| 1231 | GROUND FLOOR | 2011-07-15 → 2011-07-20 (+5d) | 2011-08-13 → 2011-08-19 (+6d) |  |  | baseline start none → 2011-07-15; baseline finish none → 2011-08-14 |
| 1232 | 1ST FLOOR | 2011-07-26 → 2011-07-31 (+5d) | 2011-08-24 → 2011-09-07 (+14d) |  |  | baseline start none → 2011-07-26; baseline finish none → 2011-08-25 |
| 1233 | 2ND FLOOR | 2011-08-20 → 2011-08-25 (+5d) | 2011-09-26 → 2011-10-02 (+6d) |  |  | baseline start none → 2011-08-20; baseline finish none → 2011-09-27 |
| 1234 | 3RD FLOOR | 2011-09-22 → 2011-09-27 (+5d) | 2011-10-21 → 2011-10-27 (+6d) |  |  | baseline start none → 2011-09-22; baseline finish none → 2011-10-22 |
| 1235 | 4TH FLOOR | 2011-10-17 → 2011-10-22 (+5d) | 2011-11-23 → 2011-11-29 (+6d) |  |  | baseline start none → 2011-10-17; baseline finish none → 2011-11-24 |
| 1236 | 5TH FLOOR | 2011-11-19 → 2011-11-24 (+5d) | 2011-12-18 → 2011-12-24 (+6d) |  |  | baseline start none → 2011-11-19; baseline finish none → 2011-12-19 |
| 1237 | 6TH FLOOR | 2011-12-14 → 2011-12-19 (+5d) | 2012-01-12 → 2012-01-18 (+6d) |  |  | baseline start none → 2011-12-14; baseline finish none → 2012-01-13 |
| 1238 | 7TH FLOOR | 2012-01-08 → 2012-01-13 (+5d) | 2012-02-06 → 2012-02-12 (+6d) |  |  | baseline start none → 2012-01-08; baseline finish none → 2012-02-07 |
| 1239 | 8TH FLOOR | 2012-02-14 → 2012-02-19 (+5d) | 2012-03-14 → 2012-03-20 (+6d) |  |  | baseline start none → 2012-02-14; baseline finish none → 2012-03-15 |
| 1240 | 9TH FLOOR | 2012-02-27 → 2012-03-03 (+5d) | 2012-03-27 → 2012-04-02 (+6d) |  |  | baseline start none → 2012-02-27; baseline finish none → 2012-03-28 |
| 1241 | 10 TH FLOOR | 2012-03-23 → 2012-03-28 (+5d) | 2012-04-21 → 2012-04-27 (+6d) |  |  | baseline start none → 2012-03-23; baseline finish none → 2012-04-22 |
| 1242 | 11TH FLOOR | 2012-04-17 → 2012-04-22 (+5d) | 2012-05-16 → 2012-05-22 (+6d) |  |  | baseline start none → 2012-04-17; baseline finish none → 2012-05-17 |
| 1243 | 12TH FLOOR | 2012-05-12 → 2012-05-17 (+5d) | 2012-06-10 → 2012-06-16 (+6d) |  |  | baseline start none → 2012-05-12; baseline finish none → 2012-06-11 |
| 1244 | 13TH FLOOR | 2012-06-06 → 2012-06-11 (+5d) | 2012-07-05 → 2012-07-11 (+6d) |  |  | baseline start none → 2012-06-06; baseline finish none → 2012-07-06 |
| 1245 | MACHINE FLOOR | 2012-05-21 → 2012-05-26 (+5d) | 2012-07-19 → 2012-07-25 (+6d) |  |  | baseline start none → 2012-05-21; baseline finish none → 2012-07-20 |
| 1246 | MEP WORKS - OUTSIDE | 2012-05-21 → 2012-05-26 (+5d) | 2012-07-19 → 2012-07-25 (+6d) |  |  | baseline start none → 2012-05-21; baseline finish none → 2012-07-20 |
| 1247 | **OUTSIDE FINISHING** | 2012-06-01 → 2012-06-06 (+5d) | 2012-08-06 → 2012-08-12 (+6d) |  |  | baseline start none → 2012-06-01; baseline finish none → 2012-08-07 |
| 1248 | PLASTER REPAIR | 2012-06-01 → 2012-06-06 (+5d) | 2012-06-15 → 2012-06-21 (+6d) |  |  | baseline start none → 2012-06-01; baseline finish none → 2012-06-16 |
| 1249 | CURTAIN WALL | 2012-06-16 → 2012-06-21 (+5d) | 2012-07-30 → 2012-08-05 (+6d) |  |  | baseline start none → 2012-06-16; baseline finish none → 2012-07-31 |
| 1250 | TITANIUM | 2012-06-16 → 2012-06-21 (+5d) | 2012-06-30 → 2012-07-06 (+6d) |  |  | baseline start none → 2012-06-16; baseline finish none → 2012-07-01 |
| 1251 | LOUVER FIXING | 2012-07-31 → 2012-08-05 (+5d) | 2012-08-06 → 2012-08-12 (+6d) |  |  | baseline start none → 2012-07-31; baseline finish none → 2012-08-07 |
| 1252 | CLOSING SLAB AFTER TC DISMANTLING | 2012-06-04 → 2012-06-09 (+5d) | 2012-07-03 → 2012-07-09 (+6d) |  |  | baseline start none → 2012-06-04; baseline finish none → 2012-07-04 |
| 1253 | LAND SCAPING | 2012-07-05 → 2012-07-10 (+5d) | 2012-09-10 → 2012-09-18 (+8d) |  |  | baseline start none → 2012-07-05; baseline finish none → 2012-09-11 |
| 1254 | PROJECT COMPLETE | 2012-09-11 → 2012-09-18 (+7d) | 2012-09-11 → 2012-09-19 (+8d) |  |  | baseline start none → 2012-09-11; baseline finish none → 2012-09-12 |
